# CRONOGRAMA GENERAL CATACAOS fin

Schedule from MS Project, 2022-01-01 to 2022-06-29.

## Calendars

- Estándar: Mon-Sun 07:00-12:00.

## Resources

| Resource | Group | Unit | Rate | Cost per use |
| --- | --- | --- | --- | --- |
| TOPOGRAFO | Mano de Obra |  | 24.7 |  |
| OFICIAL | Mano de Obra |  | 19.12 |  |
| PEON | Mano de Obra |  | 17.28 |  |
| OPERARIO | Mano de Obra |  | 24.22 |  |
| ELABORACION IMPLEMENTACION Y ADMINISTRACION DEL PLAN DE SEGURIDAD Y SALUD EN EL TRABAJO | Mano de Obra |  | 500 |  |
| ALAMBRE NEGRO # 16 | Material | kg |  | 6 |
| ALAMBRE NEGRO # 8 | Material | kg |  | 6 |
| CLAVOS CON CABEZA DE 2 1/2" 3" 4" | Material | kg |  | 3.23 |
| ACERO CORRUGADO | Material | kg |  | 4.33 |
| PIEDRA DE 8" GRANDE | Material | m3 |  | 60 |
| PIEDRA CHANCADA DE 1/2" a 3/4" | Material | m3 |  | 85 |
| OVER 1" a 6" | Material | m3 |  | 75 |
| AFIRMADO PARA BASE MEJORADO | Material | m3 |  | 43.45 |
| ARENA GRUESA | Material | m3 |  | 38 |
| PIEDRA ZARANDEADA DE 1/2" PUESTO EN OBRA | Material | m3 |  | 60 |
| CILINDROS PARA DEPOSITOS DE BASURA | Material | u |  | 55.2 |
| BAÑO PORTATIL | Material |  |  | 556.71 |
| LADRILLO PARA TECHO 15 X 30 X 30 cm | Material | u |  | 2.36 |
| CEMENTO PORTLAND TIPO MS (42.5 kg) | Material | bls |  | 25.42 |
| PLANCHA DE ETERNIT DE 10 PIES GRIS | Material | pl |  | 40.76 |
| CAL (BOLSA X 20KG) | Material | bls |  | 11.78 |
| CINTA SEÑALADORA | Material |  |  | 0.09 |
| MALLA PROTECTORA | Material | rll |  | 75 |
| ESTERA | Material | u |  | 12.71 |
| PLAN PARA LA VIGILANCIA PREVENCION Y CONTROL DEL COVID- 19 EN EL TRABAJO | Material | glb |  | 7000 |
| HORMIGON | Material | m3 |  | 42 |
| AGUA | Material | m3 |  | 5 |
| CORDEL | Material |  |  | 0.39 |
| CORREA DE SEGURIDAD | Material | u |  | 29.2 |
| ANTEOJOS PARA SOLDAR | Material | u |  | 15.97 |
| CHALECOS PARA OBRA | Material | pza |  | 15.49 |
| BOTAS DE JEBE | Material | u |  | 18.5 |
| CASCO P/OBRA | Material | u |  | 28.66 |
| GUANTES DE JEBE | Material | pza |  | 8.32 |
| PROTECTOR DE OIDOS | Material | pza |  | 3.4 |
| MASCARA CONTRA POLVO | Material | pza |  | 5.47 |
| BOTAS DE CUERO CON PUNTA DE ACERO | Material | u |  | 40.56 |
| ARNES DE SEGURIDAD | Material | u |  | 145.67 |
| SUMINISTRO E INSTALACION DE COBERTURA METALICA AUTOSOPORTADA | Material | glb |  | 164480 |
| MADERA TORNILLO | Material | p2 |  | 5.43 |
| POSTES DE MADERA PARA CINTA | Material | u |  | 12 |
| TRIPLAY DE 4' X 8' X 4 mm | Material | pl |  | 20.59 |
| PINTURA ESMALTE | Material | gal |  | 40.85 |
| HERRAMIENTAS MANUALES | Equipo |  | 8 |  |
| MEZCLADORA DE CONCRETO TAMBOR 11 p3 22 HP | Equipo |  | 20 |  |
| CAMION VOLQUETE 6 X 4 330 HP 10 m3 | Equipo |  | 180 |  |
| WINCHE CON DOS BALDES 3.6 HP | Equipo |  | 26.38 |  |
| COMPRESORA NEUMATICA 93 HP 335-375 PCM | Equipo |  | 84.75 |  |
| RODILLO LISO AUTOPROPULSADO 70-100 HP 7-9 ton VIBRATORIO | Equipo |  | 150 |  |
| MARTILLO NEUMATICO - 25/29 KG | Equipo |  | 35 |  |
| RETROEXCAVADOR SOBRE LLANTAS 58 HP 1 yd3 | Equipo |  | 101.69 |  |
| TRACTOR DE ORUGAS DE 190-240 HP | Equipo |  | 210 |  |
| CARGADOR S/ LLANTAS 110-125 HP | Equipo |  | 125 |  |
| MARTILLO NEUMÁTICO - 93 HP - 335/375 PCM | Equipo |  | 25.42 |  |
| VIBRADOR DE CONCRETO 4 HP 1.50" | Equipo |  | 12 |  |
| MOTONIVELADORA DE 125 HP MAQUINARIA | Equipo |  | 120 |  |
| PLANCHA COMPACTADORA VIBRAT. 4.0 H.P. | Equipo |  | 15 |  |
| TEODOLITO | Equipo |  | 15 |  |
| LADRILLO KK TIPO IV 24X14X9cm (maquinado) |  |  | 8 |  |
| ARENA FINA |  |  | 8 |  |
| MADERA CEDRO |  |  | 8 |  |
| ANDAMIO METAL TABLAS ALQUILER |  |  | 8 |  |
| IMPERMEABILIZANTE LIQUIDO PARA CONCRETO |  |  | 8 |  |
| CRUCETA DE 3mm |  |  | 8 |  |
| FRAGUA DE COLOR |  |  | 8 |  |
| PEGAMENTO EN POLVO |  |  | 8 |  |
| PORCELANATO 60 x 60 MODELO POTENSA BLANCO PERLA MATE- ALTO TRANSITO |  |  | 8 |  |
| CERAMICO 45 x 45 MODELO CEMENTO BLANCO- ALTO TRANSITO |  |  | 8 |  |
| CERAMICA 60X60 DE ALTO TRANSITO |  |  | 8 |  |
| PINTURA ANTICORROSIVA |  |  | 8 |  |
| SOLDADORA ELECTRICA MONOFASICA ALTERNA 225 A |  |  | 8 |  |
| ELECTRODO TIPO 6011 - CELLOCORD |  |  | 8 |  |
| TUBO METALICO DE 50 X 100 X 4 mm |  |  | 8 |  |
| SELLO BUTYL DE 3/32" x3/4" |  |  | 8 |  |
| PERFIL "C" 3"X5 lb/pie |  |  | 8 |  |
| CALAMINON TAT 1060 TERMO-AISLANTE e=25mm |  |  | 8 |  |
| PLANCHA ACERO 6.4mm X 1.22m X 2.40 m |  |  | 8 |  |
| ANGULO DE ACERO LIVIANO DE 1" X 1" X 6mm X 6 m |  |  | 8 |  |
| TIRAFON DE 1/4" X 4" |  |  | 8 |  |
| ARANDELA DE 1/4" |  |  | 8 |  |
| SOMBRERO PARA TIRAFON DE 1/4" |  |  | 8 |  |
| CAPUCHON DE JEBE PARA TIRAFONES |  |  | 8 |  |
| LADRILLO PASTELERO 25 X 25 X 3 cm |  |  | 8 |  |
| ASFALTO LIQUIDO RC-250 |  |  | 8 |  |
| COLA SINTETICA |  |  | 8 |  |
| LIJA PARA MADERA # 80 |  |  | 8 |  |
| PERFIL "U" DE ALUMINIO 2"X2"X1mm |  |  | 8 |  |
| PERFIL "L" DE ALUMINIO 2"X2"X1mm |  |  | 8 |  |
| PLANCHA FORMICA ACRILICA COLOR BLANCO DE 1.20x2.40m |  |  | 8 |  |
| TRIPLAY LUPUNA DE 4' X 8' X 6 mm |  |  | 8 |  |
| PLANCHA ESTRIADA 1/8" |  |  | 8 |  |
| ANGULO DE FIERRO 2" X2" X 3/16" |  |  | 8 |  |
| PLATINA DE FIERRO 2 1/2" X 3/16" |  |  | 8 |  |
| PLATINA DE FIERRO 3/16" X 2" X 6m |  |  | 8 |  |
| CERRADURA 2 GOLPES TIPO FORTE |  |  | 8 |  |
| CERROJO 1/2"X1"X5" |  |  | 8 |  |
| BISAGRA CON EJE DE 5/8" |  |  | 8 |  |
| RUEDA CON SOPORTE Y GUIA |  |  | 8 |  |
| PLANCHA DE ACERO LAF 1/16" X4'X8' |  |  | 8 |  |
| PLATINA DE FIERRO 3/16" X 1" X 6m |  |  | 8 |  |
| ANGULO DE FIERRO 1/8" X1"X1" |  |  | 8 |  |
| BISAGRA ALUMINIZADA 2 1/2" X 2 1/2" |  |  | 8 |  |
| LIJA PARA FIERRO |  |  | 8 |  |
| CUERDA DE NYLON |  |  | 8 |  |
| TUBERIA DE F°N° 2"x3mm STANDARD |  |  | 8 |  |
| TUBERIA DE F°N° 3"x3mm STANDARD |  |  | 8 |  |
| TUBERIA DE F°N° 4"x3mm STANDARD |  |  | 8 |  |
| PLANCHA DE ACERO LAC 1/8" (3.3mm) |  |  | 8 |  |
| TUERCA |  |  | 8 |  |
| PERNO 1/2" X 3" CON TUERCA |  |  | 8 |  |
| ARANDELA 1/2" |  |  | 8 |  |
| TUBERIA FºGº 2"X3mm |  |  | 8 |  |
| TUBERIA FºGº 1 1/2"X3mm |  |  | 8 |  |
| LIJA DE FIERRO # 80 |  |  | 8 |  |
| PLANCHA F°G° e=1/20" |  |  | 8 |  |
| ALCAYATAS DE ACERO DE 1" |  |  | 8 |  |
| SILICONA 300 ml |  |  | 8 |  |
| CANALETA DE EVACUACION PLUVIAL 610mm |  |  | 8 |  |
| PROTECTOR DE VENTANA CON °F CUADRADO DE 1/2" |  |  | 8 |  |
| PLANCHA DE ACERO LAF 3/16" X4'X8' |  |  | 8 |  |
| TORNILLO DE FIJACION 1 1/2" |  |  | 8 |  |
| TARUGO 1/2" X 1 1/2" |  |  | 8 |  |
| BATERIA ECOLOGICA DE TRES TACHOS METALICOS |  |  | 8 |  |
| VENTANA DE FIERRO CON REJA DE SEGURIDAD |  |  | 8 |  |
| SOLDADORA A GASOLINA |  |  | 8 |  |
| TUBERIA FºGº 1 "X3mm |  |  | 8 |  |
| CODO DE ALUMINIO DE 30mm |  |  | 8 |  |
| TUBO DE ALUMINIO DE 30mm |  |  | 8 |  |
| ANGULO DE FIERRO 1/8" X 3/4"X3/4" |  |  | 8 |  |
| PERFIL TEE DE FIERRO 1/8"X3/4"X3/4" |  |  | 8 |  |
| PLANCHA GALVANIZADA DE FIERRO 1/8" |  |  | 8 |  |
| TUBO RECTANGULAR DE ALUMINIO 3 1/4" X 1"x1.5mm |  |  | 8 |  |
| TUBO RECTANGULAR DE ALUMINIO 2 3/8" X 1"x1.5mm |  |  | 8 |  |
| PLATINA DE ALUMINIO 1"x1.5mm |  |  | 8 |  |
| VENTANA CORREDIZA DE ALUMINIO SERIE 25 CON CRISTAL CRUDO DE 6mm + LAMINA DE SEGURIDAD DE 4 MICRAS (SEGUN DETALLE) |  |  | 8 |  |
| BISAGRA FIERRO ALUMINIZADO PESADO DE 4" |  |  | 8 |  |
| BISAGRA 3" |  |  | 8 |  |
| CERRADURA 3 GOLPES TIPO FORTE CON TIRADOR |  |  | 8 |  |
| CERRADURA EXTERIOR DE DOS GOLPES |  |  | 8 |  |
| CHAPA DE POMO CON PESTILLO DE PUERTA |  |  | 8 |  |
| PICAPORTE DE 2" |  |  | 8 |  |
| SELLADOR BLANCO PARA MUROS |  |  | 8 |  |
| PINTURA LATEX CON RESINA VINIL ACRILICA |  |  | 8 |  |
| ANDAMIO METALICO |  |  | 8 |  |
| AGUARRAS |  |  | 8 |  |
| BARNIZ MARINO |  |  | 8 |  |
| LACA SELLADORA PARA MADERA |  |  | 8 |  |
| SELLADOR ELASTOMERICO POLIURETANO (CARTUCHO DE 300 ml) |  |  | 8 |  |
| ESPUMA PLASTICA DURA A/DENSIDAD 2X1m E=2 |  |  | 8 |  |
| TECNOPORT e= 3/8" |  |  | 8 |  |
| SUBE Y BAJA CON CUATRO ASIENTOS |  |  | 8 |  |
| TOBOGAN |  |  | 8 |  |
| COLUMBIO METALICO L=230 M CON 3 ASIENTOS |  |  | 8 |  |
| PASAMANO METALICO L=4.00 M. |  |  | 8 |  |
| STICKER PARA SEÑALETICA DE SEGURIDAD |  |  | 8 |  |
| LAMPARA DE EMERGENCIA 24 LEDS |  |  | 8 |  |
| SUMINISTRO E INSTALACION DE BOTIQUIN |  |  | 8 |  |
| EXTINTOR DE POLVO QUIMICO SECO (PQS) - ABC DE 6 Kg |  |  | 8 |  |
| PEGAMENTO PARA TUBERIA PVC |  |  | 8 |  |
| TUBERIA PVC CLASE 10 SP 2" X 5m |  |  | 8 |  |
| REDUCCION PVC SAP PARA AGUA CON ROSCA 2" A 1 1/2" |  |  | 8 |  |
| TEE PVC SAP PARA AGUA CON ROSCA DE 2" |  |  | 8 |  |
| TUBERIA PVC CLASE 10 SP 1 1/2" X 5m |  |  | 8 |  |
| REDUCCION PVC SAP PARA AGUA CON ROSCA 1 1/2" A 1" |  |  | 8 |  |
| CODO PVC SAP PARA AGUA CON ROSCA DE 1 1/2" X 90° |  |  | 8 |  |
| TEE PVC SAP PARA AGUA CON ROSCA DE 1 1/2" |  |  | 8 |  |
| TUBERIA PVC CLASE 10 ROSCADO 1" X 5M |  |  | 8 |  |
| REDUCCION PVC SAP PARA AGUA CON ROSCA 1 1/2" A 3/4" |  |  | 8 |  |
| CODO PVC SAP - CLASE 10 SP - 1" X 90 |  |  | 8 |  |
| TEE PVC SAP CLASE 10 SP 1" |  |  | 8 |  |
| TUBERIA PVC CLASE 10 SP 3/4" X 5M |  |  | 8 |  |
| REDUCCION PVC SAP PARA AGUA CON ROSCA 3/4" A 1/2" |  |  | 8 |  |
| CODO PVC SAP - CLASE 10 SP - 3/4" X 90 |  |  | 8 |  |
| TEE PVC SAP CLASE 10 SP 3/4" |  |  | 8 |  |
| CINTA TEFLON |  |  | 8 |  |
| CODO FIERRO GALVANIZADO 1 1/2" X 90° |  |  | 8 |  |
| VALVULAS TIPO BOLA 1 1/2" |  |  | 8 |  |
| TEE DE FIERRO GALVANIZADO 1 1/2" |  |  | 8 |  |
| UNION UNIVERSAL DE Fº Gº DE 1 1/2" |  |  | 8 |  |
| NIPLE DE FIERRO GALVANIZADO DE 1 1/2" X 5" |  |  | 8 |  |
| NIPLE DE FIERRO GALVANIZADO DE 1 1/2" X 10" |  |  | 8 |  |
| CAJA PREFABRICADA DE CONCRETO C/TAPA PARA VALVULAS |  |  | 8 |  |
| GRIFO BRONCE 1/2" |  |  | 8 |  |
| TUBO PVC SAL -4" (3m) |  |  | 8 |  |
| UNION PVC SAL 4" |  |  | 8 |  |
| LUBRICANTE PARA TUBO PVC |  |  | 8 |  |
| TUBERIA PVC 160mm ISO 4435 S-20 |  |  | 8 |  |
| CODO PVC 160mmX45 |  |  | 8 |  |
| ANILLO DE JEBE A-7.5 DE 160mm |  |  | 8 |  |
| CAJA PREFABRICADA DE CONCRETO C/TAPA 12" X 24" |  |  | 8 |  |
| CAJA PREFABRICADA DE CONCRETO C/TAPA 24" X 24" |  |  | 8 |  |
| INODORO TANQUE BAJO NORMAL BLANCO INCLUYE ACCESORIOS |  |  | 8 |  |
| TAPA PARA INODORO TIPO MELIMEX |  |  | 8 |  |
| URINARIO PICO COLOR INC. ACCESORIOS |  |  | 8 |  |
| GRIFERIA PARA URINARIO DE PICO |  |  | 8 |  |
| LLAVE DE LAVATORIO STANDAR |  |  | 8 |  |
| LAVATORIO LOZA BLANCA (SEGUN DISEÑO INC. ACCESORIOS) |  |  | 8 |  |
| GRIFERIA PARA LAVADERO |  |  | 8 |  |
| PORCELANA BLANCA |  |  | 8 |  |
| DISPENSADOR DE JABON LIQUIDO |  |  | 8 |  |
| PAPELERA DE LOSA BLANCA 15 X 15 cm |  |  | 8 |  |
| CANTONERAS DE PVC |  |  | 8 |  |
| PLANCHA DE MELAMINA SOFT DE COLOR 18mm |  |  | 8 |  |
| ANGULO DE ACERO LIVIANO DE 3" X 3" X 3/16" |  |  | 8 |  |
| TORNILLO DE FIJACION 2" C/TARUGOS DE PLASTICO |  |  | 8 |  |
| TRAMPA DE GRASA TIPO HEVEX MODELO IG-20 |  |  | 8 |  |
| ESPEJO BISELADO |  |  | 8 |  |
| PAPELERA PLASTICA |  |  | 8 |  |
| LLAVE DE LAVADERO PICO GIRATORIO |  |  | 8 |  |
| LAVADERO DE ACERO INOXIDABLE CON ESCURRIDERO |  |  | 8 |  |
| TUBO DE ABASTO 1/2" X 1/2" CORRUGADO |  |  | 8 |  |
| TUBO PVC SAL - 2" (3m) |  |  | 8 |  |
| CODO PVC SAL 2" X 90° |  |  | 8 |  |
| CODO PVC SAL 4" X 90° |  |  | 8 |  |
| YEE PVC SAL DE 2" X 2" |  |  | 8 |  |
| YEE PVC SAL DE 4" X 4" |  |  | 8 |  |
| TEE SANITARIA SIMPLE PVC SAL DE 4" |  |  | 8 |  |
| TUBO PVC - SAL - 2" (3M) |  |  | 8 |  |
| REGISTRO DE BRONCE DE 4" ROSCADO |  |  | 8 |  |
| REGISTRO DE BRONCE DE 2" |  |  | 8 |  |
| YESO EN BOLSAS DE 28 kg |  |  | 8 |  |
| HIPOCLORITO DE CALCIO AL 70% |  |  | 8 |  |
| TUBERIA PVC CLASE 10 SP 1/2" X 5M |  |  | 8 |  |
| CODO PVC SAP - CLASE 10 SP - 1/2" X 90 |  |  | 8 |  |
| TEE PVC SAP CLASE 10 SP 1/2" |  |  | 8 |  |
| UNION SIMPLE PVC SAP CLASE 10 SP 1/2" |  |  | 8 |  |
| UNION SIMPLE PVC SAP CLASE 10 SP 3/4" |  |  | 8 |  |
| UNION UNIVERSAL DE Fº Gº DE 3/4" |  |  | 8 |  |
| NIPLE FºGº 1/2" X 1 1/4" |  |  | 8 |  |
| VALVULA COMPUERTA 3/4" |  |  | 8 |  |
| CAJA DE MADERA P/VALVULA |  |  | 8 |  |
| BALDE PRUEBA TAPON ABRAZADERA Y ACCESORIOS |  |  | 8 |  |
| TUBERIA FºGº 3"X3.3mm |  |  | 8 |  |
| UNION UNIVERSAL DE FIERRO GALVANIZADO 3" |  |  | 8 |  |
| CODO DE FIERRO GALVANIZADO CACHIMBA DE 3" X 90° |  |  | 8 |  |
| CODO PVC SAP PARA AGUA CON ROSCA DE 2" X 90° |  |  | 8 |  |
| TUBERIA PVC CLASE 10 SP 2 1/2" X 5m |  |  | 8 |  |
| CODO PVC SAP PARA AGUA CON ROSCA DE 2 1/2" X 90° |  |  | 8 |  |
| TEE PVC SAP PARA AGUA CON ROSCA DE 2 1/2" |  |  | 8 |  |
| TUBERIA FºGº 2"X3.3mm |  |  | 8 |  |
| CODO FIERRO GALVANIZADO 2" X 90° |  |  | 8 |  |
| UNION SIMPLE DE FIERRO GALVANIZADO DE 2" |  |  | 8 |  |
| TUBERIA FºGº 1 1/2"X3.3mm |  |  | 8 |  |
| UNION SIMPLE DE FIERRO GALVANIZADO DE 1 1/2" |  |  | 8 |  |
| UNION UNIVERSAL DE Fº Gº DE 2" |  |  | 8 |  |
| NIPLE FºGº 2" X 2 1/2" |  |  | 8 |  |
| VALVULA CHECK DE BRONCE DE 2" |  |  | 8 |  |
| VALVULA CHECK DE BRONCE DE 1 1/2" |  |  | 8 |  |
| VALVULA COMPUERTA 2" |  |  | 8 |  |
| NIPLE DE FIERRO GALVANIZADO DE 1 1/2" X 3" |  |  | 8 |  |
| VALVULA COMPUERTA 1 1/2" |  |  | 8 |  |
| CODO FIERRO GALVANIZADO 1/2" X 90° |  |  | 8 |  |
| TEE DE FIERRO GALVANIZADO DE 1/2" |  |  | 8 |  |
| UNION UNIVERSAL DE Fº Gº DE 1/2" |  |  | 8 |  |
| NIPLE DE FIERRO GALVANIZADO DE 1/2" X 5" |  |  | 8 |  |
| NIPLE DE FIERRO GALVANIZADO DE 1/2" X 10" |  |  | 8 |  |
| VALVULA COMPUERTA 1/2" |  |  | 8 |  |
| VALVULA FLOTADORA 1 1/2" |  |  | 8 |  |
| CODO FIERRO GALVANIZADO 3/4" X 90° |  |  | 8 |  |
| VALVULA FLOTADORA DE 3/4" |  |  | 8 |  |
| NIPLE DE FIERRO GALVANIZADO DE 3/4" X 5" |  |  | 8 |  |
| NIPLE DE FIERRO GALVANIZADO DE 3/4" X 10" |  |  | 8 |  |
| REJILLA Y MARCO DE FIERRO 1" |  |  | 8 |  |
| CONDUCTOR NH-80 1X2.5mm2 |  |  | 8 |  |
| CONDUCTOR NH-80 1X4mm2 |  |  | 8 |  |
| TUBO PVC - P ( ELECT. ) 20mm |  |  | 8 |  |
| ELECTROBOMBA 1.5 HP ALTA PRESION 2"X11/2" |  |  | 8 |  |
| CAJA GALVANIZADA RECT. PESADA 4"X2"X2 1/4" |  |  | 8 |  |
| TABLERO ALTERNADOR DE BOMBAS 1.9 HP TRIFASICO |  |  | 8 |  |
| CONTROL AUTOMATICO PARA CISTERNA |  |  | 8 |  |
| ANGULO DE FIERRO 1" X1" X 3/16" |  |  | 8 |  |
| PLANCHA ESTRIADA 4'X8'X1/16" |  |  | 8 |  |
| TAPA DE FIERRO |  |  | 8 |  |
| CODO FIERRO GALVANIZADO 2 1/2" X 90° |  |  | 8 |  |
| REDUCCION PVC SAP 4 A 2" |  |  | 8 |  |
| SOMBRERO DE VENTILACION PVC SAL 2" |  |  | 8 |  |
| REJILLA DE BRONCE DIAMETRO 2" ROSCADO |  |  | 8 |  |
| TUBERIA FºGº 4"X3.3mm |  |  | 8 |  |
| CODO FIERRO GALVANIZADO 4" X 90° |  |  | 8 |  |
| SOMBRERO DE VENTILACION PVC SAL 4" |  |  | 8 |  |
| TORNILLO DE FIJACION 1" |  |  | 8 |  |
| TUBO PVC SAP - 110 mm CLASE 7.5(5m) |  |  | 8 |  |
| ABRAZADERA DE FIERRO GALVANIZADO CON DOS OREJAS 4" (INC. TARUGOS) |  |  | 8 |  |
| CODO PVC SAP - CLASE 10 SP - 110 mm X 90 |  |  | 8 |  |
| TUBERIA PVC UF 200mm ISO 4435 S-20 |  |  | 8 |  |
| ANILLO JEBE NARANJA PARA TUBO 200mm |  |  | 8 |  |
| CAJA PREFABRICADA DE CONCRETO C/TAPA 18" X 24" |  |  | 8 |  |
| CACHIMBA PVC 200mmX160MMx45 y accesorios |  |  | 8 |  |
| CONDUCTOR DE Cu DE 1-1x10mm2 N2XOH BLANCO |  |  | 8 |  |
| CONDUCTOR DE Cu DE 2.5 mm2 NH-80 VERDE |  |  | 8 |  |
| CONDUCTOR DE Cu DE 2.5 mm2 NH-80 BLANCO |  |  | 8 |  |
| CONDUCTOR DE Cu DE 2.5 mm2 NH-80 NEGRO |  |  | 8 |  |
| CONDUCTOR DE Cu DE 4 mm2 NH-80 BLANCO |  |  | 8 |  |
| CONDUCTOR DE Cu DE 4 mm2 NH-80 NEGRO |  |  | 8 |  |
| CONDUCTOR DE Cu DE 4 mm2 NH-80 VERDE |  |  | 8 |  |
| CONDUCTOR DE Cu DE 10 mm2 NH-80 VERDE |  |  | 8 |  |
| CONDUCTOR DE Cu DESNUDO DE 25 mm2 |  |  | 8 |  |
| TUBO PVC - P ( ELECT. ) 20mm 3M |  |  | 8 |  |
| CURVA PVC - P ( ELECT. ) 20mm |  |  | 8 |  |
| UNION PVC - P ( ELECT. ) 20mm |  |  | 8 |  |
| TUBO PVC - P ( ELECT. ) 25mm 3M |  |  | 8 |  |
| CURVA PVC - P ( ELECT. ) 25mm |  |  | 8 |  |
| UNION PVC - P ( ELECT. ) 25mm |  |  | 8 |  |
| TUBO PVC - P ( ELECT. ) 35mm 3M |  |  | 8 |  |
| CURVA PVC - P ( ELECT. ) 35mm |  |  | 8 |  |
| UNION PVC - P ( ELECT. ) 35mm |  |  | 8 |  |
| TUBO PVC - P ( ELECT. ) 40mm 3M |  |  | 8 |  |
| CURVA PVC - P ( ELECT. ) 40mm |  |  | 8 |  |
| UNION PVC - P ( ELECT. ) 40mm |  |  | 8 |  |
| CAJA DE DERIVACION GALVANIZADA 200 x 200 X 150 |  |  | 8 |  |
| TUBO CONDUIT DE 20mm |  |  | 8 |  |
| TUBO FLEXIBLE CONDUIT C/FORRO DE PVC 20mm |  |  | 8 |  |
| CURVA CONDUIT EMT 20mm |  |  | 8 |  |
| CONECTOR CONDUIT EMT 20mm |  |  | 8 |  |
| CONECTOR HERMETICO EMT 20mm |  |  | 8 |  |
| TERMINAL EMT 20mm |  |  | 8 |  |
| CAJA RECTANGULAR DE ALUMINIO DE 4 AGUJEROS DE 20mm |  |  | 8 |  |
| CAJA REDONDA DE 4 AGUJEROS DE 20mm |  |  | 8 |  |
| CINTA AISLANTE |  |  | 8 |  |
| LUMINARIA SHREDER ISLA LD 51W5096 O EQUIVALENTE P/POSTE 60MM |  |  | 8 |  |
| SmartLED Office W60L60 - PHILLIPS (LUMINARIA ADOSADA) 4 LAMPARAS |  |  | 8 |  |
| SmartLED Office W30L120 - PHILLIPS (LUMINARIA ADOSADA) 2 LAMPARAS |  |  | 8 |  |
| INDIKO FORYIMO LED - PHILLIPS (LUMINARIA HERMÉTICA) 2 LAMPARA |  |  | 8 |  |
| BERYL ADOSADA LED 15W |  |  | 8 |  |
| Reflector Josfel Hall Ligth Led 250W asimétrico o EQUIVALENTE |  |  | 8 |  |
| CAJA OCTOGONAL F°G° DE 100mm x 55mm |  |  | 8 |  |
| INTERRUPTOR SIMPLE UNIPOLAR |  |  | 8 |  |
| INTERRUPTOR DOBLE UNIPOLAR |  |  | 8 |  |
| INTERRUPTOR TRIPLE UNIPOLAR |  |  | 8 |  |
| INTERRUPTOR DE CONMUTACION SIMPLE |  |  | 8 |  |
| TOMACORRIENTE DOBLE C/T |  |  | 8 |  |
| CAJA RECTANGULAR F°G° DE 100 x 55 x 50mm |  |  | 8 |  |
| SUMINISTRO E INSTALACION DE TIMBRE (CHICHARRA) + PULSADOR |  |  | 8 |  |
| TABLERO ELECTRICO DE F°G° EMPOTRADO 8 POLOS |  |  | 8 |  |
| TABLERO ELECTRICO DE F°G° EMPOTRADO 18 POLOS |  |  | 8 |  |
| TABLERO ELECTRICO DE F°G° EMPOTRADO 32 POLOS |  |  | 8 |  |
| INTERRUPTOR THERMOMAGNETICO 2X20 A |  |  | 8 |  |
| INTERRUPTOR THERMOMAGNETICO 2X35A |  |  | 8 |  |
| INTERRUPTOR DIFERENCIAL 2 X 20A - 30mA |  |  | 8 |  |
| INTERRUPTOR DIFERENCIAL 2x25 A/30mm A |  |  | 8 |  |
| PULSADOR LUMINOSO NA 220V IP66 |  |  | 8 |  |
| CONTACTOR TRIFASICO 25A |  |  | 8 |  |
| SUMINISTRO E INSTALACION DE POSTE DE F°G° DE 4m |  |  | 8 |  |
| CEMENTO BLANCO BOLSA 50 kg |  |  | 8 |  |
| MARMOLINA |  |  | 8 |  |
| GRANALLA |  |  | 8 |  |
| CABLE TW # 2 AWG - 35 mm2 |  |  | 8 |  |
| TUBERIA PVC SAP PARA INSTALACIONES ELECTRICAS DE 1" |  |  | 8 |  |
| TIERRA DE CHACRA O VEGETAL |  |  | 8 |  |
| VARILLA DE COBRE DE 1/2" X 2.40 m |  |  | 8 |  |
| MARCO Y TAPA FIERRO GALVANIZADO PARA MEDIDOR 1/2" - 3/4" |  |  | 8 |  |
| CURVA PVC SAP PESADO PARA INSTALACIONES ELECTRICAS DE 1" |  |  | 8 |  |
| BUZON PARA PARA SISTEMA ELECTRICO |  |  | 8 |  |
| TABLERO DE CONTROL DE ELECTROBOMBA |  |  | 8 |  |
| ALTERNOR DE ELECTROBOMBA |  |  | 8 |  |
| INTERRUPTOR DE CONTROL DE NIVEL DE AGUA |  |  | 8 |  |
| CONTROLES DE ARRANQUE Y PARADA |  |  | 8 |  |
| TRANSPORTE DE MATERIALES ELECTRICOS (3% DE MATERIALES) |  |  | 8 |  |
| CAJA DE CONEXION DE SUMINISTRO |  |  | 8 |  |
| CAJA PORTAMEDIDOR |  |  | 8 |  |
| MEDIDOR DE ENERGIA ELECTRICA |  |  | 8 |  |
| CAJA PORTA - INTERRUPTOR DE 30A |  |  | 8 |  |
| AULA PROVISIONAL DRYWALL(INC. VENTANAS PUERTAS VIDRIOS TECHO CALAMINON Y ACCES.) |  |  | 8 |  |
| COMEDOR PROVISIONAL EN DRYWALL(INC. PUERTAS VENTANAS VIDRIOS TECHOS CALAMINON Y ACCESORIOS) |  |  | 8 |  |
| AMBIENTE ADMINISTRATIVO PROVISIONAL EN DRYWALL(INC. VENTANAS PUERTAS VIDRIOS TECHO CALAMINON Y ACCESORIOS) |  |  | 8 |  |
| CLAVOS PARA MADERA CON CABEZA DE 2 1/2" |  |  | 8 |  |
| MADERA MACHIHEMBRADA TORNILLO |  |  | 8 |  |
| CANDADO DE BRONCE FORTE 60 mm |  |  | 8 |  |
| PORTON METALICO |  |  | 8 |  |
| BAÑO PORTATIL INICIAL |  |  | 8 |  |
| BAÑO PORTATIL PRIMARIA |  |  | 8 |  |
| BAÑO PORTATIL DOCENTES |  |  | 8 |  |
| LAVADERO CON PEDAL INC. BASE METALICA |  |  | 8 |  |
| SUMINISTRO E INSTALACION DE TANQUE ELEVADO DE 1100 LTS Y ACCES. |  |  | 8 |  |
| TUBO ABASTO ESPIGA COBRE TERM/H-H 1/2" X 1/2" 30 cm |  |  | 8 |  |
| GRIFERIA PARA LAVADERO DE ACERO INOXIDABLE |  |  | 8 |  |
| INST. ELECTRICAS GENERAL INC. CABLES Y ACCESORIOS. |  |  | 8 |  |
| FLETE |  |  | 8 |  |
| TRASLADO DE AULAS A ALMACEN |  |  | 8 |  |

## Schedule

| ID | WBS | Task | Duration | Start | Finish | Predecessors | Total slack | Free slack | Constraint | Resources | Work | Cost | Text1 | Text8 | Text2 | Text3 | Text4 | Text6 |
| --- | --- | --- | --- | --- | --- | --- | --- | --- | --- | --- | --- | --- | --- | --- | --- | --- | --- | --- |
| 1 | 1 | **ESTRUCTURAS** | 102d? | 2022-01-01 | 2022-06-13 |  | 10d |  |  |  | 13229.8h | 1,864,697.43 | 01 | 000000000000001 |  |  |  |  |
| 2 | 1.1 | **OBRAS PROVISIONALES** | 10d? | 2022-01-01 | 2022-01-17 |  | 85d | 0d |  |  | 274.25h | 92,075.72 | 01.01 | 000000000000002 |  |  |  |  |
| 3 | 1.1.1 | ALMACÉN, OFICINAS | 4d? | 2022-01-01 | 2022-01-07 |  | 91d |  | start no earlier than 2022-01-01 | PEON [90%]; OPERARIO [90%]; CLAVOS CON CABEZA DE 2 1/2" 3" 4" [9 kg]; MADERA TORNILLO [32.4 p2]; PLANCHA DE ETERNIT DE 10 PIES GRIS [2.52 pl]; TRIPLAY DE 4' X 8' X 4 mm [6.84 pl] | 57.6h | 2,908.97 | 01.01.01 | 000000000000003 | 36 | 45.66 | 1643.76 | 10 |
| 4 | 1.1.2 | CARTEL DE OBRA DE 3.60 X 2.40 m | 1d? | 2022-01-01 | 2022-01-02 |  | 94d |  | start no earlier than 2022-01-01 | CEMENTO PORTLAND TIPO MS (42.5 kg) [1.28 bls]; PINTURA ESMALTE [0.5 gal]; PEON; OPERARIO [200%]; MEZCLADORA DE CONCRETO TAMBOR 11 p3 22 HP [33.3%]; ALAMBRE NEGRO # 16 [3.15 kg]; CLAVOS CON CABEZA DE 2 1/2" 3" 4" [0.25 kg]; PIEDRA DE 8" GRANDE [0.22 m3]; HORMIGON [0.38 m3]; AGUA [0.04 m3]; MADERA TORNILLO [70.11 p2]; TRIPLAY DE 4' X 8' X 4 mm [4 pl] | 26.66h | 1,947.18 | 01.01.02 | 000000000000004 |  | 1159.62 | 1159.62 |  |
| 5 | 1.1.3 | CERCO PROVISIONAL DE OBRA | 2d? | 2022-01-01 | 2022-01-04 |  | 93d |  | start no earlier than 2022-01-01 | PEON [182%]; ALAMBRE NEGRO # 16 [18.2 kg]; CLAVOS CON CABEZA DE 2 1/2" 3" 4" [18.2 kg]; MADERA TORNILLO [227.5 p2]; ESTERA [60.61 u] | 29.12h | 3,220.52 | 01.01.03 | 000000000000005 | 182 | 14.78 | 2689.96 | 100 |
| 6 | 1.1.4 | SERVICIOS HIGIÉNICOS | 2d? | 2022-01-01 | 2022-01-04 |  | 93d |  | start no earlier than 2022-01-01 | BAÑO PORTATIL [1000%] |  | 6,123.81 | 01.01.04 | 000000000000006 |  | 2783.55 | 5567.1 |  |
| 7 | 1.1.5 | ELABORACION, IMPLEMENTACION Y ADMINISTRACION DEL PLAN DE SEGURIDAD Y SALUD EN EL TRABAJO | 4d? | 2022-01-01 | 2022-01-07 |  | 91d |  | start no earlier than 2022-01-01 | ELABORACION IMPLEMENTACION Y ADMINISTRACION DEL PLAN DE SEGURIDAD Y SALUD EN EL TRABAJO [12.5%] | 4h | 4,000 | 01.01.05 | 000000000000007 |  | 500 | 2000 |  |
| 8 | 1.1.6 | SUMINISTRO DE DEPOSITOS DE BASURA | 3d? | 2022-01-01 | 2022-01-06 |  | 92d |  | start no earlier than 2022-01-01 | CILINDROS PARA DEPOSITOS DE BASURA [3 u] |  | 220.8 | 01.01.06 | 000000000000008 |  | 55.2 | 165.6 |  |
| 9 | 1.1.7 | SUMINISTRO DE IMPLEMENTOS DE SEGURIDAD | 1d? | 2022-01-01 | 2022-01-02 |  | 94d |  | start no earlier than 2022-01-01 | CHALECOS PARA OBRA [75 pza]; GUANTES DE JEBE [75 pza]; PROTECTOR DE OIDOS [75 pza]; MASCARA CONTRA POLVO [75 pza]; CORREA DE SEGURIDAD [75 u]; ANTEOJOS PARA SOLDAR [75 u]; BOTAS DE JEBE [35 u]; CASCO P/OBRA [75 u]; BOTAS DE CUERO CON PUNTA DE ACERO [75 u]; ARNES DE SEGURIDAD [35 u] |  | 17,087.44 | 01.01.07 | 000000000000009 |  | 16776.2 | 16776.2 |  |
| 10 | 1.1.8 | SEÑALIZACION TEMPORAL AMBIENTAL Y SEGURIDAD | 10d | 2022-01-01 | 2022-01-17 |  | 85d |  | start no earlier than 2022-01-01 | PEON [98%]; OPERARIO [98%]; CINTA SEÑALADORA [250000%]; MALLA PROTECTORA [50 rll]; POSTES DE MADERA PARA CINTA [120 u] | 156.86h | 14,567 | 01.01.08 | 000000000000010 |  | 2245 | 11225 | 0.3 |
| 11 | 1.1.9 | IMPLEMENTACION DE PLAN COVID | 5d? | 2022-01-01 | 2022-01-09 |  | 90d |  | start no earlier than 2022-01-01 | PLAN PARA LA VIGILANCIA PREVENCION Y CONTROL DEL COVID- 19 EN EL TRABAJO [5 glb] |  | 42,000 | 01.01.09 | 000000000000121 |  | 7000 | 35000 |  |
| 12 | 1.2 | **TRABAJOS PRELIMINARES** | 17d? | 2022-01-17 | 2022-02-13 | 2 | 85d | 0d |  |  | 228.31h | 17,908.45 | 01.02 | 000000000000011 |  |  |  |  |
| 13 | 1.2.1 | TRAZO Y REPLANTEO PRELIMINAR Y CONTROL PERMANENTE DE OBRA | 3d? | 2022-01-17 | 2022-01-22 |  | 99d |  | start no earlier than 2022-01-01 | CAL (BOLSA X 20KG) [101.5 bls]; TOPOGRAFO [42.3%]; PEON [169.2%]; TEODOLITO [42.3%]; CLAVOS CON CABEZA DE 2 1/2" 3" 4" [10.15 kg]; CORDEL [38571.9%]; MADERA TORNILLO [40.6 p2] | 60.9h | 3,866.05 | 01.02.01 | 000000000000012 | 2030.1 | 1.35 | 2740.64 | 800 |
| 14 | 1.2.2 | LIMPIEZA PERMANENTE Y FINAL DE OBRA | 17d? | 2022-01-17 | 2022-02-13 |  | 85d |  | start no earlier than 2022-01-01 | PEON | 135.41h | 4,735.37 | 01.02.02 | 000000000000013 | 2030.1 | 1.18 | 2395.52 | 120 |
| 15 | 1.2.3 | MOVILIZACION DE EQUIPO | 1d? | 2022-01-17 | 2022-01-18 |  | 101d |  | start no earlier than 2022-01-01 | RODILLO LISO AUTOPROPULSADO 70-100 HP 7-9 ton VIBRATORIO; RETROEXCAVADOR SOBRE LLANTAS 58 HP 1 yd3; TRACTOR DE ORUGAS DE 190-240 HP; MOTONIVELADORA DE 125 HP MAQUINARIA | 32h | 9,307.04 | 01.02.03 | 000000000000014 |  | 4653.52 | 4653.52 |  |
| 16 | 1.3 | **MITIGACION AMBIENTAL** | 10d? | 2022-02-23 | 2022-03-11 | 39 | 69d |  |  |  | 160h | 8,076.07 | 01.03 | 000000000000015 |  |  |  |  |
| 17 | 1.3.1 | RIEGO DE TERRENO, MATERIAL EXCAVADO Y AGREGADOS | 10d? | 2022-02-23 | 2022-03-11 |  | 69d |  | start no earlier than 2021-12-22 | PEON; AGUA [500 m3] | 80h | 5,269.8 | 01.03.01 | 000000000000016 |  | 3882.4 | 3882.4 | 0.1 |
| 18 | 1.3.2 | PREVENCION DE DAÑOS - DERRAME DE COMBUSTIBLES | 10d? | 2022-02-23 | 2022-03-11 |  | 69d |  | start no earlier than 2021-12-22 | PEON | 80h | 2,806.27 | 01.03.02 | 000000000000017 |  | 1423.87 | 1423.87 | 0.1 |
| 19 | 1.4 | **DESMONTAJES** | 9d? | 2022-01-17 | 2022-01-31 | 12SS | 93d | 0d |  |  | 417.29h | 16,020.64 | 01.04 | 000000000000018 |  |  |  |  |
| 20 | 1.4.1 | DESMONTAJE DE VENTANAS | 4d? | 2022-01-17 | 2022-01-23 |  | 98d |  | start no earlier than 2021-12-22 | OFICIAL [78.9%]; PEON [78.9%] | 50.47h | 1,864.94 | 01.04.01 | 000000000000019 | 63.09 | 15 | 946.35 | 20 |
| 21 | 1.4.2 | DESMONTAJE DE PUERTAS | 2d? | 2022-01-17 | 2022-01-20 |  | 100d |  | start no earlier than 2021-12-22 | OFICIAL [79.8%]; PEON [79.8%] | 25.54h | 943.56 | 01.04.02 | 000000000000020 | 39.9 | 12 | 478.8 | 25 |
| 22 | 1.4.3 | DESMONTAJE DE APARATOS SANITARIOS | 1d? | 2022-01-17 | 2022-01-18 |  | 101d |  | start no earlier than 2021-12-22 | PEON [26.7%]; OPERARIO [26.7%] | 4.27h | 179.73 | 01.04.03 | 000000000000021 |  | 22.8 | 91.2 | 15 |
| 23 | 1.4.4 | DESMONTAJE DE COBERTURAS DE PLANCHAS DE FIBROCEMENTO (INC. LA ESTRUCTURA DE SOPORTE) | 8d? | 2022-01-17 | 2022-01-30 |  | 94d |  | start no earlier than 2021-12-22 | PEON [195.2%]; OPERARIO [97.6%] | 187.42h | 7,455.62 | 01.04.04 | 000000000000022 | 234.27 | 16.15 | 3783.46 | 30 |
| 24 | 1.4.5 | DESMONTAJE DE TIJERALES METALICOS | 9d? | 2022-01-17 | 2022-01-31 |  | 93d |  | start no earlier than 2021-12-22 | OFICIAL [97.2%]; PEON [97.2%] | 140h | 5,172.41 | 01.04.05 | 000000000000024 | 52.5 | 49.99 | 2624.48 |  |
| 25 | 1.4.6 | DESMONTAJE DE PORTON ENTRADA PRINCIPAL | 1d? | 2022-01-17 | 2022-01-18 |  | 101d |  | start no earlier than 2021-12-22 | PEON [50%]; OPERARIO [50%] | 8h | 336.98 | 01.04.06 | 000000000000025 |  | 170.98 | 170.98 |  |
| 26 | 1.4.7 | DESMONTAJE DE TANQUE ELEVADO DE POLIETILENO | 1d? | 2022-01-17 | 2022-01-18 |  | 101d |  | start no earlier than 2021-12-22 | PEON [10%]; OPERARIO [10%] | 1.6h | 67.4 | 01.04.07 | 000000000000027 |  | 34.2 | 34.2 | 10 |

| ID | WBS | Task | Duration | Start | Finish | Predecessors | Total slack | Free slack | Constraint | Resources | Work | Cost | Text1 | Text8 | Text2 | Text3 | Text4 | Text6 |
| --- | --- | --- | --- | --- | --- | --- | --- | --- | --- | --- | --- | --- | --- | --- | --- | --- | --- | --- |
| 27 | 1.5 | **DEMOLICIÓN , REMOCION Y RASQUETEO** | 26d? | 2022-01-17 | 2022-02-27 | 19SS | 76d |  |  |  | 813.81h | 32,097.54 | 01.05 | 000000000000028 |  |  |  |  |
| 28 | 1.5.1 | DEMOLICIÓN DE PISO INC. C.P.- F.P. | 26d? | 2022-01-17 | 2022-02-27 |  | 76d |  | start no earlier than 2021-12-22 | PEON [98.5%] | 204.87h | 7,186.91 | 01.05.01 | 000000000000029 | 512.18 | 7.12 | 3646.72 | 20 |
| 29 | 1.5.2 | DEMOLICIÓN DE PISO DE SS.HH (INCLUYE TUBERIAS DE AGUA Y DESAGUE) | 1d? | 2022-01-17 | 2022-01-18 |  | 101d |  | start no earlier than 2021-12-22 | PEON [32.4%]; OPERARIO [3.2%]; COMPRESORA NEUMATICA 93 HP 335-375 PCM [16.2%]; MARTILLO NEUMÁTICO - 93 HP - 335/375 PCM [32.4%] | 6.75h | 455.61 | 01.05.02 | 000000000000030 | 16.22 | 14.09 | 228.54 | 50 |
| 30 | 1.5.3 | DEMOLICIÓN DE VEREDAS, PATIOS Y RAMPAS EXISTENTES | 23d? | 2022-01-17 | 2022-02-23 |  | 79d |  | start no earlier than 2021-12-22 | PEON | 183.35h | 6,434.36 | 01.05.03 | 000000000000031 | 343.8 | 9.5 | 3266.1 | 15 |
| 31 | 1.5.4 | DEMOLICIÓN DE MUROS DE LADRILLO KK (SOGA Y DE CANTO) | 19d? | 2022-01-17 | 2022-02-16 |  | 83d |  | start no earlier than 2021-12-22 | PEON [194.3%]; OPERARIO [9.7%] | 310.13h | 11,091.92 | 01.05.04 | 000000000000032 | 923.01 | 6.1 | 5630.36 | 50 |
| 32 | 1.5.5 | DEMOLICIÓN DE MUROS DE CONCRETO EN CISTERNA Y CASETA DE ELECTROBOMBA | 2d? | 2022-01-17 | 2022-01-20 |  | 100d |  | start no earlier than 2021-12-22 | PEON [104.8%]; OPERARIO [5.2%] | 17.61h | 629.7 | 01.05.05 | 000000000000033 | 26.2 | 12.2 | 319.64 | 25 |
| 33 | 1.5.6 | DEMOLICIÓN DE CIMIENTOS DE CONCRETO | 4d? | 2022-01-17 | 2022-01-23 |  | 98d |  | start no earlier than 2021-12-22 | PEON [90.3%]; OPERARIO [9%]; COMPRESORA NEUMATICA 93 HP 335-375 PCM [45.1%]; MARTILLO NEUMATICO - 25/29 KG [90.3%] | 75.1h | 5,625.1 | 01.05.06 | 000000000000034 | 65 | 43.4 | 2821 | 18 |
| 34 | 1.5.7 | DEMOLICION DE CAJAS DE DESAGUE | 1d? | 2022-01-17 | 2022-01-18 |  | 101d |  | start no earlier than 2021-12-22 | PEON; OPERARIO | 16h | 673.93 | 01.05.07 | 000000000000035 |  | 56.99 | 341.94 |  |
| 35 | 1.6 | **DESMONTAJE DEL SISTEMA ELECTRICO** | 2d? | 2022-01-17 | 2022-01-20 | 19SS | 34d | 0d |  |  | 44.8h | 1,887.14 | 01.06 | 000000000000036 |  |  |  |  |
| 36 | 1.6.1 | DESMONTAJE DE CENTROS DE LUZ (INCLUYE INTERRUPTORES) | 2d? | 2022-01-17 | 2022-01-20 |  | 34d |  | start no earlier than 2021-12-22 | PEON [83.3%]; OPERARIO [83.3%] | 26.66h | 1,123.3 | 01.06.01 | 000000000000037 | 25 | 22.8 | 570 | 15 |
| 37 | 1.6.2 | DESMONTAJE DE TOMACORRIENTES | 1d? | 2022-01-17 | 2022-01-18 |  | 35d |  | start no earlier than 2021-12-22 | PEON [80%]; OPERARIO [80%] | 12.8h | 539.2 | 01.06.02 | 000000000000038 | 16 | 17.1 | 273.6 | 20 |
| 38 | 1.6.3 | DESMONTAJE DE TABLEROS | 1d? | 2022-01-17 | 2022-01-18 |  | 35d |  | start no earlier than 2021-12-22 | PEON [33.3%]; OPERARIO [33.3%] | 5.33h | 224.64 | 01.06.03 | 000000000000039 |  | 56.99 | 113.98 |  |
| 39 | 1.7 | **MOVIMIENTO DE TIERRAS** | 21d? | 2022-01-20 | 2022-02-23 |  | 34d | 0d |  |  | 563.14h | 89,219.75 | 01.07 | 000000000000048 |  |  |  |  |
| 40 | 1.7.1 | **CORTE Y EXCAVACION** | 5d? | 2022-01-20 | 2022-01-28 | 35 | 34d | 0d |  |  | 139.84h | 18,521.36 | 01.07.01 | 000000000000049 |  |  |  |  |
| 41 | 1.7.1.1 | EXCAVACION DE ZANJAS PARA CIMENTACION (CIMIENTOS CORRIDOS , PLATEAS Y ZAPATAS) | 5d | 2022-01-20 | 2022-01-28 |  | 34d |  | start no earlier than 2021-12-22 | PEON [99.2%] | 39.68h | 9,727.05 | 01.07.01.01 | 000000000000050 | 253.97 | 35.6 | 9041.33 |  |
| 42 | 1.7.1.2 | CORTE DE MATERIAL SUELTO R=150 m3/dia (EQUIPO) | 4d? | 2022-01-20 | 2022-01-26 |  | 35d |  | start no earlier than 2021-12-22 | OFICIAL [19.6%]; PEON [195.6%]; RETROEXCAVADOR SOBRE LLANTAS 58 HP 1 yd3 [97.7%] | 100.16h | 8,794.31 | 01.07.01.02 | 000000000000051 | 586.74 | 7.52 | 4412.28 | 150 |
| 43 | 1.7.2 | **RELLENO** | 15d? | 2022-01-28 | 2022-02-21 | 40 | 69d | 0d |  |  | 300.89h | 48,190.36 | 01.07.02 | 000000000000052 |  |  |  |  |
| 44 | 1.7.2.1 | RELLENO COMPACTADO MANUAL MATERIAL PROPIO | 15d | 2022-01-28 | 2022-02-21 |  | 69d |  | start no earlier than 2021-12-22 | PEON [99.4%]; PLANCHA COMPACTADORA VIBRAT. 4.0 H.P. [24.9%] | 149.12h | 16,563.46 | 01.07.02.01 | 000000000000053 | 570.63 | 24.63 | 14054.62 |  |
| 45 | 1.7.2.2 | RELLENO COMPACTADO MANUAL MATERIAL DE PRESTAMO (AFIRMADO PREPARADO) | 10d | 2022-01-28 | 2022-02-13 |  | 74d |  | start no earlier than 2021-12-22 | PEON [97.5%]; OPERARIO [24.4%]; PLANCHA COMPACTADORA VIBRAT. 4.0 H.P. [24.4%]; AFIRMADO PARA BASE MEJORADO [471.57 m3]; AGUA [43.53 m3] | 117.03h | 29,592.75 | 01.07.02.02 | 000000000000054 | 362.75 | 75.62 | 27431.16 | 12 |
| 46 | 1.7.2.3 | RELLENO CON HORMIGON | 1d? | 2022-01-28 | 2022-01-30 |  | 83d |  | start no earlier than 2021-12-22 | OFICIAL [96.5%]; PEON [96.5%]; PLANCHA COMPACTADORA VIBRAT. 4.0 H.P. [241.2%]; HORMIGON [20.27 m3] | 34.74h | 2,034.15 | 01.07.02.03 | 000000000000055 | 19.3 | 73.66 | 1421.64 | 20 |
| 47 | 1.7.3 | **CONFORMACION,NIVELACION Y REFINE** | 5d? | 2022-01-20 | 2022-01-28 | 40SS | 85d |  |  |  | 62.31h | 3,226.62 | 01.07.03 | 000000000000056 |  |  |  |  |
| 48 | 1.7.3.1 | NIVELACION DE TERRENO Y COMPACTACION | 5d? | 2022-01-20 | 2022-01-28 |  | 85d |  | start no earlier than 2021-12-22 | PEON [89%]; OPERARIO [22.2%]; PLANCHA COMPACTADORA VIBRAT. 4.0 H.P. [44.6%]; AGUA [200.36 m3] | 62.31h | 3,226.62 | 01.07.03.01 | 000000000000057 | 667.88 | 3.18 | 2123.86 | 150 |
| 49 | 1.7.4 | **MEJORAMIENTO DE TERRENO** | 1d? | 2022-01-28 | 2022-01-30 | 43SS | 33d | 0d |  |  | 8.4h | 6,168.18 | 01.07.04 | 000000000000058 |  |  |  |  |
| 50 | 1.7.4.1 | MEJORAMIENTO DE TERRENO NATURAL e=40cm (COLOCACION DE OVER DE 1" A 6" - CON EQUIPO) | 1d? | 2022-01-28 | 2022-01-30 |  | 33d |  | start no earlier than 2021-12-22 | PEON [21%]; OPERARIO [21%]; RODILLO LISO AUTOPROPULSADO 70-100 HP 7-9 ton VIBRATORIO [21%]; TRACTOR DE ORUGAS DE 190-240 HP [21%]; MOTONIVELADORA DE 125 HP MAQUINARIA [21%]; OVER 1" a 6" [33.61 m3]; ARENA GRUESA [13.44 m3]; PIEDRA ZARANDEADA DE 1/2" PUESTO EN OBRA [20.17 m3] | 8.4h | 6,168.18 | 01.07.04.01 | 000000000000059 | 168.05 | 30.46 | 5118.8 | 800 |

| ID | WBS | Task | Duration | Start | Finish | Predecessors | Total slack | Free slack | Constraint | Resources | Work | Cost | Text1 | Text8 | Text2 | Text3 | Text4 | Text6 |
| --- | --- | --- | --- | --- | --- | --- | --- | --- | --- | --- | --- | --- | --- | --- | --- | --- | --- | --- |
| 51 | 1.7.5 | **ACARREO Y ELIMINACION DE MATERIAL** | 1d? | 2022-02-21 | 2022-02-23 | 43 | 69d |  |  |  | 51.69h | 13,113.24 | 01.07.05 | 000000000000060 |  |  |  |  |
| 52 | 1.7.5.1 | ELIMINACION DE MATERIAL EXCEDENTE CON MAQUINARIA (Dprom=5 km) | 1d? | 2022-02-21 | 2022-02-23 |  | 69d |  | start no earlier than 2021-12-22 | PEON [92.1%]; OPERARIO [92.1%]; CAMION VOLQUETE 6 X 4 330 HP 10 m3 [369.8%]; CARGADOR S/ LLANTAS 110-125 HP [92.1%] | 51.69h | 13,113.24 | 01.07.05.01 | 000000000000062 | 508.26 | 12.91 | 6561.64 | 550 |
| 53 | 1.8 | **CONCRETO SIMPLE** | 19d? | 2022-01-30 | 2022-03-01 | 40 | 33d |  |  |  | 1522.14h | 94,046.6 | 01.08 | 000000000000063 |  |  |  |  |
| 54 | 1.8.1 | **SOLADO** | 10d? | 2022-01-30 | 2022-02-15 | 49 | 33d | 0d |  |  | 782.98h | 42,442.6 | 01.08.01 | 000000000000064 |  |  |  |  |
| 55 | 1.8.1.1 | SOLADO PARA ZAPATA e=4", 1:12 C/H | 10d? | 2022-01-30 | 2022-02-15 |  | 33d |  | start no earlier than 2021-12-22 | CEMENTO PORTLAND TIPO MS (42.5 kg) [300.66 bls]; OFICIAL [97.9%]; PEON [587.2%]; OPERARIO [195.7%]; MEZCLADORA DE CONCRETO TAMBOR 11 p3 22 HP [97.9%]; HORMIGON [103.35 m3]; AGUA [9.4 m3] | 782.98h | 42,442.6 | 01.08.01.01 | 000000000000065 | 782.98 | 34.99 | 27396.47 | 80 |
| 56 | 1.8.2 | **FALSO PISO** | 5d? | 2022-02-15 | 2022-02-23 | 54 | 33d | 0d |  |  | 391.18h | 25,278.24 | 01.08.02 | 000000000000066 |  |  |  |  |
| 57 | 1.8.2.1 | FALSO PISO MEZCLA 1:8 e=4" | 5d? | 2022-02-15 | 2022-02-23 |  | 33d |  | start no earlier than 2021-12-22 | CEMENTO PORTLAND TIPO MS (42.5 kg) [264.03 bls]; OFICIAL [97.8%]; PEON [586.7%]; OPERARIO [195.5%]; MEZCLADORA DE CONCRETO TAMBOR 11 p3 22 HP [97.8%]; HORMIGON [70.41 m3]; AGUA [10.56 m3]; MADERA TORNILLO [58.67 p2] | 391.18h | 25,278.24 | 01.08.02.01 | 000000000000067 | 586.74 | 30.2 | 17719.55 | 120 |
| 58 | 1.8.3 | **CIMIENTOS** | 4d? | 2022-02-23 | 2022-03-01 | 56 | 33d | 0d |  |  | 347.98h | 26,325.77 | 01.08.03 | 000000000000068 |  |  |  |  |
| 59 | 1.8.3.1 | CIMIENTOS CORRIDOS 1:10 + 30% P.G. FC=100 Kg/cm2 | 4d? | 2022-02-23 | 2022-03-01 |  | 33d |  | start no earlier than 2021-12-22 | CEMENTO PORTLAND TIPO MS (42.5 kg) [268.24 bls]; OFICIAL [90.6%]; PEON [725%]; OPERARIO [181.2%]; MEZCLADORA DE CONCRETO TAMBOR 11 p3 22 HP [90.6%]; PIEDRA DE 8" GRANDE [45.67 m3]; HORMIGON [78.84 m3]; AGUA [9.52 m3] | 347.98h | 26,325.77 | 01.08.03.01 | 000000000000069 | 90.62 | 216.79 | 19645.51 | 25 |
| 60 | 1.9 | **CONCRETO ARMADO** | 73d? | 2022-02-15 | 2022-06-11 |  | 10d | 0d |  |  | 9206.03h | 1,184,405.51 | 01.09 | 000000000000070 |  |  |  |  |
| 61 | 1.9.1 | **SOBRECIMIENTO** | 12d? | 2022-03-01 | 2022-03-20 | 58 | 33d | 0d |  |  | 389.06h | 27,986.37 | 01.09.01 | 000000000000071 |  |  |  |  |
| 62 | 1.9.1.1 | SOBRECIMIENTOS.-CONCRETO f'c=175 kg/cm2 | 2d? | 2022-03-01 | 2022-03-04 |  | 43d |  | start no earlier than 2021-12-22 | CEMENTO PORTLAND TIPO MS (42.5 kg) [92.64 bls]; OFICIAL [100.7%]; PEON [402.8%]; OPERARIO [50.4%]; MEZCLADORA DE CONCRETO TAMBOR 11 p3 22 HP [50.4%]; VIBRADOR DE CONCRETO 4 HP 1.50" [25.2%]; PIEDRA CHANCADA DE 1/2" a 3/4" [6.37 m3]; ARENA GRUESA [5.79 m3]; AGUA [2.65 m3] | 100.7h | 6,983.95 | 01.09.01.01 | 000000000000072 | 11.58 | 432.15 | 5004.3 | 11.5 |
| 63 | 1.9.1.2 | SOBRECIMIENTO, ENCOFRADO Y DESENCOFRADO | 12d? | 2022-03-01 | 2022-03-20 |  | 33d |  | start no earlier than 2021-12-22 | OFICIAL [91.9%]; PEON [46%]; OPERARIO [64.3%]; ALAMBRE NEGRO # 8 [40.15 kg]; CLAVOS CON CABEZA DE 2 1/2" 3" 4" [20.08 kg]; MADERA TORNILLO [517.34 p2] | 194.13h | 11,141.36 | 01.09.01.02 | 000000000000073 | 154.43 | 46.5 | 7181 | 14 |
| 64 | 1.9.1.3 | SOBRECIMIENTO.-ACERO fy=4200 kg/cm2 | 6d? | 2022-03-01 | 2022-03-11 |  | 39d |  | start no earlier than 2021-12-22 | OFICIAL [98.2%]; OPERARIO [98.2%]; ALAMBRE NEGRO # 16 [58.89 kg]; ACERO CORRUGADO [1236.7 kg] | 94.22h | 9,861.06 | 01.09.01.03 | 000000000000074 | 1177.81 | 6.63 | 7808.88 | 200 |
| 65 | 1.9.2 | **ZAPATAS** | 12d? | 2022-02-15 | 2022-03-06 | 54 | 71d | 0d |  |  | 1307.18h | 238,005.08 | 01.09.02 | 000000000000075 |  |  |  |  |
| 66 | 1.9.2.1 | ZAPATAS.-CONCRETO f'c=210 kg/cm2 | 9d? | 2022-02-15 | 2022-03-01 |  | 74d |  | start no earlier than 2021-12-22 | CEMENTO PORTLAND TIPO MS (42.5 kg) [1880.46 bls]; OFICIAL [185.7%]; PEON [742.9%]; OPERARIO [185.7%]; MEZCLADORA DE CONCRETO TAMBOR 11 p3 22 HP [92.9%]; VIBRADOR DE CONCRETO 4 HP 1.50" [92.9%]; PIEDRA CHANCADA DE 1/2" a 3/4" [114.92 m3]; ARENA GRUESA [104.47 m3]; AGUA [47.85 m3] | 936.05h | 96,741.04 | 01.09.02.01 | 000000000000076 | 208.94 | 380.06 | 79409.74 | 25 |
| 67 | 1.9.2.2 | ZAPATAS.- ENCOFRADO Y DESENCOFRADO | 12d? | 2022-02-15 | 2022-03-06 |  | 71d |  | start no earlier than 2021-12-22 | OFICIAL [93.3%]; OPERARIO [93.3%]; ALAMBRE NEGRO # 8 [15.68 kg]; CLAVOS CON CABEZA DE 2 1/2" 3" 4" [23.52 kg]; MADERA TORNILLO [815.41 p2] | 179.2h | 12,495.87 | 01.09.02.02 | 000000000000077 | 156.81 | 54.83 | 8597.89 | 14 |
| 68 | 1.9.2.3 | ZAPATAS.-ACERO fy=4200 kg/cm2 | 12d | 2022-02-15 | 2022-03-06 |  | 71d |  | start no earlier than 2021-12-22 | OFICIAL; OPERARIO; ALAMBRE NEGRO # 16 [939.66 kg]; ACERO CORRUGADO [19732.8 kg] | 191.93h | 128,768.18 | 01.09.02.03 | 000000000000078 | 18793.17 | 6.63 | 124598.72 | 200 |
| 69 | 1.9.3 | **VIGAS DE CIMENTACION** | 15d? | 2022-02-15 | 2022-03-11 | 65SS | 38d | 0d |  |  | 852.21h | 110,766.94 | 01.09.03 | 000000000000079 |  |  |  |  |
| 70 | 1.9.3.1 | VIGAS DE CIMENTACION.-CONCRETO f'c=280 kg/cm2 - 1 PISO | 3d? | 2022-02-15 | 2022-02-19 |  | 50d |  | start no earlier than 2021-12-22 | CEMENTO PORTLAND TIPO MS (42.5 kg) [545.48 bls]; OFICIAL [199.8%]; PEON [999.1%]; OPERARIO [199.8%]; MEZCLADORA DE CONCRETO TAMBOR 11 p3 22 HP; VIBRADOR DE CONCRETO 4 HP 1.50"; PIEDRA CHANCADA DE 1/2" a 3/4" [23.08 m3]; ARENA GRUESA [20.98 m3]; AGUA [9.61 m3] | 383.64h | 30,991.14 | 01.09.03.01 | 000000000000080 | 41.96 | 568.37 | 23848.81 | 14 |
| 71 | 1.9.3.2 | VIGAS DE CIMENTACION.- ENCOFRADO Y DESENCOFRADO | 15d | 2022-02-15 | 2022-03-11 |  | 38d |  | start no earlier than 2021-12-22 | OFICIAL [97.8%]; OPERARIO [97.8%]; ALAMBRE NEGRO # 8 [76.72 kg]; CLAVOS CON CABEZA DE 2 1/2" 3" 4" [92.06 kg]; MADERA TORNILLO [2075.17 p2] | 234.83h | 26,917.68 | 01.09.03.02 | 000000000000081 | 383.58 | 56.87 | 21814.19 | 14 |
| 72 | 1.9.3.3 | VIGAS DE CIMENTACION.-ACERO fy=4200 kg/cm2 | 15d | 2022-02-15 | 2022-03-11 |  | 38d |  | start no earlier than 2021-12-22 | OFICIAL [97.4%]; OPERARIO [97.4%]; ALAMBRE NEGRO # 16 [360.35 kg]; ACERO CORRUGADO [7567.38 kg] | 233.74h | 52,858.12 | 01.09.03.03 | 000000000000082 | 7207.03 | 6.63 | 47782.61 | 200 |
| 73 | 1.9.4 | **COLUMNA** | 30d? | 2022-03-11 | 2022-04-28 | 69 | 38d | 0d |  |  | 2212.32h | 272,663.63 | 01.09.04 | 000000000000083 |  |  |  |  |
| 74 | 1.9.4.1 | COLUMNAS.-CONCRETO f'c=210 kg/cm2 - 1 PISO | 10d? | 2022-03-11 | 2022-03-27 |  | 58d |  | start no earlier than 2021-12-22 | CEMENTO PORTLAND TIPO MS (42.5 kg) [884.88 bls]; OFICIAL [196.6%]; PEON [983.2%]; OPERARIO [196.6%]; MEZCLADORA DE CONCRETO TAMBOR 11 p3 22 HP [98.3%]; VIBRADOR DE CONCRETO 4 HP 1.50" [98.3%]; PIEDRA CHANCADA DE 1/2" a 3/4" [54.08 m3]; ARENA GRUESA [49.16 m3]; AGUA [22.52 m3] | 1258.5h | 75,690.12 | 01.09.04.01 | 000000000000084 | 98.32 | 535.09 | 52610.05 | 10 |
| 75 | 1.9.4.2 | COLUMNAS.- ENCOFRADO Y DESENCOFRADO | 30d | 2022-03-11 | 2022-04-28 |  | 38d |  | start no earlier than 2021-12-22 | OFICIAL [99.5%]; OPERARIO [99.5%]; ALAMBRE NEGRO # 8 [381.89 kg]; CLAVOS CON CABEZA DE 2 1/2" 3" 4" [280.05 kg]; MADERA TORNILLO [5321.01 p2] | 477.36h | 87,921.19 | 01.09.04.02 | 000000000000085 | 1272.97 | 60.93 | 77562.06 | 10 |
| 76 | 1.9.4.3 | COLUMNAS.-ACERO fy=4200 kg/cm2 | 30d | 2022-03-11 | 2022-04-28 |  | 38d |  | start no earlier than 2021-12-22 | OFICIAL [99.3%]; OPERARIO [99.3%]; ALAMBRE NEGRO # 16 [744.47 kg]; ACERO CORRUGADO [15633.9 kg] | 476.46h | 109,052.32 | 01.09.04.03 | 000000000000086 | 14889.45 | 6.63 | 98717.05 | 200 |

| ID | WBS | Task | Duration | Start | Finish | Predecessors | Total slack | Free slack | Constraint | Resources | Work | Cost | Text1 | Text8 | Text2 | Text3 | Text4 | Text6 |
| --- | --- | --- | --- | --- | --- | --- | --- | --- | --- | --- | --- | --- | --- | --- | --- | --- | --- | --- |
| 77 | 1.9.5 | **PLACAS** | 2d? | 2022-03-11 | 2022-03-14 | 73SS | 0d |  |  |  | 50.91h | 3,640.22 | 01.09.05 | 000000000000123 |  |  |  |  |
| 78 | 1.9.5.1 | PLACAS.-CONCRETO f'c=280 kg/cm2 - 1 PISO | 1d? | 2022-03-11 | 2022-03-12 |  | 1d |  | start no earlier than 2021-12-22 | CEMENTO PORTLAND TIPO MS (42.5 kg) [11.25 bls]; OFICIAL [25%]; PEON [125%]; OPERARIO [25%]; MEZCLADORA DE CONCRETO TAMBOR 11 p3 22 HP [12.5%]; VIBRADOR DE CONCRETO 4 HP 1.50" [12.5%]; PIEDRA CHANCADA DE 1/2" a 3/4" [0.69 m3]; ARENA GRUESA [0.62 m3]; AGUA [0.29 m3] | 16h | 1,113.76 | 01.09.05.01 | 000000000000124 | 1.25 | 535.09 | 668.86 | 10 |
| 79 | 1.9.5.2 | PLACAS.- ENCOFRADO Y DESENCOFRADO | 2d? | 2022-03-11 | 2022-03-14 |  | 0d |  | start no earlier than 2021-12-22 | OFICIAL [80.1%]; OPERARIO [80.1%]; ALAMBRE NEGRO # 8 [4.81 kg]; CLAVOS CON CABEZA DE 2 1/2" 3" 4" [3.52 kg]; MADERA TORNILLO [66.96 p2] | 25.63h | 1,546.21 | 01.09.05.03 | 000000000000126 | 16.02 | 60.93 | 976.1 | 10 |
| 80 | 1.9.5.3 | PLACAS.-ACERO fy=4200 kg/cm2 | 1d? | 2022-03-11 | 2022-03-12 |  | 1d |  | start no earlier than 2021-12-22 | OFICIAL [58%]; OPERARIO [58%]; ALAMBRE NEGRO # 16 [5.8 kg]; ACERO CORRUGADO [121.77 kg] | 9.28h | 980.26 | 01.09.05.04 | 000000000000127 | 115.97 | 6.63 | 768.88 | 200 |
| 81 | 1.9.6 | **VIGAS** | 28d? | 2022-03-14 | 2022-04-28 | 77 | 0d |  |  |  | 1493.31h | 250,168.53 | 01.09.06 | 000000000000087 |  |  |  |  |
| 82 | 1.9.6.1 | VIGAS.-CONCRETO f'c=210 kg/cm2 - 1 PISO | 5d? | 2022-03-14 | 2022-03-22 |  | 23d |  | start no earlier than 2021-12-22 | CEMENTO PORTLAND TIPO MS (42.5 kg) [843.75 bls]; OFICIAL [187.5%]; PEON [937.5%]; OPERARIO [187.5%]; MEZCLADORA DE CONCRETO TAMBOR 11 p3 22 HP [93.8%]; VIBRADOR DE CONCRETO 4 HP 1.50" [93.8%]; PIEDRA CHANCADA DE 1/2" a 3/4" [51.56 m3]; ARENA GRUESA [46.88 m3]; AGUA [21.47 m3] | 600h | 50,026.73 | 01.09.06.01 | 000000000000088 | 93.75 | 415.39 | 38942.81 | 20 |
| 83 | 1.9.6.2 | VIGAS.- ENCOFRADO Y DESENCOFRADO | 28d | 2022-03-14 | 2022-04-28 |  | 0d |  | start no earlier than 2021-12-22 | OFICIAL; OPERARIO; ALAMBRE NEGRO # 8 [190.19 kg]; CLAVOS CON CABEZA DE 2 1/2" 3" 4" [228.23 kg]; MADERA TORNILLO [5144.75 p2] | 447.49h | 63,793.49 | 01.09.06.02 | 000000000000089 | 950.97 | 56.87 | 54081.66 | 14 |
| 84 | 1.9.6.3 | VIGAS.-ACERO fy=4200 kg/cm2 | 28d | 2022-03-14 | 2022-04-28 |  | 0d |  | start no earlier than 2021-12-22 | OFICIAL; OPERARIO; ALAMBRE NEGRO # 16 [955.33 kg]; ACERO CORRUGADO [20062 kg] | 445.82h | 136,348.3 | 01.09.06.03 | 000000000000090 | 19106.64 | 6.63 | 126677.02 | 200 |
| 85 | 1.9.7 | **LOSAS ALIGERADAS** | 28d? | 2022-04-28 | 2022-06-11 | 81 | 0d |  |  |  | 1739.87h | 194,862.66 | 01.09.07 | 000000000000091 |  |  |  |  |
| 86 | 1.9.7.1 | LOSA ALIGERADA.-CONCRETO f'c=210 kg/cm2 - 1 PISO | 4d? | 2022-04-28 | 2022-05-04 |  | 24d |  | start no earlier than 2021-12-22 | CEMENTO PORTLAND TIPO MS (42.5 kg) [879.66 bls]; OFICIAL [195.5%]; PEON [1075.1%]; OPERARIO [293.2%]; MEZCLADORA DE CONCRETO TAMBOR 11 p3 22 HP [97.7%]; VIBRADOR DE CONCRETO 4 HP 1.50" [97.7%]; PIEDRA CHANCADA DE 1/2" a 3/4" [53.76 m3]; ARENA GRUESA [48.87 m3]; AGUA [22.38 m3] | 562.98h | 50,165.38 | 01.09.07.01 | 000000000000092 | 97.74 | 405.13 | 39597.41 | 25 |
| 87 | 1.9.7.2 | LOSA ALIGERADA.- ENCOFRADO Y DESENCOFRADO | 28d | 2022-04-28 | 2022-06-11 |  | 0d |  | start no earlier than 2021-12-22 | OFICIAL [99.1%]; OPERARIO [99.1%]; ALAMBRE NEGRO # 8 [115.37 kg]; CLAVOS CON CABEZA DE 2 1/2" 3" 4" [126.91 kg]; MADERA TORNILLO [4107.24 p2] | 444.07h | 67,392.78 | 01.09.07.02 | 000000000000093 | 1153.72 | 50.06 | 57755.22 | 12 |
| 88 | 1.9.7.3 | LOSA ALIGERADA.-ACERO fy=4200 kg/cm2 | 28d | 2022-04-28 | 2022-06-11 |  | 0d |  | start no earlier than 2021-12-22 | OFICIAL; OPERARIO; ALAMBRE NEGRO # 16 [308.88 kg]; ACERO CORRUGADO [6486.47 kg] | 446.38h | 50,640.82 | 01.09.07.03 | 000000000000094 | 6177.59 | 6.63 | 40957.42 | 200 |
| 89 | 1.9.7.4 | LOSA ALIGERADA.- LADR. HUECO 15X30X30 | 4d? | 2022-04-28 | 2022-05-04 |  | 24d |  | start no earlier than 2021-12-22 | OFICIAL [81.4%]; PEON [732.4%]; OPERARIO [81.4%]; LADRILLO PARA TECHO 15 X 30 X 30 cm [6835.5 u] | 286.44h | 26,663.67 | 01.09.07.04 | 000000000000095 | 6510 | 3.3 | 21483 | 2000 |
| 90 | 1.9.8 | **ESCALERAS** | 9d? | 2022-04-28 | 2022-05-12 | 85SS | 17d | 0d |  |  | 321.56h | 25,751.73 | 01.09.08 | 000000000000096 |  |  |  |  |
| 91 | 1.9.8.1 | ESCALERAS.- CONCRETO fc=210 kg/cm2 | 1d? | 2022-04-28 | 2022-04-29 |  | 25d |  | start no earlier than 2021-12-22 | CEMENTO PORTLAND TIPO MS (42.5 kg) [77.13 bls]; OFICIAL [142.8%]; PEON [714.2%]; OPERARIO [142.8%]; MEZCLADORA DE CONCRETO TAMBOR 11 p3 22 HP [71.4%]; WINCHE CON DOS BALDES 3.6 HP [71.4%]; VIBRADOR DE CONCRETO 4 HP 1.50" [71.4%]; PIEDRA CHANCADA DE 1/2" a 3/4" [4.71 m3]; ARENA GRUESA [4.29 m3]; AGUA [1.96 m3] | 97.13h | 6,363.91 | 01.09.08.01 | 000000000000097 | 8.57 | 512.77 | 4394.44 | 12 |
| 92 | 1.9.8.2 | ESCALERAS.- ENCOFRADO Y DESENCOFRADO | 6d? | 2022-04-28 | 2022-05-07 |  | 20d |  | start no earlier than 2021-12-22 | OFICIAL [86.3%]; OPERARIO [86.3%]; ALAMBRE NEGRO # 8 [3.11 kg]; CLAVOS CON CABEZA DE 2 1/2" 3" 4" [3.11 kg]; MADERA TORNILLO [163.38 p2] | 82.82h | 4,573.5 | 01.09.08.02 | 000000000000098 | 31.06 | 88.99 | 2764.03 |  |
| 93 | 1.9.8.3 | ESCALERAS.- ACERO fy=4200 kg/cm2 | 9d? | 2022-04-28 | 2022-05-12 |  | 17d |  | start no earlier than 2021-12-22 | OFICIAL [98.3%]; OPERARIO [98.3%]; ALAMBRE NEGRO # 16 [88.5 kg]; ACERO CORRUGADO [1858.55 kg] | 141.6h | 14,814.32 | 01.09.08.03 | 000000000000099 | 1770.05 | 6.63 | 11735.43 | 200 |
| 94 | 1.9.9 | **CUNETAS CON REJILLA** | 6d? | 2022-02-15 | 2022-02-24 | 56SS | 77d |  |  |  | 146.26h | 9,684.17 | 01.09.09 | 000000000000100 |  |  |  |  |
| 95 | 1.9.9.1 | CUNETAS.-CONCRETO f'c=175 kg/cm2 | 1d? | 2022-02-15 | 2022-02-16 |  | 82d |  | start no earlier than 2021-12-22 | CEMENTO PORTLAND TIPO MS (42.5 kg) [47.76 bls]; OFICIAL [39.8%]; PEON [398%]; OPERARIO [79.6%]; MEZCLADORA DE CONCRETO TAMBOR 11 p3 22 HP [39.8%]; VIBRADOR DE CONCRETO 4 HP 1.50" [39.8%]; PIEDRA CHANCADA DE 1/2" a 3/4" [3.28 m3]; ARENA GRUESA [2.98 m3]; AGUA [1.07 m3] | 47.76h | 3,522.82 | 01.09.09.01 | 000000000000101 | 5.97 | 419.13 | 2502.21 | 15 |
| 96 | 1.9.9.2 | CUNETAS.- ENCOFRADO Y DESENCOFRADO | 6d? | 2022-02-15 | 2022-02-24 |  | 77d |  | start no earlier than 2021-12-22 | OFICIAL [86.2%]; OPERARIO [86.2%]; ALAMBRE NEGRO # 8 [10.75 kg]; CLAVOS CON CABEZA DE 2 1/2" 3" 4" [5.38 kg]; MADERA TORNILLO [141.04 p2] | 82.72h | 4,501.39 | 01.09.09.02 | 000000000000102 | 41.36 | 65.14 | 2694.19 |  |
| 97 | 1.9.9.3 | CUNETAS.-ACERO fy=4200 kg/cm2 | 1d? | 2022-02-15 | 2022-02-16 |  | 82d |  | start no earlier than 2021-12-22 | OFICIAL [98.6%]; OPERARIO [98.6%]; ALAMBRE NEGRO # 16 [9.86 kg]; ACERO CORRUGADO [207.1 kg] | 15.78h | 1,659.97 | 01.09.09.03 | 000000000000103 | 197.24 | 6.63 | 1307.7 | 200 |
| 98 | 1.9.10 | **CISTERNA** | 12d? | 2022-05-12 | 2022-05-31 | 90 | 17d |  |  |  | 496.69h | 36,215.24 | 01.09.10 | 000000000000104 |  |  |  |  |
| 99 | 1.9.10.1 | CISTERNA.-CONCRETO f'c=210 kg/cm2 | 2d? | 2022-05-12 | 2022-05-15 |  | 27d |  | start no earlier than 2021-12-22 | CEMENTO PORTLAND TIPO MS (42.5 kg) [144.36 bls]; OFICIAL [160.4%]; PEON [802%]; OPERARIO [160.4%]; MEZCLADORA DE CONCRETO TAMBOR 11 p3 22 HP [40.1%]; VIBRADOR DE CONCRETO 4 HP 1.50" [40.1%]; PIEDRA CHANCADA DE 1/2" a 3/4" [8.82 m3]; ARENA GRUESA [8.02 m3]; AGUA [3.67 m3] | 192.48h | 12,065.91 | 01.09.10.01 | 000000000000105 | 16.04 | 522.29 | 8377.53 | 10 |
| 100 | 1.9.10.2 | CISTERNA.- ENCOFRADO Y DESENCOFRADO | 12d? | 2022-05-12 | 2022-05-31 |  | 17d |  | start no earlier than 2021-12-22 | OFICIAL [94.2%]; OPERARIO [94.2%]; ALAMBRE NEGRO # 8 [16.28 kg]; CLAVOS CON CABEZA DE 2 1/2" 3" 4" [29.85 kg]; MADERA TORNILLO [567.06 p2] | 180.89h | 11,246.59 | 01.09.10.02 | 000000000000106 | 135.66 | 53.9 | 7312.07 | 12 |
| 101 | 1.9.10.3 | CISTERNA.-ACERO fy=4200 kg/cm2 | 8d? | 2022-05-12 | 2022-05-25 |  | 21d |  | start no earlier than 2021-12-22 | OFICIAL [96.3%]; OPERARIO [96.3%]; ALAMBRE NEGRO # 16 [77.07 kg]; ACERO CORRUGADO [1618.56 kg] | 123.32h | 12,902.74 | 01.09.10.03 | 000000000000107 | 1541.49 | 6.63 | 10220.08 | 200 |

| ID | WBS | Task | Duration | Start | Finish | Predecessors | Total slack | Free slack | Constraint | Resources | Work | Cost | Text1 | Text8 | Text2 | Text3 | Text4 | Text6 |
| --- | --- | --- | --- | --- | --- | --- | --- | --- | --- | --- | --- | --- | --- | --- | --- | --- | --- | --- |
| 102 | 1.9.11 | **TANQUE ELEVADO** | 5d? | 2022-04-28 | 2022-05-06 | 90SS | 33d |  |  |  | 196.66h | 14,660.94 | 01.09.11 | 000000000000108 |  |  |  |  |
| 103 | 1.9.11.1 | TANQUE ELEVADO.-CONCRETO f'c=210 kg/cm2 | 1d? | 2022-04-28 | 2022-04-29 |  | 37d |  | start no earlier than 2021-12-22 | CEMENTO PORTLAND TIPO MS (42.5 kg) [43.92 bls]; OFICIAL [97.6%]; PEON [488%]; OPERARIO [97.6%]; MEZCLADORA DE CONCRETO TAMBOR 11 p3 22 HP [24.4%]; VIBRADOR DE CONCRETO 4 HP 1.50" [24.4%]; PIEDRA CHANCADA DE 1/2" a 3/4" [2.68 m3]; ARENA GRUESA [2.44 m3]; AGUA [1.12 m3] | 58.56h | 3,777.67 | 01.09.11.01 | 000000000000109 | 4.88 | 522.29 | 2548.78 | 10 |
| 104 | 1.9.11.2 | TANQUE ELEVADO.- ENCOFRADO Y DESENCOFRADO | 5d? | 2022-04-28 | 2022-05-06 |  | 33d |  | start no earlier than 2021-12-22 | OFICIAL [98.4%]; OPERARIO [98.4%]; ALAMBRE NEGRO # 8 [5.9 kg]; CLAVOS CON CABEZA DE 2 1/2" 3" 4" [10.82 kg]; MADERA TORNILLO [205.66 p2] | 78.72h | 4,665.14 | 01.09.11.02 | 000000000000110 | 49.2 | 59.85 | 2944.62 | 10 |
| 105 | 1.9.11.3 | TANQUE ELEVADO.-ACERO fy=4200 kg/cm2 | 4d? | 2022-04-28 | 2022-05-04 |  | 34d |  | start no earlier than 2021-12-22 | OFICIAL [92.8%]; OPERARIO [92.8%]; ALAMBRE NEGRO # 16 [37.11 kg]; ACERO CORRUGADO [779.35 kg] | 59.38h | 6,218.13 | 01.09.11.03 | 000000000000111 | 742.24 | 6.63 | 4921.05 | 200 |
| 106 | 1.10 | **ESTRUCTURAS METALICAS** | 1d? | 2022-06-12 | 2022-06-13 | 60 | 10d |  |  |  |  | 328,960 | 01.10 | 000000000000112 |  |  |  |  |
| 107 | 1.10.1 | COBERTURA LIVIANA CURVA | 1d? | 2022-06-12 | 2022-06-13 |  | 10d |  | start no earlier than 2021-12-22 | SUMINISTRO E INSTALACION DE COBERTURA METALICA AUTOSOPORTADA [1 glb] |  | 328,960 | 01.10.01 | 000000000000120 |  | 164480 | 164480 | 20 |
| 108 | 2 | **ARQUITECTURA** | 63d? | 2022-03-20 | 2022-06-29 |  | 0d |  |  |  | 45210h | 1,367,847.85 | 01 | 000000000000001 |  |  |  |  |
| 109 | 2.1 | **MUROS Y TABIQUES DE ALBAÑILERIA** | 30d? | 2022-03-20 | 2022-05-07 | 61 | 33d | 0d |  |  | 25138.8h | 316,538.76 | 01.01 | 000000000000002 |  |  |  |  |
| 110 | 2.1.1 | MURO DE LADRILLO KK TIPO IV SOGA M : 1:1:4 e=1.5cm | 30d | 2022-03-20 | 2022-05-07 |  | 33d |  | start no earlier than 2021-12-22 | CEMENTO PORTLAND TIPO MS (42.5 kg) [171.05 bls]; CAL (BOLSA X 20KG) [113.77 bls]; PEON [50%]; OPERARIO; CLAVOS CON CABEZA DE 2 1/2" 3" 4" [15.7 kg]; ARENA GRUESA [20.4 m3]; AGUA [7.07 m3]; MADERA TORNILLO [455.08 p2]; LADRILLO KK TIPO IV 24X14X9cm (maquinado) [4608.6%] | 11420.3h | 148,743.02 | 01.01.01 | 000000000000003 | 784.64 | 66.64 | 52288.41 | 9.46 |
| 111 | 2.1.2 | MURO DE LADRILLO KK TIPO IV CABEZA M : 1:1:4 e=1.5cm | 30d | 2022-03-20 | 2022-05-07 |  | 33d |  | start no earlier than 2021-12-22 | CEMENTO PORTLAND TIPO MS (42.5 kg) [191.43 bls]; CAL (BOLSA X 20KG) [150.15 bls]; PEON [49.8%]; OPERARIO; CLAVOS CON CABEZA DE 2 1/2" 3" 4" [9.38 kg]; ARENA GRUESA [27.22 m3]; AGUA [9.85 m3]; MADERA TORNILLO [272.13 p2]; LADRILLO KK TIPO IV 24X14X9cm (maquinado) [5543.6%] | 13663.5h | 165,321.78 | 01.01.02 | 000000000000004 | 469.2 | 108.56 | 50936.35 | 6.45 |
| 112 | 2.1.3 | MURO DE LADRILLO KK TIPO IV CANTO M : 1:1:4 e=1.5cm | 1d? | 2022-03-20 | 2022-03-22 |  | 62d |  | start no earlier than 2021-12-22 | CEMENTO PORTLAND TIPO MS (42.5 kg) [0.5 bls]; CAL (BOLSA X 20KG) [0.39 bls]; PEON [5.1%]; OPERARIO [10.2%]; CLAVOS CON CABEZA DE 2 1/2" 3" 4" [0.02 kg]; ARENA GRUESA [0.07 m3]; AGUA [0.03 m3]; MADERA TORNILLO [0.71 p2]; LADRILLO KK TIPO IV 24X14X9cm (maquinado) [3660%] | 37.82h | 484.76 | 01.01.03 | 000000000000086 | 1.22 | 62.63 | 76.41 | 12 |
| 113 | 2.1.4 | FIERRO REFUERZO HORIZONTAL EN MUROS | 2d? | 2022-03-20 | 2022-03-23 |  | 61d |  | start no earlier than 2021-12-22 | OFICIAL [53.9%]; OPERARIO [53.9%]; ACERO CORRUGADO [282.94 kg] | 17.23h | 1,989.21 | 01.01.04 | 000000000000005 | 269.47 | 5.98 | 1611.43 | 250 |
| 114 | 2.2 | **REVOQUES Y REVESTIMIENTOS** | 32d? | 2022-03-20 | 2022-05-10 | 109SS | 11d | 0d |  |  | 2364.37h | 198,029.93 | 01.02 | 000000000000006 |  |  |  |  |
| 115 | 2.2.1 | TARRAJEO EN MUROS INTERIORES | 30d | 2022-03-20 | 2022-05-07 |  | 13d |  | start no earlier than 2021-12-22 | CEMENTO PORTLAND TIPO MS (42.5 kg) [105.52 bls]; PEON [49.1%]; OPERARIO [98.2%]; CLAVOS CON CABEZA DE 2 1/2" 3" 4" [19.83 kg]; ARENA FINA [3.8%]; AGUA [3.6 m3]; MADERA TORNILLO [545.58 p2] | 362.63h | 27,688.26 | 01.02.01 | 000000000000008 | 901.8 | 21.99 | 19830.58 | 18 |
| 116 | 2.2.2 | TARRAJEO EN MUROS EXTERIORES | 30d | 2022-03-20 | 2022-05-07 |  | 13d |  | start no earlier than 2021-12-22 | CEMENTO PORTLAND TIPO MS (42.5 kg) [71.23 bls]; PEON [49.7%]; OPERARIO [99.5%]; CLAVOS CON CABEZA DE 2 1/2" 3" 4" [13.4 kg]; ARENA FINA [2.5%]; AGUA [2.43 m3]; MADERA TORNILLO [529.73 p2] | 364.25h | 26,778.91 | 01.02.02 | 000000000000009 | 608.88 | 30.95 | 18844.84 | 12 |
| 117 | 2.2.3 | TARRAJEO DE COLUMNAS | 20d | 2022-03-20 | 2022-04-21 |  | 23d |  | start no earlier than 2021-12-22 | CEMENTO PORTLAND TIPO MS (42.5 kg) [111.13 bls]; PEON [32.9%]; OPERARIO; CLAVOS CON CABEZA DE 2 1/2" 3" 4" [20.9 kg]; ARENA FINA [1.7%]; AGUA [3.8 m3]; MADERA TORNILLO [550.92 p2]; MADERA CEDRO [38.7%] | 276.97h | 43,697.52 | 01.02.03 | 000000000000010 | 949.85 | 40.39 | 38364.44 |  |
| 118 | 2.2.4 | TARRAJEO DE VIGAS | 30d | 2022-03-20 | 2022-05-07 |  | 13d |  | start no earlier than 2021-12-22 | CEMENTO PORTLAND TIPO MS (42.5 kg) [78.17 bls]; PEON [32.7%]; OPERARIO [99%]; CLAVOS CON CABEZA DE 2 1/2" 3" 4" [29.4 kg]; ARENA FINA [1.6%]; AGUA [2.67 m3]; MADERA TORNILLO [1737.13 p2]; MADERA CEDRO [36%] | 406.16h | 43,607.4 | 01.02.04 | 000000000000011 | 668.13 | 53.49 | 35738.27 | 7.5 |
| 119 | 2.2.5 | TARRAJEO DEL TIPO RAYADO O PRIMARIO CON MORTERO 1:5 | 5d? | 2022-03-20 | 2022-03-28 |  | 38d |  | start no earlier than 2021-12-22 | CEMENTO PORTLAND TIPO MS (42.5 kg) [6.36 bls]; PEON [40.7%]; OPERARIO [81.5%]; CLAVOS CON CABEZA DE 2 1/2" 3" 4" [1.79 kg]; ARENA FINA [97.8%]; AGUA [0.22 m3]; MADERA TORNILLO [47.27 p2] | 49.88h | 2,680.54 | 01.02.05 | 000000000000007 | 81.5 | 19.17 | 1562.36 | 20 |
| 120 | 2.2.6 | TARRAJEO CON IMPERMEABILIZANTE | 9d? | 2022-03-20 | 2022-04-04 |  | 34d |  | start no earlier than 2021-12-22 | CEMENTO PORTLAND TIPO MS (42.5 kg) [12.11 bls]; ANDAMIO METAL TABLAS ALQUILER [46.1%]; IMPERMEABILIZANTE LIQUIDO PARA CONCRETO; PEON [46.7%]; OPERARIO [93.4%]; ARENA FINA [161.5%]; AGUA [0.61 m3] | 207.75h | 5,983.53 | 01.02.06 | 000000000000012 | 67.28 | 42.92 | 2887.66 |  |
| 121 | 2.2.7 | VESTIDURA DE DERRAMES (1:5) | 30d | 2022-03-20 | 2022-05-07 |  | 13d |  | start no earlier than 2021-12-22 | CEMENTO PORTLAND TIPO MS (42.5 kg) [28.57 bls]; PEON [33%]; OPERARIO [99.1%]; CLAVOS CON CABEZA DE 2 1/2" 3" 4" [15.87 kg]; ARENA FINA [0.4%]; AGUA [1.58 m3]; MADERA TORNILLO [201.6 p2]; MADERA CEDRO [16.3%] | 357.1h | 32,091.91 | 01.02.07 | 000000000000013 | 1587.37 | 15.5 | 24604.24 | 18 |
| 122 | 2.2.8 | BRUÑAS SEGÚN DETALLE | 32d? | 2022-03-20 | 2022-05-10 |  | 11d |  | start no earlier than 2021-12-22 | PEON [33.1%]; OPERARIO | 339.62h | 15,501.86 | 01.02.08 | 000000000000014 | 1592.17 | 4.94 | 7865.32 | 50 |
| 123 | 2.3 | **CIELORRASOS** | 15d | 2022-05-11 | 2022-06-03 | 114 | 16d |  |  |  | 185.92h | 50,287.03 | 01.03 | 000000000000015 |  |  |  |  |
| 124 | 2.3.1 | CIELORRASO CON MEZCLA C:A 1:5 | 15d | 2022-05-11 | 2022-06-03 |  | 16d |  | start no earlier than 2021-12-22 | CEMENTO PORTLAND TIPO MS (42.5 kg) [239.32 bls]; PEON [49.7%]; OPERARIO [99.5%]; CLAVOS CON CABEZA DE 2 1/2" 3" 4" [8.38 kg]; ARENA FINA [3.7%]; AGUA [3.72 m3]; MADERA TORNILLO [2011.35 p2]; MADERA CEDRO [2%] | 185.92h | 50,287.03 | 01.03.01 | 000000000000016 | 931.18 | 49.69 | 46270.33 |  |
| 125 | 2.4 | **PISOS Y PAVIMENTOS** | 15d? | 2022-05-11 | 2022-06-03 | 114 | 11d | 0d |  |  | 3090.86h | 184,794.76 | 01.04 | 000000000000017 |  |  |  |  |
| 126 | 2.4.1 | **CONTRAPISOS** | 5d? | 2022-05-11 | 2022-05-18 |  | 21d |  |  |  | 411.43h | 21,456.1 | 01.04.01 | 000000000000018 |  |  |  |  |
| 127 | 2.4.1.1 | CONTRAPISO DE 40 mm | 5d? | 2022-05-11 | 2022-05-18 |  | 21d |  | start no earlier than 2021-12-22 | CEMENTO PORTLAND TIPO MS (42.5 kg) [185.85 bls]; OFICIAL [85.3%]; PEON [512.3%]; OPERARIO [256.1%]; MEZCLADORA DE CONCRETO TAMBOR 11 p3 22 HP [85.3%]; ARENA GRUESA [30.48 m3]; AGUA [8.13 m3]; MADERA CEDRO [3585.5%] | 411.43h | 21,456.1 | 01.04.01.01 | 000000000000019 | 597.58 | 23 | 13744.34 | 140 |

| ID | WBS | Task | Duration | Start | Finish | Predecessors | Total slack | Free slack | Constraint | Resources | Work | Cost | Text1 | Text8 | Text2 | Text3 | Text4 | Text6 |
| --- | --- | --- | --- | --- | --- | --- | --- | --- | --- | --- | --- | --- | --- | --- | --- | --- | --- | --- |
| 128 | 2.4.2 | **PISOS** | 15d? | 2022-05-11 | 2022-06-03 |  | 11d |  |  |  | 2295.61h | 136,892.62 | 01.04.02 | 000000000000020 |  |  |  |  |
| 129 | 2.4.2.1 | PISO PORCELANATO 60 x 60 MODELO POTENSA BLANCO PERLA MATE- ALTO TRANSITO | 15d | 2022-05-11 | 2022-06-03 |  | 11d |  | start no earlier than 2021-12-22 | CRUCETA DE 3mm [8.7%]; PEON [49.7%]; OPERARIO [99.4%]; FRAGUA DE COLOR; PEGAMENTO EN POLVO; PORCELANATO 60 x 60 MODELO POTENSA BLANCO PERLA MATE- ALTO TRANSITO [130.5%]; AGUA [3.42 m3]; MADERA CEDRO [5.6%] | 592.6h | 40,997.59 | 01.04.02.01 | 000000000000021 | 427.39 | 79 | 33763.81 | 10 |
| 130 | 2.4.2.2 | PISO CERAMICO 45 x 45 MODELO CEMENTO BLANCO- ALTO TRANSITO | 11d? | 2022-05-11 | 2022-05-28 |  | 15d |  | start no earlier than 2021-12-22 | CRUCETA DE 3mm [761.8%]; PEON [49.5%]; OPERARIO [98.9%]; FRAGUA DE COLOR; PEGAMENTO EN POLVO; CERAMICO 45 x 45 MODELO CEMENTO BLANCO- ALTO TRANSITO [11427.1%]; AGUA [0.87 m3]; MADERA CEDRO [489.7%] | 433.38h | 12,479.77 | 01.04.02.02 | 000000000000022 | 108.83 | 66.08 | 7191.49 | 10 |
| 131 | 2.4.2.3 | PISO DE CONCRETO EN PATIOS f'c=175kg/cm2; e=15cm FROTACHADO | 10d? | 2022-05-11 | 2022-05-26 |  | 16d |  | start no earlier than 2021-12-22 | CEMENTO PORTLAND TIPO MS (42.5 kg) [933.02 bls]; OFICIAL [93.2%]; PEON [652.5%]; OPERARIO [372.8%]; MEZCLADORA DE CONCRETO TAMBOR 11 p3 22 HP [93.2%]; VIBRADOR DE CONCRETO 4 HP 1.50" [93.2%]; CLAVOS CON CABEZA DE 2 1/2" 3" 4" [3.91 kg]; ARENA FINA [913.4%]; PIEDRA CHANCADA DE 1/2" a 3/4" [50.89 m3]; ARENA GRUESA [50.24 m3]; AGUA [20.23 m3]; MADERA TORNILLO [411.05 p2] | 1053.08h | 73,498.75 | 01.04.02.03 | 000000000000024 | 652.46 | 81.55 | 53208.11 | 70 |
| 132 | 2.4.2.4 | PATIOS.- ENCOFRADO Y DESENCOFRADO | 2d? | 2022-05-11 | 2022-05-14 |  | 24d |  | start no earlier than 2021-12-22 | OFICIAL [37.6%]; PEON [75.2%]; OPERARIO [75.2%]; ALAMBRE NEGRO # 8 [7.82 kg]; CLAVOS CON CABEZA DE 2 1/2" 3" 4" [3.91 kg]; MADERA TORNILLO [100.77 p2] | 30.08h | 1,868.38 | 01.04.02.04 | 000000000000025 | 30.08 | 41.2 | 1239.3 | 20 |
| 133 | 2.4.2.5 | PISO SUAVE - ARENA FINA | 13d? | 2022-05-11 | 2022-05-31 |  | 13d |  | start no earlier than 2021-12-22 | OPERARIO [98.1%]; PEON [73.6%]; ARENA FINA [790.8%]; AGUA [0.31 m3] | 186.47h | 8,048.13 | 01.04.02.05 | 000000000000087 | 51.02 | 82.05 | 4186.19 |  |
| 134 | 2.4.3 | **SARDINELES** | 3d? | 2022-05-11 | 2022-05-15 |  | 23d |  |  |  | 103.4h | 6,194.68 | 01.04.03 | 000000000000027 |  |  |  |  |
| 135 | 2.4.3.1 | SARDINEL.-CONCRETO f'c=175 kg/cm2 (INC. EXCAVACION) | 1d? | 2022-05-11 | 2022-05-12 |  | 25d |  | start no earlier than 2021-12-22 | CEMENTO PORTLAND TIPO MS (42.5 kg) [26.87 bls]; OFICIAL [98.8%]; PEON [494%]; OPERARIO [98.8%]; MEZCLADORA DE CONCRETO TAMBOR 11 p3 22 HP [49.4%]; VIBRADOR DE CONCRETO 4 HP 1.50" [49.4%]; ALAMBRE NEGRO # 8 [7.9 kg]; ACERO CORRUGADO [59.28 kg]; ARENA FINA [43.5%]; PIEDRA CHANCADA DE 1/2" a 3/4" [1.19 m3]; ARENA GRUESA [1.07 m3]; AGUA [1.19 m3]; MADERA TORNILLO [45.05 p2] | 63.65h | 3,901.77 | 01.04.03.01 | 000000000000028 | 39.52 | 65.22 | 2577.49 | 80 |
| 136 | 2.4.3.2 | SARDINEL.- ENCOFRADO Y DESENCOFRADO | 3d? | 2022-05-11 | 2022-05-15 |  | 23d |  | start no earlier than 2021-12-22 | OFICIAL [75.3%]; PEON [37.6%]; OPERARIO [52.7%]; ALAMBRE NEGRO # 8 [8.22 kg]; CLAVOS CON CABEZA DE 2 1/2" 3" 4" [4.11 kg]; MADERA TORNILLO [105.93 p2] | 39.75h | 2,292.91 | 01.04.03.02 | 000000000000029 | 31.62 | 46.5 | 1470.33 | 14 |
| 137 | 2.4.4 | **VEREDAS Y RAMPAS** | 3d? | 2022-05-11 | 2022-05-15 |  | 23d |  |  |  | 280.42h | 20,251.35 | 01.04.04 | 000000000000030 |  |  |  |  |
| 138 | 2.4.4.1 | VEREDAS e=4" DE CONCRETO f'c=175kg/cm2 ACABADO FROTACHADO Y BRUÑADO | 3d? | 2022-05-11 | 2022-05-15 |  | 23d |  | start no earlier than 2021-12-22 | CEMENTO PORTLAND TIPO MS (42.5 kg) [213.28 bls]; OFICIAL [81.9%]; PEON [491.4%]; OPERARIO [245.7%]; MEZCLADORA DE CONCRETO TAMBOR 11 p3 22 HP [81.9%]; VIBRADOR DE CONCRETO 4 HP 1.50" [81.9%]; ARENA FINA [344%]; PIEDRA CHANCADA DE 1/2" a 3/4" [13.51 m3]; ARENA GRUESA [11.06 m3]; AGUA [6.63 m3]; MADERA TORNILLO [242.27 p2] | 239.28h | 17,701.63 | 01.04.04.01 | 000000000000031 | 245.71 | 53.09 | 13044.74 | 100 |
| 139 | 2.4.4.2 | VEREDAS Y RAMPAS.- ENCOFRADO Y DESENCOFRADO | 3d? | 2022-05-11 | 2022-05-15 |  | 23d |  | start no earlier than 2021-12-22 | OFICIAL [34.3%]; PEON [68.6%]; OPERARIO [68.6%]; ALAMBRE NEGRO # 8 [10.7 kg]; CLAVOS CON CABEZA DE 2 1/2" 3" 4" [5.35 kg]; MADERA TORNILLO [137.82 p2] | 41.13h | 2,549.73 | 01.04.04.02 | 000000000000032 | 41.14 | 41.2 | 1694.97 | 20 |
| 140 | 2.5 | **ZOCALOS Y CONTRAZÓCALOS** | 8d? | 2022-06-04 | 2022-06-16 |  | 8d |  |  |  | 577.46h | 26,820.63 | 01.05 | 000000000000033 |  |  |  |  |
| 141 | 2.5.1 | **ZOCALOS** | 5d | 2022-06-04 | 2022-06-11 | 125 | 11d | 0d |  |  | 187.57h | 13,065.51 | 01.05.01 | 000000000000034 |  |  |  |  |
| 142 | 2.5.1.1 | ZOCALOS DE PORCELANATO 60X60 COLOR MATE | 5d | 2022-06-04 | 2022-06-11 |  | 11d |  | start no earlier than 2021-12-22 | CRUCETA DE 3mm [7.5%]; PEON [47.8%]; OPERARIO [95.7%]; FRAGUA DE COLOR; PEGAMENTO EN POLVO; CERAMICA 60X60 DE ALTO TRANSITO [113%]; AGUA [1.23 m3]; MADERA CEDRO [4.8%] | 187.57h | 13,065.51 | 01.05.01.01 | 000000000000088 | 155 | 69.43 | 10761.65 |  |
| 143 | 2.5.2 | **CONTRAZOCALOS** | 8d? | 2022-06-04 | 2022-06-16 | 141SS | 8d |  |  |  | 389.9h | 13,755.11 | 01.05.02 | 000000000000036 |  |  |  |  |
| 144 | 2.5.2.1 | CONTRAZOCALO PORCELANATO 10 x 60 MODELO POTENSA BLANCO PERLA MATE- ALTO TRANSITO | 8d? | 2022-06-04 | 2022-06-16 |  | 8d |  | start no earlier than 2021-12-22 | CRUCETA DE 3mm [160.3%]; PEON [47.7%]; OPERARIO [95.4%]; FRAGUA DE COLOR; PEGAMENTO EN POLVO; PORCELANATO 60 x 60 MODELO POTENSA BLANCO PERLA MATE- ALTO TRANSITO [1602.9%]; AGUA [0.18 m3]; MADERA CEDRO [103%] | 238.25h | 6,170.73 | 01.05.02.01 | 000000000000037 | 228.99 | 13.04 | 2986.03 | 30 |
| 145 | 2.5.2.2 | CONTRAZOCALO DE CEMENTO SIN COLOREAR DE H=10 cm | 8d | 2022-06-04 | 2022-06-16 |  | 8d |  | start no earlier than 2021-12-22 | CEMENTO PORTLAND TIPO MS (42.5 kg) [3.58 bls]; PEON [31.1%]; OPERARIO [93.3%]; ARENA FINA [0.6%] | 79.96h | 4,162.53 | 01.05.02.02 | 000000000000089 | 223.91 | 10.47 | 2344.34 | 24 |
| 146 | 2.5.2.3 | CONTRAZOCALO DE CEMENTO SIN COLOREAR DE H=20 cm | 5d? | 2022-06-04 | 2022-06-11 |  | 11d |  | start no earlier than 2021-12-22 | CEMENTO PORTLAND TIPO MS (42.5 kg) [2.63 bls]; PEON [28.3%]; OPERARIO [84.9%]; ARENA FINA [34%] | 45.6h | 2,173.25 | 01.05.02.03 | 000000000000039 | 84.89 | 13.28 | 1127.34 | 20 |
| 147 | 2.5.2.4 | CONTRAZOCALO CEMENTO SIN COLOREAR H = variable | 3d? | 2022-06-04 | 2022-06-08 |  | 13d |  | start no earlier than 2021-12-22 | CEMENTO PORTLAND TIPO MS (42.5 kg) [1.28 bls]; OPERARIO [81.2%]; PEON [26.8%]; ARENA FINA [16.6%] | 26.08h | 1,248.61 | 01.05.02.04 | 000000000000097 | 41.4 | 15.43 | 638.8 | 17 |
| 148 | 2.6 | **COBERTURAS** | 10d | 2022-03-20 | 2022-04-05 | 114SS | 53d |  |  |  | 6049.77h | 205,418.16 | 01.06 | 000000000000040 |  |  |  |  |
| 149 | 2.6.1 | COBERTURA CON PLANCHA CALAMINON TAT 1060 TERMO-AISLANTE e=25mm (INC. ESTRUCTURA DE SOPORTE METALICA) | 10d | 2022-03-20 | 2022-04-05 |  | 53d |  | start no earlier than 2021-12-22 | PINTURA ANTICORROSIVA [7%]; PINTURA ESMALTE [15.2 gal]; OFICIAL [97.9%]; PEON [97.9%]; OPERARIO [195.8%]; SOLDADORA ELECTRICA MONOFASICA ALTERNA 225 A [48.9%]; ELECTRODO TIPO 6011 - CELLOCORD; TUBO METALICO DE 50 X 100 X 4 mm [224.3%]; SELLO BUTYL DE 3/32" x3/4"; PERFIL "C" 3"X5 lb/pie [339.6%]; CALAMINON TAT 1060 TERMO-AISLANTE e=25mm [321.2%]; PLANCHA ACERO 6.4mm X 1.22m X 2.40 m [0.5%]; ANGULO DE ACERO LIVIANO DE 1" X 1" X 6mm X 6 m [3.1%]; TIRAFON DE 1/4" X 4" [826%]; ARANDELA DE 1/4"; SOMBRERO PARA TIRAFON DE 1/4"; CAPUCHON DE JEBE PARA TIRAFONES | 2129.75h | 143,344.29 | 01.06.01 | 000000000000041 | 660.79 | 184.82 | 122127.21 | 25 |
| 150 | 2.6.2 | COBERTURA LADRILLO PASTELERO ASENTADO CON MEZCLA DE CEMENTO | 10d | 2022-03-20 | 2022-04-05 |  | 53d |  | start no earlier than 2021-12-22 | CEMENTO PORTLAND TIPO MS (42.5 kg) [24.6 bls]; PEON [137.8%]; OPERARIO [98.4%]; ARENA GRUESA [2.82 m3]; MADERA CEDRO [1.8%]; LADRILLO PASTELERO 25 X 25 X 3 cm [4391.5%] | 3703.59h | 52,677.77 | 01.06.02 | 000000000000098 | 702.64 | 29.44 | 20685.72 | 21 |
| 151 | 2.6.3 | IMPERMEABILIZANTE DE TECHOS CON PINTURA ASFALTICA | 10d | 2022-03-20 | 2022-04-05 |  | 53d |  | start no earlier than 2021-12-22 | ASFALTO LIQUIDO RC-250 [82.3%]; PEON [94.1%]; OPERARIO [94.1%] | 216.42h | 9,396.1 | 01.06.03 | 000000000000042 | 856.2 | 6.71 | 5745.1 | 70 |

| ID | WBS | Task | Duration | Start | Finish | Predecessors | Total slack | Free slack | Constraint | Resources | Work | Cost | Text1 | Text8 | Text2 | Text3 | Text4 | Text6 |
| --- | --- | --- | --- | --- | --- | --- | --- | --- | --- | --- | --- | --- | --- | --- | --- | --- | --- | --- |
| 152 | 2.7 | **CARPINTERIA DE MADERA** | 6d? | 2022-05-11 | 2022-05-20 | 125SS | 13d | 0d |  |  | 983.43h | 59,310.11 | 01.07 | 000000000000043 |  |  |  |  |
| 153 | 2.7.1 | PUERTA MACHIEMBRADA | 6d | 2022-05-11 | 2022-05-20 |  | 13d |  | start no earlier than 2021-12-22 | COLA SINTETICA [0.5%]; OFICIAL; OPERARIO; CLAVOS CON CABEZA DE 2 1/2" 3" 4" [2.65 kg]; MADERA CEDRO [310.1%]; LIJA PARA MADERA # 80 [4.7%] | 247.16h | 41,213.37 | 01.07.01 | 000000000000045 | 53.16 | 713.37 | 37922.75 | 0.75 |
| 154 | 2.7.2 | PUERTA MACHIEMBRADA + SOBRELUZ | 6d? | 2022-05-11 | 2022-05-20 |  | 13d |  | start no earlier than 2021-12-22 | COLA SINTETICA [64.1%]; OFICIAL [97%]; OPERARIO [145.6%]; CLAVOS CON CABEZA DE 2 1/2" 3" 4" [0.64 kg]; MADERA CEDRO [41160.7%]; LIJA PARA MADERA # 80 [640.5%] | 535.08h | 11,981.97 | 01.07.02 | 000000000000091 | 12.81 | 472.04 | 6046.83 | 2.2 |
| 155 | 2.7.3 | PIZARRA ACRILICA | 6d? | 2022-05-11 | 2022-05-20 |  | 13d |  | start no earlier than 2021-12-22 | COLA SINTETICA [207.4%]; PEON [43.2%]; OPERARIO [86.4%]; CLAVOS CON CABEZA DE 2 1/2" 3" 4" [0.8 kg]; PERFIL "U" DE ALUMINIO 2"X2"X1mm [5676.5%]; PERFIL "L" DE ALUMINIO 2"X2"X1mm [2268%]; MADERA TORNILLO [73.09 p2]; PLANCHA FORMICA ACRILICA COLOR BLANCO DE 1.20x2.40m; TRIPLAY LUPUNA DE 4' X 8' X 6 mm [946.1%] | 201.18h | 6,114.77 | 01.07.03 | 000000000000046 | 25.92 | 140.11 | 3631.65 |  |
| 156 | 2.8 | **CARPINTERIA METALICA Y HERRERÍA** | 19d? | 2022-05-11 | 2022-06-10 | 152SS | 12d |  |  |  | 4880.22h | 127,157.46 | 01.08 | 000000000000047 |  |  |  |  |
| 157 | 2.8.1 | CANTONERA DE FIERRO EN ESCALERA | 5d? | 2022-05-11 | 2022-05-18 |  | 26d |  | start no earlier than 2021-12-22 | PINTURA ANTICORROSIVA [89.2%]; PINTURA ESMALTE [0.57 gal]; OPERARIO [89.2%]; PLANCHA ESTRIADA 1/8" [499.8%] | 41.6h | 2,772.69 | 01.08.01 | 000000000000048 | 71.4 | 25.49 | 1819.99 | 16 |
| 158 | 2.8.2 | PUERTAS DE INGRESOS PRINCIPALES | 12d? | 2022-05-11 | 2022-05-30 |  | 19d |  | start no earlier than 2021-12-22 | PINTURA ANTICORROSIVA [34.4%]; PINTURA ESMALTE [0.22 gal]; OFICIAL [91.8%]; PEON [45.9%]; OPERARIO [91.8%]; ACERO CORRUGADO [4.41 kg]; ELECTRODO TIPO 6011 - CELLOCORD; ANGULO DE FIERRO 2" X2" X 3/16" [4959%]; PLATINA DE FIERRO 2 1/2" X 3/16" [9642.5%]; PLATINA DE FIERRO 3/16" X 2" X 6m [25346%]; CERRADURA 2 GOLPES TIPO FORTE [454.9%]; CERROJO 1/2"X1"X5" [606.1%]; BISAGRA CON EJE DE 5/8" [1763.2%]; RUEDA CON SOPORTE Y GUIA [440.8%]; PLANCHA ESTRIADA 1/8" [192.8%]; PLANCHA DE ACERO LAF 1/16" X4'X8' [49.6%] | 751.33h | 16,859.69 | 01.08.02 | 000000000000049 | 27.55 | 289.81 | 7984.27 | 2.5 |
| 159 | 2.8.3 | REJILLA METALICA | 2d? | 2022-05-11 | 2022-05-14 |  | 29d |  | start no earlier than 2021-12-22 | PINTURA ANTICORROSIVA [34.3%]; PINTURA ESMALTE [0.34 gal]; PEON [102.5%]; OPERARIO [102.5%]; SOLDADORA ELECTRICA MONOFASICA ALTERNA 225 A [51.3%]; ACERO CORRUGADO [3.33 kg]; ELECTRODO TIPO 6011 - CELLOCORD; PLATINA DE FIERRO 3/16" X 1" X 6m [5763.3%]; ANGULO DE FIERRO 1/8" X1"X1" [779.4%]; BISAGRA ALUMINIZADA 2 1/2" X 2 1/2" [1025.5%]; LIJA PARA FIERRO [205.1%] | 135.08h | 2,853.61 | 01.08.03 | 000000000000092 | 20.51 | 63.85 | 1309.56 | 20 |
| 160 | 2.8.4 | ESTRUCTURA METALICA TIPO I | 2d? | 2022-05-11 | 2022-05-14 |  | 29d |  | start no earlier than 2021-12-22 | CEMENTO PORTLAND TIPO MS (42.5 kg) [8.65 bls]; PINTURA ANTICORROSIVA [20%]; PINTURA ESMALTE [0.11 gal]; OFICIAL [200%]; PEON [200%]; OPERARIO; MEZCLADORA DE CONCRETO TAMBOR 11 p3 22 HP [2%]; VIBRADOR DE CONCRETO 4 HP 1.50" [2%]; ALAMBRE NEGRO # 16 [1 kg]; CLAVOS CON CABEZA DE 2 1/2" 3" 4" [1.18 kg]; ELECTRODO TIPO 6011 - CELLOCORD; CUERDA DE NYLON [3600%]; TUBERIA DE F°N° 2"x3mm STANDARD [540%]; TUBERIA DE F°N° 3"x3mm STANDARD [540%]; TUBERIA DE F°N° 4"x3mm STANDARD [660%]; PLANCHA DE ACERO LAC 1/8" (3.3mm) [6%]; ARENA FINA [27.6%]; PIEDRA CHANCADA DE 1/2" a 3/4" [0.76 m3]; ARENA GRUESA [0.51 m3]; AGUA [0.18 m3]; MADERA TORNILLO [24.23 p2]; TUERCA [1200%]; PERNO 1/2" X 3" CON TUERCA; ARANDELA 1/2"; LIJA PARA FIERRO [400%] | 198.58h | 5,245.46 | 01.08.04 | 000000000000093 |  | 1265.24 | 2530.48 |  |
| 161 | 2.8.5 | BARANDA METALICA EN ESCALERA | 5d? | 2022-05-11 | 2022-05-18 |  | 26d |  | start no earlier than 2021-12-22 | PINTURA ANTICORROSIVA [20.6%]; PINTURA ESMALTE [0.21 gal]; OFICIAL [87%]; OPERARIO [87%]; ELECTRODO TIPO 6011 - CELLOCORD; TUBERIA FºGº 2"X3mm [2576%]; TUBERIA FºGº 1 1/2"X3mm [515.2%]; LIJA DE FIERRO # 80 [772.8%] | 148.48h | 4,218.22 | 01.08.05 | 000000000000051 | 25.76 | 79.1 | 2037.62 | 5.92 |
| 162 | 2.8.6 | REJILLA METALICA PARA CUNETA DE 1"X1"X1/8" (INCLUYE COLOCACION) | 9d? | 2022-05-11 | 2022-05-25 |  | 22d |  | start no earlier than 2021-12-22 | PINTURA ANTICORROSIVA [203.5%]; PINTURA ESMALTE [2.03 gal]; PEON [180.5%]; OPERARIO [180.5%]; SOLDADORA ELECTRICA MONOFASICA ALTERNA 225 A [90.2%]; ACERO CORRUGADO [19.8 kg]; ELECTRODO TIPO 6011 - CELLOCORD; PLATINA DE FIERRO 3/16" X 1" X 6m [34234.2%]; LIJA DE FIERRO # 80 [1218.3%]; ANGULO DE FIERRO 1/8" X1"X1" [4629.5%]; BISAGRA ALUMINIZADA 2 1/2" X 2 1/2" [6091.5%] | 860.65h | 19,741.98 | 01.08.06 | 000000000000052 | 121.83 | 77.96 | 9497.87 | 15 |
| 163 | 2.8.7 | SUMINISTRO E INSTALACION DE ENCUENTRO METALICO ENTRE SOBRETECHO Y PARAPETO | 11d? | 2022-05-11 | 2022-05-28 |  | 20d |  | start no earlier than 2021-12-22 | PEON [47.4%]; OPERARIO [94.7%]; PLANCHA F°G° e=1/20" [2062.9%]; ALCAYATAS DE ACERO DE 1" [112524%]; SILICONA 300 ml | 1358.88h | 18,121.47 | 01.08.07 | 000000000000101 | 187.54 | 29.39 | 5511.8 | 18 |
| 164 | 2.8.8 | SUMINISTRO E INSTALACION DE CANALETA DE EVACUACION PLUVIAL 610 mm | 6d? | 2022-05-11 | 2022-05-20 |  | 25d |  | start no earlier than 2021-12-22 | OPERARIO [92.1%]; CANALETA DE EVACUACION PLUVIAL 610mm [14505.8%] | 189.25h | 7,585.61 | 01.08.08 | 000000000000102 | 138.15 | 38.76 | 5354.69 | 25 |
| 165 | 2.8.9 | SUMINISTRO E INSTALACION DE PROTECTORES DE SEGURIDAD CON °F CUADRADO DE 1/2" | 19d? | 2022-05-11 | 2022-06-10 |  | 12d |  | start no earlier than 2021-12-22 | OFICIAL [49.6%]; PEON [49.6%]; OPERARIO [99.1%]; ELECTRODO TIPO 6011 - CELLOCORD; PROTECTOR DE VENTANA CON °F CUADRADO DE 1/2" [22603%] | 679.4h | 40,043.42 | 01.08.09 | 000000000000100 | 226.03 | 135.5 | 30627.07 | 12 |
| 166 | 2.8.10 | TAPAJUNTA METALICA | 2d? | 2022-05-11 | 2022-05-14 |  | 29d |  | start no earlier than 2021-12-22 | PINTURA ANTICORROSIVA [29.6%]; PINTURA ESMALTE [0.2 gal]; PEON [78.8%]; OPERARIO [78.8%]; PLANCHA DE ACERO LAF 3/16" X4'X8' [220.6%]; TORNILLO DE FIJACION 1 1/2" [19700%]; TARUGO 1/2" X 1 1/2" [19700%] | 421.7h | 5,103.32 | 01.08.10 | 000000000000053 | 39.4 | 34.71 | 1367.57 | 25 |
| 167 | 2.8.11 | BATERIAS ECOLOGICAS DE TRES TACHOS | 1d? | 2022-05-11 | 2022-05-12 |  | 30d |  | start no earlier than 2021-12-22 | OFICIAL; OPERARIO; BATERIA ECOLOGICA DE TRES TACHOS METALICOS [300%] | 19h | 2,883.82 | 01.08.11 | 000000000000054 |  | 837.7 | 2513.1 |  |
| 168 | 2.8.12 | VENTANA METALICA CON REJILLA | 1d? | 2022-05-11 | 2022-05-12 |  | 30d |  | start no earlier than 2021-12-22 | OFICIAL [10.5%]; PEON [10.5%]; OPERARIO [21%]; ELECTRODO TIPO 6011 - CELLOCORD; VENTANA DE FIERRO CON REJA DE SEGURIDAD [105%] | 12.4h | 330.03 | 01.08.12 | 000000000000099 | 1.05 | 177.65 | 186.53 |  |
| 169 | 2.8.13 | ESCALERA DE GATO DE FIERRO GALVANIZADO | 1d? | 2022-05-11 | 2022-05-12 |  | 30d |  | start no earlier than 2021-12-22 | PEON [10%]; OPERARIO [20%]; SOLDADORA A GASOLINA [20%]; ELECTRODO TIPO 6011 - CELLOCORD; TUBERIA FºGº 1 1/2"X3mm [250%]; TUBERIA FºGº 1 "X3mm [200%]; LIJA DE FIERRO # 80 [50%] | 17h | 334.56 | 01.08.13 | 000000000000055 |  | 165.18 | 165.18 |  |
| 170 | 2.8.14 | ESCALERA DE ALUMINIO EN CISTERNA | 1d? | 2022-05-11 | 2022-05-12 |  | 30d |  | start no earlier than 2021-12-22 | PEON [25%]; OPERARIO [50%]; CODO DE ALUMINIO DE 30mm [1400%]; TUBO DE ALUMINIO DE 30mm [600%] | 26h | 575.28 | 01.08.14 | 000000000000056 |  | 283.84 | 283.84 |  |
| 171 | 2.8.15 | PUERTA DE CASETA DE ELECTROBOMBA | 1d? | 2022-05-11 | 2022-05-12 |  | 30d |  | start no earlier than 2021-12-22 | OFICIAL [13.9%]; PEON [13.9%]; OPERARIO [27.8%]; ELECTRODO TIPO 6011 - CELLOCORD; ANGULO DE FIERRO 1/8" X 3/4"X3/4" [99%]; PERFIL TEE DE FIERRO 1/8"X3/4"X3/4" [99%]; PLANCHA GALVANIZADA DE FIERRO 1/8" [115.5%]; ANGULO DE FIERRO 1/8" X1"X1" [528%] | 20.85h | 488.28 | 01.08.15 | 000000000000057 |  | 262.75 | 262.75 | 3.6 |
| 172 | 2.9 | **VENTANAS DE ALUMINIO CON PROTECTOR, CRISTAL Y VIDRIOS** | 5d | 2022-05-11 | 2022-05-18 | 114 | 26d |  |  |  | 323.78h | 98,133.9 | 01.09 | 000000000000058 |  |  |  |  |
| 173 | 2.9.1 | SUMINISTRO E INSTALACION DE VENTANA DE ALUMINIO CON CRISTAL CRUDO DE 6 mm INCOLORO + LAMINA DE SEGURIDAD DE 4 MICRAS Y PROTECTOR DE SEGURIDAD | 5d | 2022-05-11 | 2022-05-18 |  | 26d |  | start no earlier than 2021-12-22 | PEON [99.1%]; OPERARIO [99.1%]; TUBO RECTANGULAR DE ALUMINIO 3 1/4" X 1"x1.5mm [163.6%]; TUBO RECTANGULAR DE ALUMINIO 2 3/8" X 1"x1.5mm [325.7%]; PLATINA DE ALUMINIO 1"x1.5mm [47.6%]; VENTANA CORREDIZA DE ALUMINIO SERIE 25 CON CRISTAL CRUDO DE 6mm + LAMINA DE SEGURIDAD DE 4 MICRAS (SEGUN DETALLE) [74.4%] | 323.78h | 98,133.9 | 01.09.01 | 000000000000059 | 226.03 | 418.23 | 94532.53 |  |
| 174 | 2.10 | **CERRAJERIA** | 12d? | 2022-05-20 | 2022-06-08 | 152 | 13d |  |  |  | 308.65h | 9,437.62 | 01.10 | 000000000000060 |  |  |  |  |
| 175 | 2.10.1 | BISAGRA ALUMINIZADA DE 4" PESADA EN PUERTAS | 12d? | 2022-05-20 | 2022-06-08 |  | 13d |  | start no earlier than 2021-12-22 | OPERARIO [46.7%]; BISAGRA FIERRO ALUMINIZADO PESADO DE 4" [11200%] | 156.8h | 3,994.82 | 01.10.01 | 000000000000061 | 112 | 17.98 | 2013.76 | 10 |
| 176 | 2.10.2 | BISAGRA ALUMINIZADA DE 3" PESADA EN PUERTAS | 6d? | 2022-05-20 | 2022-05-30 |  | 19d |  | start no earlier than 2021-12-22 | OPERARIO [45%]; BISAGRA 3" [5400%] | 75.6h | 1,791.07 | 01.10.02 | 000000000000062 | 54 | 15.48 | 835.92 | 10 |
| 177 | 2.10.3 | CERRADURA TRES GOLPES CON TIRADOR EN PUERTAS | 3d? | 2022-05-20 | 2022-05-25 |  | 22d |  | start no earlier than 2021-12-22 | OPERARIO [91.7%]; CERRADURA 3 GOLPES TIPO FORTE CON TIRADOR [2200%] | 44h | 2,541.22 | 01.10.03 | 000000000000063 | 22 | 83.29 | 1832.38 |  |
| 178 | 2.10.4 | CERRADURA DOS GOLPES EN PUERTAS | 1d? | 2022-05-20 | 2022-05-22 |  | 24d |  | start no earlier than 2021-12-22 | OPERARIO [25%]; CERRADURA EXTERIOR DE DOS GOLPES | 3h | 161.33 | 01.10.04 | 000000000000106 |  | 104.89 | 104.89 |  |
| 179 | 2.10.5 | CHAPA DE POMO CON PESTILLO EN PUERTA | 2d? | 2022-05-20 | 2022-05-23 |  | 23d |  | start no earlier than 2021-12-22 | OPERARIO [56.2%]; CHAPA DE POMO CON PESTILLO DE PUERTA [900%] | 18h | 746.55 | 01.10.05 | 000000000000104 |  | 50.73 | 456.57 |  |
| 180 | 2.10.6 | PICAPORTE EN PUERTAS DE SS.HH | 1d? | 2022-05-20 | 2022-05-22 |  | 24d |  | start no earlier than 2021-12-22 | OPERARIO [28.1%]; PICAPORTE DE 2" [900%] | 11.25h | 202.63 | 01.10.06 | 000000000000105 |  | 8.46 | 76.14 | 32 |

| ID | WBS | Task | Duration | Start | Finish | Predecessors | Total slack | Free slack | Constraint | Resources | Work | Cost | Text1 | Text8 | Text2 | Text3 | Text4 | Text6 |
| --- | --- | --- | --- | --- | --- | --- | --- | --- | --- | --- | --- | --- | --- | --- | --- | --- | --- | --- |
| 181 | 2.11 | **PINTURA** | 5d? | 2022-06-12 | 2022-06-19 | 85 | 0d |  |  |  | 458.77h | 67,601.74 | 01.11 | 000000000000066 |  |  |  |  |
| 182 | 2.11.1 | PINTURA LATEX 2 MANOS EN MUROS Y COLUMNAS | 5d | 2022-06-12 | 2022-06-19 |  | 0d |  | start no earlier than 2021-12-22 | SELLADOR BLANCO PARA MUROS; PINTURA LATEX CON RESINA VINIL ACRILICA [19.8%]; OPERARIO [99.2%]; ANDAMIO METALICO [99.2%]; LIJA PARA MADERA # 80 [99.2%] | 167h | 33,253.53 | 01.11.01 | 000000000000067 | 2460.57 | 12.71 | 31273.84 | 40 |
| 183 | 2.11.2 | PINTURA LATEX 2 MANOS EN CIELO RASO Y VIGAS | 4d | 2022-06-12 | 2022-06-18 |  | 1d |  | start no earlier than 2021-12-22 | SELLADOR BLANCO PARA MUROS; PINTURA LATEX CON RESINA VINIL ACRILICA [16.4%]; OPERARIO [99.1%]; ANDAMIO METALICO [99.1%]; LIJA PARA MADERA # 80 [81.8%] | 126.86h | 27,603.18 | 01.11.02 | 000000000000068 | 1865.07 | 13.98 | 26073.68 | 33 |
| 184 | 2.11.3 | PINTURA ANTICORROSIVA Y ESMALTE 2 MANOS DE CARPINTERIA METALICA | 2d? | 2022-06-12 | 2022-06-15 |  | 3d |  | start no earlier than 2021-12-22 | PINTURA ANTICORROSIVA [166.6%]; PINTURA ESMALTE [1.05 gal]; PEON [27.8%]; OPERARIO [55.5%]; LIJA DE FIERRO # 80 [666.4%] | 21.65h | 795.45 | 01.11.03 | 000000000000069 | 33.32 | 11.89 | 396.17 | 30 |
| 185 | 2.11.4 | PINTURA ESMALTE EN ZOCALO Y CONTRAZOCALO | 5d | 2022-06-12 | 2022-06-19 |  | 0d |  | start no earlier than 2021-12-22 | SELLADOR BLANCO PARA MUROS; PINTURA ESMALTE [9.22 gal]; OPERARIO [91.8%]; LIJA PARA MADERA # 80 [1.7%] | 77.4h | 3,544.69 | 01.11.04 | 000000000000070 | 137.66 | 16.63 | 2289.29 | 15 |
| 186 | 2.11.5 | PINTURA EN PUERTAS DE MADERA | 3d? | 2022-06-12 | 2022-06-16 |  | 2d |  | start no earlier than 2021-12-22 | AGUARRAS [26.9%]; BARNIZ MARINO [268.7%]; LACA SELLADORA PARA MADERA [449.8%]; PEON [97.3%]; OPERARIO [97.3%]; LIJA PARA MADERA # 80 [1168.2%] | 65.87h | 2,404.88 | 01.11.05 | 000000000000071 | 58.41 | 21.95 | 1282.1 | 20 |
| 187 | 2.12 | **JUNTAS** | 6d? | 2022-06-20 | 2022-06-29 | 181 | 0d |  |  |  | 715.5h | 13,993.08 | 01.12 | 000000000000072 |  |  |  |  |
| 188 | 2.12.1 | JUNTAS DE DILATACION CON ESPUMA PLÁSTICA RELLENO CON POLIURETANO | 6d? | 2022-06-20 | 2022-06-29 |  | 0d |  | start no earlier than 2021-12-22 | OPERARIO [96.9%]; SELLADOR ELASTOMERICO POLIURETANO (CARTUCHO DE 300 ml); ESPUMA PLASTICA DURA A/DENSIDAD 2X1m E=2 | 142.52h | 4,808.9 | 01.12.01 | 000000000000107 | 145.35 | 20.05 | 2914.27 | 25 |
| 189 | 2.12.2 | TAPAJUNTA METALICA EN PISOS | 2d? | 2022-06-20 | 2022-06-23 |  | 4d |  | start no earlier than 2021-12-22 | PINTURA ANTICORROSIVA [31.7%]; PINTURA ESMALTE [0.21 gal]; PEON [84.6%]; OPERARIO [84.6%]; PLANCHA DE ACERO LAF 3/16" X4'X8' [237%]; TORNILLO DE FIJACION 1 1/2" [21160%]; TARUGO 1/2" X 1 1/2" [21160%] | 452.98h | 5,479.17 | 01.12.02 | 000000000000108 | 42.32 | 34.71 | 1468.93 | 25 |
| 190 | 2.12.3 | JUNTA DE DILATACION EN PISOS CON TECNOPORT DE e= 3/8" RELLENO CON POLIURETANO | 1d? | 2022-06-20 | 2022-06-21 |  | 5d |  | start no earlier than 2021-12-22 | OFICIAL [9.5%]; OPERARIO [9.5%]; TECNOPORT e= 3/8" [34.2%]; SELLADOR ELASTOMERICO POLIURETANO (CARTUCHO DE 300 ml) | 9.88h | 171.45 | 01.12.03 | 000000000000109 | 5.7 | 12.53 | 71.42 | 60 |
| 191 | 2.12.4 | JUNTAS ASFALTICAS e=1" | 4d? | 2022-06-20 | 2022-06-26 |  | 2d |  | start no earlier than 2021-12-22 | ASFALTO LIQUIDO RC-250 [8127.4%]; OPERARIO [82.9%]; ARENA FINA [232.2%] | 110.12h | 3,533.55 | 01.12.04 | 000000000000110 | 232.21 | 9.57 | 2222.25 | 70 |
| 192 | 2.13 | **JUEGOS INFANTILES** | 1d? | 2022-06-12 | 2022-06-13 | 181SS | 10d |  |  |  | 4h | 5,762 | 01.13 | 000000000000080 |  |  |  |  |
| 193 | 2.13.1 | JUEGO INFANTILES - NIVEL INCIAL | 1d? | 2022-06-12 | 2022-06-13 |  | 10d |  | start no earlier than 2021-12-22 | SUBE Y BAJA CON CUATRO ASIENTOS; TOBOGAN; COLUMBIO METALICO L=230 M CON 3 ASIENTOS; PASAMANO METALICO L=4.00 M. | 4h | 5,762 | 01.13.01 | 000000000000131 |  | 5730 | 5730 |  |
| 194 | 2.14 | **VARIOS** | 3d? | 2022-06-12 | 2022-06-16 | 181SS | 8d |  |  |  | 128.4h | 4,562.67 | 01.14 | 000000000000075 |  |  |  |  |
| 195 | 2.14.1 | SUMINISTRO E INSTALACION DE STICKER PARA SEÑALITICA DE SEGURIDAD | 3d? | 2022-06-12 | 2022-06-16 |  | 8d |  | start no earlier than 2021-12-22 | PEON [98.3%]; STICKER PARA SEÑALETICA DE SEGURIDAD [5900%] | 82.6h | 1,445.03 | 01.14.01 | 000000000000077 | 59 | 9.58 | 565.22 | 20 |
| 196 | 2.14.2 | SUMINISTRO E INSTALACION DE LAMPARAS DE EMERGENCIA | 3d? | 2022-06-12 | 2022-06-16 |  | 8d |  | start no earlier than 2021-12-22 | OPERARIO [83.3%]; LAMPARA DE EMERGENCIA 24 LEDS [500%] | 25h | 1,380.65 | 01.14.02 | 000000000000129 |  | 171.25 | 856.25 |  |
| 197 | 2.14.3 | SUMINISTRO E INSTALACION DE BOTIQUIN | 1d? | 2022-06-12 | 2022-06-13 |  | 10d |  | start no earlier than 2021-12-22 | OPERARIO [60%]; SUMINISTRO E INSTALACION DE BOTIQUIN [300%] | 7.8h | 803.41 | 01.14.03 | 000000000000130 |  | 221.05 | 663.15 |  |
| 198 | 2.14.4 | SUMINISTRO E INSTALACION DE EXTINTOR DE POLVO QUIMICO SECO | 1d? | 2022-06-12 | 2022-06-13 |  | 10d |  | start no earlier than 2021-12-22 | PEON; EXTINTOR DE POLVO QUIMICO SECO (PQS) - ABC DE 6 Kg [500%] | 13h | 933.59 | 01.14.04 | 000000000000078 |  | 151.07 | 755.35 |  |
| 199 | 3 | **INSTALACIONES SANITARIAS** | 26d? | 2022-05-11 | 2022-06-21 |  | 5d |  |  |  | 3747.56h | 118,292.32 | 01 | 000000000000001 |  |  |  |  |
| 200 | 3.1 | **MOVIMIENTO DE TIERRAS** | 4d? | 2022-05-11 | 2022-05-17 | 125SS | 5d | 0d |  |  | 99.35h | 5,007.7 | 01.01 | 000000000000002 |  |  |  |  |
| 201 | 3.1.1 | EXCAVACION DE ZANJAS PARA H=0.80m, PARA TUBERIA DE 160 Y 200 mm | 1d? | 2022-05-11 | 2022-05-12 |  | 8d |  | start no earlier than 2021-12-22 | OFICIAL [80.8%]; PEON [80.8%]; RETROEXCAVADOR SOBRE LLANTAS 58 HP 1 yd3 [80.8%] | 19.4h | 1,792.67 | 01.01.01 | 000000000000003 | 96.95 | 9.28 | 899.7 | 120 |
| 202 | 3.1.2 | RELLENO C/ARENA HASTA e=0.20m LA CLAVE PARA TUBO DE 160 Y 200 mm | 4d? | 2022-05-11 | 2022-05-17 |  | 5d |  | start no earlier than 2021-12-22 | PEON [80.8%]; OPERARIO [8.1%] | 28.43h | 1,034.73 | 01.01.02 | 000000000000004 | 96.95 | 5.42 | 525.47 | 30 |
| 203 | 3.1.3 | RELLENO Y COMPACTACION DE ZANJAS C/ MATERIAL PROPIO CON EQUIPO H=0.8m | 4d? | 2022-05-11 | 2022-05-17 |  | 5d |  | start no earlier than 2021-12-22 | PEON [80.8%]; PLANCHA COMPACTADORA VIBRAT. 4.0 H.P. [20.2%]; AGUA [14.54 m3] | 32.32h | 1,178.87 | 01.01.03 | 000000000000005 | 96.95 | 6.5 | 630.18 | 30 |
| 204 | 3.1.4 | REFINE, NIVELACION DE ZANJAS P/TUBO DE 160 Y 200 mm | 1d? | 2022-05-11 | 2022-05-12 |  | 8d |  | start no earlier than 2021-12-22 | PEON [97%]; OPERARIO [9.7%] | 8.53h | 309.95 | 01.01.04 | 000000000000006 | 96.95 | 1.62 | 157.06 | 100 |
| 205 | 3.1.5 | CAMA DE ARENA GRUESA e=0.10m PARA TUBO DE 160 Y 200 mm | 2d? | 2022-05-11 | 2022-05-14 |  | 7d |  | start no earlier than 2021-12-22 | PEON [60.6%]; OPERARIO [6.1%]; ARENA GRUESA [6.98 m3] | 10.67h | 691.48 | 01.01.05 | 000000000000007 | 96.95 | 4.77 | 462.45 | 80 |

| ID | WBS | Task | Duration | Start | Finish | Predecessors | Total slack | Constraint | Resources | Work | Cost | Text1 | Text8 | Text3 | Text4 | Text6 | Text2 |
| --- | --- | --- | --- | --- | --- | --- | --- | --- | --- | --- | --- | --- | --- | --- | --- | --- | --- |
| 206 | 3.2 | **SISTEMA DE AGUA POTABLE EXTERIOR** | 3d? | 2022-05-11 | 2022-05-15 | 200SS | 28d |  |  | 332.98h | 7,584.1 | 01.02 | 000000000000008 |  |  |  |  |
| 207 | 3.2.1 | TUBERIA PVC-SAP 2" CLASE 10 | 1d? | 2022-05-11 | 2022-05-12 |  | 30d | start no earlier than 2021-12-22 | PEGAMENTO PARA TUBERIA PVC [1.1%]; PEON [26.7%]; OPERARIO [26.7%]; TUBERIA PVC CLASE 10 SP 2" X 5m [840%]; REDUCCION PVC SAP PARA AGUA CON ROSCA 2" A 1 1/2" [333.4%]; TEE PVC SAP PARA AGUA CON ROSCA DE 2" [222.2%] | 18.23h | 392.68 | 01.02.01 | 000000000000009 | 24.05 | 192.4 | 30 |  |
| 208 | 3.2.2 | TUBERIA PVC-SAP 1 1/2" CLASE 10 | 3d? | 2022-05-11 | 2022-05-15 |  | 28d | start no earlier than 2021-12-22 | PEGAMENTO PARA TUBERIA PVC [6.5%]; PEON [72.7%]; OPERARIO [72.7%]; TUBERIA PVC CLASE 10 SP 1 1/2" X 5m [6867%]; REDUCCION PVC SAP PARA AGUA CON ROSCA 1 1/2" A 1" [300.8%]; CODO PVC SAP PARA AGUA CON ROSCA DE 1 1/2" X 90° [268.1%]; TEE PVC SAP PARA AGUA CON ROSCA DE 1 1/2" [300.8%] | 112.35h | 2,424.84 | 01.02.02 | 000000000000010 | 16.53 | 1081.06 | 30 | 65.4 |
| 209 | 3.2.3 | TUBERIA PVC-SAP 1" CLASE 10 | 2d? | 2022-05-11 | 2022-05-14 |  | 29d | start no earlier than 2021-12-22 | PEGAMENTO PARA TUBERIA PVC [4.8%]; PEON [79.5%]; OPERARIO [79.5%]; TUBERIA PVC CLASE 10 ROSCADO 1" X 5M [5008.5%]; REDUCCION PVC SAP PARA AGUA CON ROSCA 1 1/2" A 3/4" [151.2%]; CODO PVC SAP - CLASE 10 SP - 1" X 90 [75.8%]; TEE PVC SAP CLASE 10 SP 1" [264.3%] | 80.5h | 1,815.9 | 01.02.03 | 000000000000011 | 17.77 | 847.63 | 30 | 47.7 |
| 210 | 3.2.4 | TUBERIA PVC-SAP 3/4" CLASE 10 | 2d? | 2022-05-11 | 2022-05-14 |  | 29d | start no earlier than 2021-12-22 | PEGAMENTO PARA TUBERIA PVC [3.5%]; PEON [58.9%]; OPERARIO [58.9%]; TUBERIA PVC CLASE 10 SP 3/4" X 5M [3711.8%]; REDUCCION PVC SAP PARA AGUA CON ROSCA 3/4" A 1/2" [161.9%]; CODO PVC SAP - CLASE 10 SP - 3/4" X 90 [135%]; TEE PVC SAP CLASE 10 SP 3/4" [81%] | 59.8h | 1,224.81 | 01.02.04 | 000000000000012 | 14.31 | 505.86 | 30 | 35.35 |
| 211 | 3.2.5 | VALVULA TIPO BOLA 1 1/2" | 1d? | 2022-05-11 | 2022-05-12 |  | 30d | start no earlier than 2021-12-22 | PEON [37.5%]; OPERARIO [37.5%]; CINTA TEFLON [750%]; CODO FIERRO GALVANIZADO 1 1/2" X 90° [900%]; VALVULAS TIPO BOLA 1 1/2" [300%]; TEE DE FIERRO GALVANIZADO 1 1/2" [300%]; UNION UNIVERSAL DE Fº Gº DE 1 1/2" [600%]; NIPLE DE FIERRO GALVANIZADO DE 1 1/2" X 5" [1200%]; NIPLE DE FIERRO GALVANIZADO DE 1 1/2" X 10" [300%] | 49.5h | 1,200.24 | 01.02.05 | 000000000000013 | 242.58 | 727.74 |  |  |
| 212 | 3.2.6 | CAJA PREFABRICADA P/VALVULAS | 1d? | 2022-05-11 | 2022-05-12 |  | 30d | start no earlier than 2021-12-22 | PEON [60%]; OPERARIO [60%]; CAJA PREFABRICADA DE CONCRETO C/TAPA PARA VALVULAS [300%] | 12.6h | 525.63 | 01.02.06 | 000000000000014 | 100.81 | 302.43 |  |  |
| 213 | 3.3 | **SISTEMA DE RIEGO** | 1d? | 2022-05-11 | 2022-05-12 | 200SS | 30d |  |  | 20.02h | 1,167.05 | 01.03 | 000000000000015 |  |  |  |  |
| 214 | 3.3.1 | LLAVE DE RIEGO C/GRIFO DE ½" EN CAJUELA CONCRETO F'c 140 S/D | 1d? | 2022-05-11 | 2022-05-12 |  | 30d | start no earlier than 2021-12-22 | CEMENTO PORTLAND TIPO MS (42.5 kg) [2.8 bls]; SELLADOR BLANCO PARA MUROS [20%]; PINTURA ESMALTE [0.2 gal]; PEON [83.3%]; OPERARIO [83.3%]; MEZCLADORA DE CONCRETO TAMBOR 11 p3 22 HP [3.3%]; VIBRADOR DE CONCRETO 4 HP 1.50" [3.3%]; ALAMBRE NEGRO # 16 [0.65 kg]; ALAMBRE NEGRO # 8 [0.95 kg]; CLAVOS CON CABEZA DE 2 1/2" 3" 4" [0.6 kg]; ACERO CORRUGADO [13.95 kg]; CINTA TEFLON [75%]; ARENA FINA [5%]; PIEDRA CHANCADA DE 1/2" a 3/4" [0.4 m3]; ARENA GRUESA [0.15 m3]; AGUA [0.05 m3]; MADERA TORNILLO [14.2 p2]; MADERA CEDRO [15%]; GRIFO BRONCE 1/2" [500%] | 20.02h | 1,167.05 | 01.03.01 | 000000000000016 | 122.68 | 613.4 |  |  |
| 215 | 3.4 | **SISTEMA DE DESAGUE EXTERIOR** | 4d? | 2022-05-11 | 2022-05-17 | 200SS | 27d |  |  | 433.85h | 14,983.73 | 01.04 | 000000000000017 |  |  |  |  |
| 216 | 3.4.1 | TUBERIA DE PVC SAL 4" | 4d? | 2022-05-11 | 2022-05-17 |  | 27d | start no earlier than 2021-12-22 | PEGAMENTO PARA TUBERIA PVC [310.5%]; PEON [77.6%]; OPERARIO [77.6%]; TUBO PVC SAL -4" (3m) [6520.5%]; UNION PVC SAL 4" [2395.2%] | 141.92h | 3,589.35 | 01.04.01 | 000000000000018 | 29.32 | 1820.77 | 20 | 62.1 |
| 217 | 3.4.2 | SUMINISTRO E INSTALACION DE TUBERIA PVC 160mm ISO 4435 S-20 | 2d? | 2022-05-11 | 2022-05-14 |  | 29d | start no earlier than 2021-12-22 | LUBRICANTE PARA TUBO PVC [504.1%]; OFICIAL [138.5%]; PEON [69.3%]; OPERARIO [69.3%]; TUBERIA PVC 160mm ISO 4435 S-20 [9985.9%]; CODO PVC 160mmX45 [484.8%]; ANILLO DE JEBE A-7.5 DE 160mm [3262.4%] | 186.7h | 5,927.87 | 01.04.02 | 000000000000019 | 40.28 | 3905.15 | 70 | 96.95 |
| 218 | 3.4.3 | CAJA DE REGISTRO PREFABRICADA DE 12" X 24" CON TAPA DE CONCRETO | 3d? | 2022-05-11 | 2022-05-15 |  | 28d | start no earlier than 2021-12-22 | CEMENTO PORTLAND TIPO MS (42.5 kg) [3 bls]; PEON; OPERARIO; ARENA FINA [12%]; CAJA PREFABRICADA DE CONCRETO C/TAPA 12" X 24" [600%] | 54.12h | 2,671.09 | 01.04.03 | 000000000000020 | 266.79 | 1600.74 |  |  |
| 219 | 3.4.4 | CAJA DE REGISTRO PREFABRICADA DE 24" X 24" CON TAPA DE CONCRETO | 3d? | 2022-05-11 | 2022-05-15 |  | 28d | start no earlier than 2021-12-22 | CEMENTO PORTLAND TIPO MS (42.5 kg) [3 bls]; PEON; OPERARIO; ARENA FINA [12%]; CAJA PREFABRICADA DE CONCRETO C/TAPA 24" X 24" [300%] | 51.12h | 2,795.41 | 01.04.04 | 000000000000021 | 583.02 | 1749.06 |  |  |
| 220 | 3.5 | **PRUEBA HIDRAULICA DE CISTERNA, TANQUE Y SISTEMA DE BOMBEO** | 2d? | 2022-05-11 | 2022-05-14 | 200SS | 29d |  |  | 32h | 1,573.33 | 01.05 | 000000000000022 |  |  |  |  |
| 221 | 3.5.1 | PRUEBA HIDRAULICA DE CISTERNA Y EQUIPO DE BOMBEO | 2d? | 2022-05-11 | 2022-05-14 |  | 29d | start no earlier than 2021-12-22 | OPERARIO [200%] | 32h | 1,573.33 | 01.05.01 | 000000000000023 | 798.29 | 798.29 | 0.5 |  |
| 222 | 3.6 | **APARATOS SANITARIOS Y ACCESORIOS** | 6d? | 2022-05-17 | 2022-05-26 | 200 | 21d |  |  | 363.95h | 20,152.42 | 01.06 | 000000000000024 |  |  |  |  |
| 223 | 3.6.1 | INODORO TANQUE BAJO DE LOSA INCLUYE ACCESORIOS PARA INCIAL Y PRIMARIA | 3d? | 2022-05-17 | 2022-05-22 |  | 24d | start no earlier than 2021-12-22 | OFICIAL [88.9%]; OPERARIO [88.9%]; INODORO TANQUE BAJO NORMAL BLANCO INCLUYE ACCESORIOS [800%]; TAPA PARA INODORO TIPO MELIMEX [800%] | 58.67h | 3,713 | 01.06.01 | 000000000000081 | 332.55 | 2660.4 |  |  |
| 224 | 3.6.2 | URINARIOS DE LOZA DE PICO | 2d? | 2022-05-17 | 2022-05-20 |  | 25d | start no earlier than 2021-12-22 | PEON [66.7%]; OPERARIO [66.7%]; URINARIO PICO COLOR INC. ACCESORIOS [400%]; GRIFERIA PARA URINARIO DE PICO [400%] | 29.33h | 1,476.31 | 01.06.02 | 000000000000026 | 242.41 | 969.64 |  |  |
| 225 | 3.6.3 | LAVATORIO DE LOZA BLANCA | 3d? | 2022-05-17 | 2022-05-22 |  | 24d | start no earlier than 2021-12-22 | PEON [88.9%]; OPERARIO [88.9%]; LLAVE DE LAVATORIO STANDAR [800%]; LAVATORIO LOZA BLANCA (SEGUN DISEÑO INC. ACCESORIOS) [800%]; GRIFERIA PARA LAVADERO [800%] | 66.67h | 4,251.42 | 01.06.03 | 000000000000027 | 396.76 | 3174.08 |  |  |
| 226 | 3.6.4 | DISPENSADOR DE JABON LIQUIDO | 1d? | 2022-05-17 | 2022-05-18 |  | 26d | start no earlier than 2021-12-22 | CEMENTO PORTLAND TIPO MS (42.5 kg) [1.6 bls]; OPERARIO; PORCELANA BLANCA [48%]; DISPENSADOR DE JABON LIQUIDO [800%] | 16.48h | 1,426.89 | 01.06.04 | 000000000000028 | 142.48 | 1139.84 |  |  |
| 227 | 3.6.5 | PAPELERA DE CERAMICA | 3d? | 2022-05-17 | 2022-05-22 |  | 24d | start no earlier than 2021-12-22 | CEMENTO PORTLAND TIPO MS (42.5 kg) [0.36 bls]; PEON [37.5%]; OPERARIO [75%]; PORCELANA BLANCA [108%]; PAPELERA DE LOSA BLANCA 15 X 15 cm [1800%] | 46.08h | 1,618.81 | 01.06.05 | 000000000000029 | 47.18 | 849.24 |  | 18 |
| 228 | 3.6.6 | SEPARADOR DE MELAMINA 18mm color blanco | 1d? | 2022-05-17 | 2022-05-18 |  | 26d | start no earlier than 2021-12-22 | PEON [16.7%]; OPERARIO [33.3%]; CANTONERAS DE PVC [160%]; PLANCHA DE MELAMINA SOFT DE COLOR 18mm [10%]; ANGULO DE ACERO LIVIANO DE 3" X 3" X 3/16" [17%]; TORNILLO DE FIJACION 2" C/TARUGOS DE PLASTICO [1200%] | 17.87h | 324.92 | 01.06.06 | 000000000000030 | 126.36 | 126.36 |  |  |
| 229 | 3.6.7 | TRAMPA DE GRASA TIPO HEVEX MODELO IG-20 | 6d? | 2022-05-17 | 2022-05-26 |  | 21d | start no earlier than 2021-12-22 | PEON [88.9%]; OPERARIO [88.9%]; TRAMPA DE GRASA TIPO HEVEX MODELO IG-20 [800%] | 93.33h | 5,865.3 | 01.06.07 | 000000000000031 | 503.83 | 4030.64 | 1.5 |  |
| 230 | 3.6.8 | ESPEJO BISELADO | 1d? | 2022-05-17 | 2022-05-18 |  | 26d | start no earlier than 2021-12-22 | PEON [12.8%]; OPERARIO [25.6%]; ESPEJO BISELADO [131.8%] | 4.38h | 336.68 | 01.06.08 | 000000000000032 | 202.29 | 258.93 |  | 1.28 |
| 231 | 3.6.9 | PAPELERA PLASTICA | 2d? | 2022-05-17 | 2022-05-20 |  | 25d | start no earlier than 2021-12-22 | PEON [30%]; PAPELERA PLASTICA [1800%] | 22.8h | 584.6 | 01.06.09 | 000000000000033 | 19.87 | 357.66 | 15 | 18 |
| 232 | 3.6.10 | LAVADERO DE ACERO INOXIDABLE | 1d? | 2022-05-17 | 2022-05-18 |  | 26d | start no earlier than 2021-12-22 | PEON [33.3%]; OPERARIO [33.3%]; LLAVE DE LAVADERO PICO GIRATORIO; LAVADERO DE ACERO INOXIDABLE CON ESCURRIDERO; TUBO DE ABASTO 1/2" X 1/2" CORRUGADO | 8.33h | 554.49 | 01.06.10 | 000000000000034 | 419.82 | 419.82 |  |  |

| ID | WBS | Task | Duration | Start | Finish | Predecessors | Total slack | Free slack | Constraint | Resources | Work | Cost | Text1 | Text8 | Text2 | Text3 | Text4 | Text6 |
| --- | --- | --- | --- | --- | --- | --- | --- | --- | --- | --- | --- | --- | --- | --- | --- | --- | --- | --- |
| 233 | 3.7 | **INSTALACIONES SANITARIAS DE DESAGUE** | 6d? | 2022-05-17 | 2022-05-26 | 200 | 5d | 0d |  |  | 842.81h | 26,832.11 | 01.07 | 000000000000035 |  |  |  |  |
| 234 | 3.7.1 | SALIDA DE DESAGUE EN PVC | 5d | 2022-05-17 | 2022-05-25 |  | 6d |  | start no earlier than 2021-12-22 | PEGAMENTO PARA TUBERIA PVC [2.5%]; PEON; OPERARIO; TUBO PVC SAL - 2" (3m) [30%]; TUBO PVC SAL -4" (3m) [30%]; CODO PVC SAL 2" X 90° [32.7%]; CODO PVC SAL 4" X 90° [17.3%]; YEE PVC SAL DE 2" X 2" [32.7%]; YEE PVC SAL DE 4" X 4" [17.3%]; TEE SANITARIA SIMPLE PVC SAL DE 4" [17.3%] | 151.91h | 8,444.71 | 01.07.01 | 000000000000036 | 60 | 103.49 | 6209.4 |  |
| 235 | 3.7.2 | SALIDA PARA VENTILACION | 5d? | 2022-05-17 | 2022-05-25 |  | 6d |  | start no earlier than 2021-12-22 | PEGAMENTO PARA TUBERIA PVC [1.7%]; PEON [85%]; OPERARIO [85%]; TUBO PVC SAL - 2" (3m) [3400%]; CODO PVC SAL 2" X 90° [3400%] | 136.02h | 3,521.17 | 01.07.02 | 000000000000037 | 17 | 92.12 | 1566.04 |  |
| 236 | 3.7.3 | TUBERIA PVC-SAL 2" | 6d? | 2022-05-17 | 2022-05-26 |  | 5d |  | start no earlier than 2021-12-22 | PEGAMENTO PARA TUBERIA PVC [11%]; PEON [183.3%]; OPERARIO [91.7%]; TUBO PVC - SAL - 2" (3M) [11330%] | 245.42h | 6,408.65 | 01.07.03 | 000000000000038 | 110 | 26.5 | 2915 | 20 |
| 237 | 3.7.4 | TUBERIA PVC-SAL 4" | 4d? | 2022-05-17 | 2022-05-23 |  | 7d |  | start no earlier than 2021-12-22 | PEGAMENTO PARA TUBERIA PVC [12.4%]; PEON [155.2%]; OPERARIO [77.6%]; TUBO PVC SAL -4" (3m) [6520.5%] | 139.83h | 3,919.42 | 01.07.04 | 000000000000039 | 62.1 | 31.19 | 1936.9 | 20 |
| 238 | 3.7.5 | REGISTROS DE BRONCE DE 4" | 3d? | 2022-05-17 | 2022-05-22 |  | 8d |  | start no earlier than 2021-12-22 | OPERARIO [94.4%]; REGISTRO DE BRONCE DE 4" ROSCADO [1700%] | 39.67h | 1,492.83 | 01.07.05 | 000000000000040 | 17 | 47.52 | 807.84 |  |
| 239 | 3.7.6 | REGISTROS DE BRONCE DE 2" | 2d? | 2022-05-17 | 2022-05-20 |  | 9d |  | start no earlier than 2021-12-22 | OPERARIO [66.7%]; REGISTRO DE BRONCE DE 2" [800%] | 18.67h | 656.02 | 01.07.06 | 000000000000041 |  | 41.71 | 333.68 |  |
| 240 | 3.7.7 | PRUEBA HIDRAULICA Y ESCORRENTIA TUB. DESAGUE | 2d? | 2022-05-17 | 2022-05-20 |  | 9d |  | start no earlier than 2021-12-22 | CEMENTO PORTLAND TIPO MS (42.5 kg) [1.03 bls]; YESO EN BOLSAS DE 28 kg [103.4%]; PEON [172.3%]; OPERARIO [86.2%]; ARENA GRUESA [0.21 m3]; AGUA [6.08 m3]; LADRILLO KK TIPO IV 24X14X9cm (maquinado) [6892%] | 111.3h | 2,389.3 | 01.07.07 | 000000000000042 | 172.3 | 5.52 | 951.1 | 100 |
| 241 | 3.8 | **INSTALACIONES SANITARIAS DE AGUA** | 9d? | 2022-05-27 | 2022-06-10 | 233 | 5d | 0d |  |  | 789.62h | 15,751.4 | 01.08 | 000000000000043 |  |  |  |  |
| 242 | 3.8.1 | SALIDA DE AGUA FRIA.- PVC | 9d? | 2022-05-27 | 2022-06-10 |  | 5d |  | start no earlier than 2021-12-22 | PEGAMENTO PARA TUBERIA PVC [106.1%]; PEON [94.4%]; OPERARIO [94.4%]; HIPOCLORITO DE CALCIO AL 70% [34%]; CINTA TEFLON [6120%]; TUBERIA PVC CLASE 10 SP 1/2" X 5M [5100%]; TUBERIA PVC CLASE 10 SP 3/4" X 5M [3400%]; CODO PVC SAP - CLASE 10 SP - 1/2" X 90 [6800%]; CODO PVC SAP - CLASE 10 SP - 3/4" X 90 [3400%]; TEE PVC SAP CLASE 10 SP 1/2" [3400%]; TEE PVC SAP CLASE 10 SP 3/4" [3400%] | 453.6h | 8,781.16 | 01.08.01 | 000000000000044 | 34 | 100.54 | 3418.36 |  |
| 243 | 3.8.2 | TUBERIA PVC CLASE 10 - 1/2" ROSCADA | 2d? | 2022-05-27 | 2022-05-30 |  | 12d |  | start no earlier than 2021-12-22 | PEON [96%]; OPERARIO [96%]; CINTA TEFLON [885.8%]; TUBERIA PVC CLASE 10 SP 1/2" X 5M [6082.1%]; UNION SIMPLE PVC SAP CLASE 10 SP 1/2" [1217.6%] | 112.55h | 2,054.16 | 01.08.02 | 000000000000045 | 59.05 | 12.91 | 762.34 | 30.77 |
| 244 | 3.8.3 | TUBERIA PVC CLASE 10 - 3/4" ROSCADA | 2d? | 2022-05-27 | 2022-05-30 |  | 12d |  | start no earlier than 2021-12-22 | PEON [67%]; OPERARIO [67%]; CINTA TEFLON [618.8%]; TUBERIA PVC CLASE 10 SP 3/4" X 5M [4248.8%]; REDUCCION PVC SAP PARA AGUA CON ROSCA 3/4" A 1/2" [1693.7%]; UNION SIMPLE PVC SAP CLASE 10 SP 3/4" [940.9%] | 96.48h | 1,655.25 | 01.08.03 | 000000000000046 | 41.25 | 14.78 | 609.68 | 30.77 |
| 245 | 3.8.4 | VALVULA DE COMPUERTA DE BRONCE 3/4" | 2d? | 2022-05-27 | 2022-05-30 |  | 12d |  | start no earlier than 2021-12-22 | PEON [83.3%]; OPERARIO [83.3%]; CINTA TEFLON [2000%]; UNION UNIVERSAL DE Fº Gº DE 3/4" [2000%]; NIPLE FºGº 1/2" X 1 1/4" [2000%]; VALVULA COMPUERTA 3/4" [1000%] | 96.67h | 2,095.62 | 01.08.04 | 000000000000047 | 10 | 98.23 | 982.3 |  |
| 246 | 3.8.5 | CAJA DE MADERA PARA VALVULA | 2d? | 2022-05-27 | 2022-05-30 |  | 12d |  | start no earlier than 2021-12-22 | PEON [41.7%]; OPERARIO [83.3%]; CAJA DE MADERA P/VALVULA [1000%] | 30h | 1,148.43 | 01.08.05 | 000000000000048 | 10 | 63.03 | 630.3 |  |
| 247 | 3.8.6 | PRUEBA HIDRAULICA EN TUBERIA DE AGUA | 1d? | 2022-05-27 | 2022-05-28 |  | 13d |  | start no earlier than 2021-12-22 | PEON [2.2%]; OPERARIO [1.1%]; BALDE PRUEBA TAPON ABRAZADERA Y ACCESORIOS [0.6%]; AGUA [0.12 m3] | 0.32h | 16.78 | 01.08.06 | 000000000000049 |  | 6.19 | 6.19 | 90 |
| 248 | 3.9 | **TUBERIAS Y ACCESORIOS TANQUE ELEVADO** | 2d? | 2022-06-10 | 2022-06-13 | 241 | 5d | 0d |  |  | 521.07h | 15,605.76 | 01.09 | 000000000000050 |  |  |  |  |
| 249 | 3.9.1 | TUBERIA FIERRO GALVANIZADO 3" | 1d? | 2022-06-10 | 2022-06-11 |  | 6d |  | start no earlier than 2021-12-22 | PEON [10%]; OPERARIO [10%]; TUBERIA FºGº 3"X3.3mm [309%]; CINTA TEFLON [60%]; UNION UNIVERSAL DE FIERRO GALVANIZADO 3"; CODO DE FIERRO GALVANIZADO CACHIMBA DE 3" X 90° | 7.28h | 283.33 | 01.09.01 | 000000000000051 |  | 68.22 | 204.66 | 30 |
| 250 | 3.9.2 | TUBERIA DE PVC SAP 2" CLASE 10 | 1d? | 2022-06-10 | 2022-06-11 |  | 6d |  | start no earlier than 2021-12-22 | PEGAMENTO PARA TUBERIA PVC [1.4%]; PEON [48.3%]; OPERARIO [48.3%]; TUBERIA PVC CLASE 10 SP 2" X 5m [1522.5%]; CODO PVC SAP PARA AGUA CON ROSCA DE 2" X 90°; TEE PVC SAP PARA AGUA CON ROSCA DE 2" | 24.98h | 588.77 | 01.09.02 | 000000000000052 | 14.5 | 20.02 | 290.29 | 30 |
| 251 | 3.9.3 | TUBERIA DE PVC SAP 2 1/2" CLASE 10 | 1d? | 2022-06-10 | 2022-06-11 |  | 6d |  | start no earlier than 2021-12-22 | PEGAMENTO PARA TUBERIA PVC [0.7%]; PEON [23.3%]; OPERARIO [23.3%]; TUBERIA PVC CLASE 10 SP 2 1/2" X 5m [735%]; CODO PVC SAP PARA AGUA CON ROSCA DE 2 1/2" X 90°; TEE PVC SAP PARA AGUA CON ROSCA DE 2 1/2" | 13.08h | 324.34 | 01.09.03 | 000000000000053 |  | 24.58 | 172.06 | 30 |
| 252 | 3.9.4 | TUBERIA FIERRO GALVANIZADO 2" | 1d? | 2022-06-10 | 2022-06-11 |  | 6d |  | start no earlier than 2021-12-22 | PEON [36.7%]; OPERARIO [36.7%]; TUBERIA FºGº 2"X3.3mm [1133%]; CINTA TEFLON [220%]; CODO FIERRO GALVANIZADO 2" X 90° [300%]; UNION SIMPLE DE FIERRO GALVANIZADO DE 2" [300%] | 25.4h | 732.21 | 01.09.04 | 000000000000054 | 11 | 41.29 | 454.19 | 30 |
| 253 | 3.9.5 | TUBERIA FIERRO GALVANIZADO 1 1/2" | 1d? | 2022-06-10 | 2022-06-11 |  | 6d |  | start no earlier than 2021-12-22 | PEON [38.3%]; OPERARIO [38.3%]; TUBERIA FºGº 1 1/2"X3.3mm [1184.5%]; CINTA TEFLON [230%]; CODO FIERRO GALVANIZADO 1 1/2" X 90° [300%]; UNION SIMPLE DE FIERRO GALVANIZADO DE 1 1/2" [300%] | 26.28h | 669.12 | 01.09.05 | 000000000000055 | 11.5 | 33.1 | 380.65 | 30 |
| 254 | 3.9.6 | TUBERIA PVC CLASE 10 - 1/2" ROSCADA | 1d? | 2022-06-10 | 2022-06-11 |  | 6d |  | start no earlier than 2021-12-22 | PEON [8.3%]; OPERARIO [8.3%]; CINTA TEFLON [37.5%]; TUBERIA PVC CLASE 10 SP 1/2" X 5M [257.5%]; UNION SIMPLE PVC SAP CLASE 10 SP 1/2" | 5.3h | 93.05 | 01.09.06 | 000000000000056 | 2.5 | 13.46 | 33.65 | 30 |
| 255 | 3.9.7 | VALVULA CHECK 2" | 1d? | 2022-06-10 | 2022-06-11 |  | 6d |  | start no earlier than 2021-12-22 | PEON [37.5%]; OPERARIO [37.5%]; CINTA TEFLON [750%]; CODO FIERRO GALVANIZADO 2" X 90° [900%]; UNION UNIVERSAL DE Fº Gº DE 2" [600%]; NIPLE FºGº 2" X 2 1/2" [1500%]; VALVULA CHECK DE BRONCE DE 2" [300%] | 46.5h | 1,444.59 | 01.09.07 | 000000000000057 |  | 332.03 | 996.09 |  |
| 256 | 3.9.8 | VALVULA CHECK 1 1/2" | 1d? | 2022-06-10 | 2022-06-11 |  | 6d |  | start no earlier than 2021-12-22 | PEON [25%]; OPERARIO [25%]; CINTA TEFLON [500%]; CODO FIERRO GALVANIZADO 1 1/2" X 90° [600%]; UNION UNIVERSAL DE Fº Gº DE 1 1/2" [400%]; NIPLE DE FIERRO GALVANIZADO DE 1 1/2" X 5" [800%]; NIPLE DE FIERRO GALVANIZADO DE 1 1/2" X 10" [200%]; VALVULA CHECK DE BRONCE DE 1 1/2" [200%] | 31h | 853.3 | 01.09.08 | 000000000000058 |  | 277.15 | 554.3 |  |
| 257 | 3.9.9 | VALVULA DE COMPUERTA DE BRONCE 2" | 1d? | 2022-06-10 | 2022-06-11 |  | 6d |  | start no earlier than 2021-12-22 | PEON [66.7%]; OPERARIO [66.7%]; CINTA TEFLON [800%]; UNION UNIVERSAL DE Fº Gº DE 2" [800%]; NIPLE FºGº 2" X 2 1/2" [800%]; VALVULA COMPUERTA 2" [400%] | 38.67h | 1,475.49 | 01.09.09 | 000000000000059 |  | 257.54 | 1030.16 |  |
| 258 | 3.9.10 | VALVULA DE COMPUERTA DE BRONCE 1 1/2" | 1d? | 2022-06-10 | 2022-06-11 |  | 6d |  | start no earlier than 2021-12-22 | PEON [37.5%]; OPERARIO [37.5%]; CINTA TEFLON [750%]; UNION UNIVERSAL DE Fº Gº DE 1 1/2" [600%]; NIPLE DE FIERRO GALVANIZADO DE 1 1/2" X 3" [600%]; VALVULA COMPUERTA 1 1/2" [300%] | 28.5h | 779.97 | 01.09.10 | 000000000000060 |  | 158.49 | 475.47 |  |
| 259 | 3.9.11 | VALVULA DE COMPUERTA DE BRONCE 1/2" | 1d? | 2022-06-10 | 2022-06-11 |  | 6d |  | start no earlier than 2021-12-22 | PEON [12.5%]; OPERARIO [12.5%]; CINTA TEFLON [250%]; CODO FIERRO GALVANIZADO 1/2" X 90° [300%]; TEE DE FIERRO GALVANIZADO DE 1/2"; UNION UNIVERSAL DE Fº Gº DE 1/2" [200%]; NIPLE DE FIERRO GALVANIZADO DE 1/2" X 5" [400%]; NIPLE DE FIERRO GALVANIZADO DE 1/2" X 10"; VALVULA COMPUERTA 1/2" | 16.5h | 253.65 | 01.09.11 | 000000000000061 |  | 96.15 | 96.15 |  |
| 260 | 3.9.12 | VALVULA FLOTADORA 1 1/2" | 1d? | 2022-06-10 | 2022-06-11 |  | 6d |  | start no earlier than 2021-12-22 | PEON; OPERARIO; CINTA TEFLON [250%]; CODO FIERRO GALVANIZADO 1 1/2" X 90° [300%]; VALVULA FLOTADORA 1 1/2"; UNION UNIVERSAL DE Fº Gº DE 1 1/2" [200%]; NIPLE DE FIERRO GALVANIZADO DE 1 1/2" X 5" [400%]; NIPLE DE FIERRO GALVANIZADO DE 1 1/2" X 10" | 29.5h | 1,026.81 | 01.09.12 | 000000000000062 |  | 586.81 | 586.81 |  |
| 261 | 3.9.13 | VALVULA FLOTADORA 3/4" | 1d? | 2022-06-10 | 2022-06-11 |  | 6d |  | start no earlier than 2021-12-22 | PEON; OPERARIO; CINTA TEFLON [250%]; CODO FIERRO GALVANIZADO 3/4" X 90° [300%]; VALVULA FLOTADORA DE 3/4"; UNION UNIVERSAL DE Fº Gº DE 3/4" [200%]; NIPLE DE FIERRO GALVANIZADO DE 3/4" X 5" [400%]; NIPLE DE FIERRO GALVANIZADO DE 3/4" X 10" | 29.5h | 888.23 | 01.09.13 | 000000000000063 |  | 448.23 | 448.23 |  |
| 262 | 3.9.14 | CAJA BAYPAS DE CONCRETO | 1d? | 2022-06-10 | 2022-06-11 |  | 6d |  | start no earlier than 2021-12-22 | CEMENTO PORTLAND TIPO MS (42.5 kg) [3 bls]; PEON [33.3%]; OPERARIO [33.3%]; ARENA FINA [25%]; PIEDRA CHANCADA DE 1/2" a 3/4" [0.15 m3]; ARENA GRUESA [0.18 m3] | 5.58h | 479.79 | 01.09.14 | 000000000000064 |  | 218.7 | 218.7 |  |
| 263 | 3.9.15 | CAJA DE REBOSE CON REJILLA METALICA | 1d? | 2022-06-10 | 2022-06-11 |  | 6d |  | start no earlier than 2021-12-22 | CEMENTO PORTLAND TIPO MS (42.5 kg) [3 bls]; PEON [33.3%]; OPERARIO [33.3%]; PIEDRA CHANCADA DE 1/2" a 3/4" [0.26 m3]; ARENA GRUESA [0.35 m3]; REJILLA Y MARCO DE FIERRO 1" | 6.33h | 501 | 01.09.15 | 000000000000065 |  | 233.91 | 233.91 |  |
| 264 | 3.9.16 | SUMINISTRO E INSTALACION DE EQUIPO DE BOMBEO, 01 ELECTROBOMBA 1.5 HP. | 1d? | 2022-06-10 | 2022-06-11 |  | 6d |  | start no earlier than 2021-12-22 | OPERARIO; CONDUCTOR NH-80 1X2.5mm2 [3000%]; CONDUCTOR NH-80 1X4mm2 [1800%]; TUBO PVC - P ( ELECT. ) 20mm [1500%]; ELECTROBOMBA 1.5 HP ALTA PRESION 2"X11/2"; CAJA GALVANIZADA RECT. PESADA 4"X2"X2 1/4" [400%]; TABLERO ALTERNADOR DE BOMBAS 1.9 HP TRIFASICO; CONTROL AUTOMATICO PARA CISTERNA | 78h | 2,293.41 | 01.09.16 | 000000000000079 |  | 1539.65 | 1539.65 |  |
| 265 | 3.9.17 | TAPA DE FIERRO EN CISTERNA | 1d? | 2022-06-10 | 2022-06-11 |  | 6d |  | start no earlier than 2021-12-22 | OPERARIO [25%]; ANGULO DE FIERRO 1" X1" X 3/16" [640%]; PLATINA DE FIERRO 3/16" X 1" X 6m [320%]; PLANCHA ESTRIADA 4'X8'X1/16" [64%]; TAPA DE FIERRO | 13.23h | 415.03 | 01.09.17 | 000000000000067 |  | 276.72 | 276.72 |  |
| 266 | 3.9.18 | REBOSE DE TANQUE ALTO FIERRO GALVAN. 2" | 1d? | 2022-06-10 | 2022-06-11 |  | 6d |  | start no earlier than 2021-12-22 | OPERARIO [25%]; SOLDADORA A GASOLINA [12.5%]; ELECTRODO TIPO 6011 - CELLOCORD [5%]; TUBERIA FºGº 2"X3.3mm [10%]; PLANCHA GALVANIZADA DE FIERRO 1/8" [7%]; CODO FIERRO GALVANIZADO 2" X 90° [300%]; CODO FIERRO GALVANIZADO 2 1/2" X 90° [300%]; REDUCCION PVC SAP 4 A 2"; SOMBRERO DE VENTILACION PVC SAL 2"; REJILLA DE BRONCE DIAMETRO 2" ROSCADO | 12.22h | 294.22 | 01.09.18 | 000000000000068 |  | 164.05 | 164.05 |  |
| 267 | 3.9.19 | REBOSE DE CISTERNA DE FIERRO GALVANIZADA 4" | 1d? | 2022-06-10 | 2022-06-11 |  | 6d |  | start no earlier than 2021-12-22 | OPERARIO [25%]; SOLDADORA A GASOLINA [25%]; ELECTRODO TIPO 6011 - CELLOCORD [50%]; TUBERIA FºGº 4"X3.3mm [10%]; PLANCHA GALVANIZADA DE FIERRO 1/8" [7%]; CODO FIERRO GALVANIZADO 4" X 90°; SOMBRERO DE VENTILACION PVC SAL 4"; REJILLA DE BRONCE DIAMETRO 2" ROSCADO | 7.67h | 290.47 | 01.09.19 | 000000000000069 |  | 196.7 | 196.7 |  |
| 268 | 3.9.20 | ABRAZADERA DE FIJACION DE TUBO | 2d? | 2022-06-10 | 2022-06-13 |  | 5d |  | start no earlier than 2021-12-22 | OFICIAL [66.7%]; PEON [33.3%]; OPERARIO [66.7%]; ALAMBRE NEGRO # 8 [1.7 kg]; CLAVOS CON CABEZA DE 2 1/2" 3" 4" [1.66 kg]; PLATINA DE FIERRO 3/16" X 1" X 6m [320%]; MADERA TORNILLO [25.6 p2]; TORNILLO DE FIJACION 1" [4000%] | 69.87h | 1,656.11 | 01.09.20 | 000000000000070 | 20 | 37.07 | 741.4 | 15 |
| 269 | 3.9.21 | ROMPE AGUA | 1d? | 2022-06-10 | 2022-06-11 |  | 6d |  | start no earlier than 2021-12-22 | OPERARIO [52%]; ELECTRODO TIPO 6011 - CELLOCORD [20%]; TUBERIA FºGº 2"X3.3mm [120%]; PLANCHA DE ACERO LAC 1/8" (3.3mm) [9.7%] | 5.67h | 262.88 | 01.09.21 | 000000000000071 |  | 37.49 | 149.96 | 10 |

| ID | WBS | Task | Duration | Start | Finish | Predecessors | Total slack | Free slack | Constraint | Resources | Work | Cost | Text1 | Text8 | Text2 | Text3 | Text4 | Text6 |
| --- | --- | --- | --- | --- | --- | --- | --- | --- | --- | --- | --- | --- | --- | --- | --- | --- | --- | --- |
| 270 | 3.10 | **SISTEMA DE DRENAJE PLUVIAL** | 4d? | 2022-06-13 | 2022-06-19 | 248 | 5d | 0d |  |  | 260.92h | 8,365.19 | 01.10 | 000000000000072 |  |  |  |  |
| 271 | 3.10.1 | TUBERIA DE BAJADA Y RED PVC SAP 110 mm | 4d? | 2022-06-13 | 2022-06-19 |  | 5d |  | start no earlier than 2021-12-22 | PEGAMENTO PARA TUBERIA PVC [1.5%]; PEON [182%]; OPERARIO [91%]; TUBO PVC SAP - 110 mm CLASE 7.5(5m) [7644%]; ABRAZADERA DE FIERRO GALVANIZADO CON DOS OREJAS 4" (INC. TARUGOS) [7280%]; CODO PVC SAP - CLASE 10 SP - 110 mm X 90 [1067.3%] | 247.27h | 7,620.89 | 01.10.01 | 000000000000073 | 72.8 | 63.6 | 4630.08 | 20 |
| 272 | 3.10.2 | SUMINISTRO E INSTALACION TUBERIA PVC 200mm ISO 4435 S-20 | 1d? | 2022-06-13 | 2022-06-15 |  | 8d |  | start no earlier than 2021-12-22 | LUBRICANTE PARA TUBO PVC [5.2%]; OFICIAL [3.3%]; PEON [1.7%]; OPERARIO [1.7%]; TUBERIA PVC UF 200mm ISO 4435 S-20 [103%]; ANILLO JEBE NARANJA PARA TUBO 200mm [34.1%] | 1.95h | 86.96 | 01.10.02 | 000000000000074 |  | 65 | 65 | 60 |
| 273 | 3.10.3 | CAJA DE REGISTRO PREFABRICADA DE 18" X 24" CON TAPA DE CONCRETO | 1d? | 2022-06-13 | 2022-06-15 |  | 8d |  | start no earlier than 2021-12-22 | CEMENTO PORTLAND TIPO MS (42.5 kg) [0.75 bls]; PEON [66.7%]; OPERARIO [66.7%]; ARENA FINA [3%]; CAJA PREFABRICADA DE CONCRETO C/TAPA 18" X 24" | 11.7h | 657.34 | 01.10.03 | 000000000000075 |  | 402.32 | 402.32 | 1.5 |
| 274 | 3.11 | **RECONEXION A LAS REDES EXISTENTES** | 1d? | 2022-06-20 | 2022-06-21 | 270 | 5d |  |  |  | 51h | 1,269.53 | 01.11 | 000000000000076 |  |  |  |  |
| 275 | 3.11.1 | EMPALME A RED EXISTENTE, DESAGÜE | 1d? | 2022-06-20 | 2022-06-21 |  | 5d |  | start no earlier than 2021-12-22 | PEGAMENTO PARA TUBERIA PVC [0.1%]; OFICIAL [50%]; PEON [50%]; TUBO PVC SAL -4" (3m) [400%]; CACHIMBA PVC 200mmX160MMx45 y accesorios | 13h | 387.68 | 01.11.01 | 000000000000077 |  | 202.08 | 202.08 |  |
| 276 | 3.11.2 | EMPALME A RED EXISTENTE, AGUA | 1d? | 2022-06-20 | 2022-06-21 |  | 5d |  | start no earlier than 2021-12-22 | PEON; OPERARIO; CINTA TEFLON [2000%]; TUBERIA PVC CLASE 10 ROSCADO 1" X 5M; UNION UNIVERSAL DE Fº Gº DE 3/4" | 38h | 881.85 | 01.11.02 | 000000000000078 |  | 373.85 | 373.85 |  |
| 277 | 4 | **INSTALACIONES ELECTRICAS** | 23d? | 2022-05-11 | 2022-06-16 |  | 8d |  |  |  | 8180.57h | 188,575.69 | 01 | 000000000000001 |  |  |  |  |
| 278 | 4.1 | **MOVIMIENTO DE TIERRAS** | 10d? | 2022-05-11 | 2022-05-26 | 200SS | 15d | 0d |  |  | 184.55h | 9,033.59 | 01.01 | 000000000000002 |  |  |  |  |
| 279 | 4.1.1 | EXCAVACION MANUAL DE ZANJAS PARA CABLE ELECTRICO DE 100 x 100 cm | 10d | 2022-05-11 | 2022-05-26 |  | 15d |  | start no earlier than 2021-12-22 | PEON [97.5%] | 77.98h | 4,678.16 | 01.01.01 | 000000000000003 | 140.36 | 23.73 | 3330.74 |  |
| 280 | 4.1.2 | REFINE, NIVELACION DE ZANJAS INCLUYE CAMA DE 100 CM | 2d? | 2022-05-11 | 2022-05-14 |  | 23d |  | start no earlier than 2021-12-22 | PEON [87.7%]; OPERARIO [8.8%]; ARENA GRUESA [10.11 m3] | 15.43h | 983.92 | 01.01.02 | 000000000000004 | 140.36 | 4.77 | 669.52 | 80 |
| 281 | 4.1.3 | RELLENO Y COMPACTACION MANUAL DE ZANJAS C/ MATERIAL PROPIO CON EQUIPO 100 x 100 cm | 10d | 2022-05-11 | 2022-05-26 |  | 15d |  | start no earlier than 2021-12-22 | PEON [91.1%]; PLANCHA COMPACTADORA VIBRAT. 4.0 H.P. [22.8%]; AGUA [21.05 m3] | 91.14h | 3,371.51 | 01.01.03 | 000000000000005 | 140.36 | 13.06 | 1833.1 | 14 |
| 282 | 4.2 | **CONDUCTORES, DUCTOS Y ACCESORIOS** | 6d? | 2022-05-27 | 2022-06-05 | 278 | 15d | 0d |  |  | 6469.35h | 81,607.65 | 01.02 | 000000000000006 |  |  |  |  |
| 283 | 4.2.1 | CONDUCTOR DE Cu DE 1-1x10mm2 N2XOH BLANCO | 1d? | 2022-05-27 | 2022-05-28 |  | 20d |  | start no earlier than 2021-12-22 | OFICIAL [6.2%]; PEON [3.1%]; OPERARIO [6.2%]; CONDUCTOR DE Cu DE 1-1x10mm2 N2XOH BLANCO [1050%] | 11.75h | 175.29 | 01.02.01 | 000000000000007 | 10 | 6.53 | 65.3 | 160 |
| 284 | 4.2.2 | CONDUCTOR DE Cu DE 2.5 mm2 NH-80 VERDE | 6d? | 2022-05-27 | 2022-06-05 |  | 15d |  | start no earlier than 2021-12-22 | OFICIAL [95.6%]; PEON [47.8%]; OPERARIO [95.6%]; CONDUCTOR DE Cu DE 2.5 mm2 NH-80 VERDE [96396.3%] | 1078.72h | 13,503.62 | 01.02.02 | 000000000000008 | 918.06 | 3.71 | 3406 | 160 |
| 285 | 4.2.3 | CONDUCTOR DE Cu DE 2.5 mm2 NH-80 BLANCO | 6d? | 2022-05-27 | 2022-06-05 |  | 15d |  | start no earlier than 2021-12-22 | OFICIAL [95.6%]; PEON [47.8%]; OPERARIO [95.6%]; CONDUCTOR DE Cu DE 2.5 mm2 NH-80 BLANCO [96396.3%] | 1078.72h | 13,503.62 | 01.02.03 | 000000000000009 | 918.06 | 3.71 | 3406 | 160 |
| 286 | 4.2.4 | CONDUCTOR DE Cu DE 2.5 mm2 NH-80 NEGRO | 6d? | 2022-05-27 | 2022-06-05 |  | 15d |  | start no earlier than 2021-12-22 | OFICIAL [95.6%]; PEON [47.8%]; OPERARIO [95.6%]; CONDUCTOR DE Cu DE 2.5 mm2 NH-80 NEGRO [96396.3%] | 1078.72h | 13,503.62 | 01.02.04 | 000000000000010 | 918.06 | 3.71 | 3406 | 160 |
| 287 | 4.2.5 | CONDUCTOR DE Cu DE 4 mm2 NH-80 BLANCO | 2d? | 2022-05-27 | 2022-05-30 |  | 19d |  | start no earlier than 2021-12-22 | OFICIAL [67.1%]; PEON [33.5%]; OPERARIO [67.1%]; CONDUCTOR DE Cu DE 4 mm2 NH-80 BLANCO [22539.3%] | 252.23h | 3,297.02 | 01.02.05 | 000000000000011 | 214.66 | 4.36 | 935.92 | 160 |
| 288 | 4.2.6 | CONDUCTOR DE Cu DE 4 mm2 NH-80 NEGRO | 2d? | 2022-05-27 | 2022-05-30 |  | 19d |  | start no earlier than 2021-12-22 | OFICIAL [67.1%]; PEON [33.5%]; OPERARIO [67.1%]; CONDUCTOR DE Cu DE 4 mm2 NH-80 NEGRO [22539.3%] | 252.23h | 3,297.02 | 01.02.06 | 000000000000012 | 214.66 | 4.36 | 935.92 | 160 |
| 289 | 4.2.7 | CONDUCTOR DE Cu DE 4 mm2 NH-80 VERDE | 2d? | 2022-05-27 | 2022-05-30 |  | 19d |  | start no earlier than 2021-12-22 | OFICIAL [67.1%]; PEON [33.5%]; OPERARIO [67.1%]; CONDUCTOR DE Cu DE 4 mm2 NH-80 VERDE [22539.3%] | 252.23h | 3,297.02 | 01.02.07 | 000000000000013 | 214.66 | 4.36 | 935.92 | 160 |
| 290 | 4.2.8 | CONDUCTOR DE Cu DE 10 mm2 NH-80 VERDE | 1d? | 2022-05-27 | 2022-05-28 |  | 20d |  | start no earlier than 2021-12-22 | OFICIAL [6.2%]; PEON [3.1%]; OPERARIO [6.2%]; CONDUCTOR DE Cu DE 10 mm2 NH-80 VERDE [1050%] | 11.75h | 174.29 | 01.02.08 | 000000000000014 | 10 | 6.43 | 64.3 | 160 |
| 291 | 4.2.9 | CONDUCTOR DE Cu DESNUDO DE 25 mm2 | 1d? | 2022-05-27 | 2022-05-28 |  | 20d |  | start no earlier than 2021-12-22 | OFICIAL [27.2%]; PEON [13.6%]; OPERARIO [27.2%]; CONDUCTOR DE Cu DESNUDO DE 25 mm2 [4578%] | 51.23h | 1,161.51 | 01.02.09 | 000000000000015 | 43.6 | 15.64 | 681.9 | 160 |
| 292 | 4.2.10 | TUBERIA PVC-SAP DE 20 MM DE DIAMETRO INC. ACCESORIOS | 6d? | 2022-05-27 | 2022-06-05 |  | 15d |  | start no earlier than 2021-12-22 | PEGAMENTO PARA TUBERIA PVC [91.8%]; OFICIAL [95.6%]; PEON [47.8%]; OPERARIO [95.6%]; TUBO PVC - P ( ELECT. ) 20mm 3M [96396.3%]; CURVA PVC - P ( ELECT. ) 20mm [18645.8%]; UNION PVC - P ( ELECT. ) 20mm [41386.1%] | 1679.95h | 20,232.23 | 01.02.10 | 000000000000016 | 918.06 | 5.8 | 5324.75 | 160 |
| 293 | 4.2.11 | TUBERIA PVC-SAP DE 25 MM DE DIAMETRO INC. ACCESORIOS | 2d? | 2022-05-27 | 2022-05-30 |  | 19d |  | start no earlier than 2021-12-22 | PEGAMENTO PARA TUBERIA PVC [21.5%]; OFICIAL [67.1%]; PEON [33.5%]; OPERARIO [67.1%]; TUBO PVC - P ( ELECT. ) 25mm 3M [22539.3%]; CURVA PVC - P ( ELECT. ) 25mm [4359.7%]; UNION PVC - P ( ELECT. ) 25mm [9676.9%] | 392.82h | 4,870.33 | 01.02.11 | 000000000000017 | 214.66 | 6.45 | 1384.56 | 160 |
| 294 | 4.2.12 | TUBERIA PVC-SAP DE 35 MM DE DIAMETRO INC. ACCESORIOS | 1d? | 2022-05-27 | 2022-05-28 |  | 20d |  | start no earlier than 2021-12-22 | PEGAMENTO PARA TUBERIA PVC [1%]; OFICIAL [6.2%]; PEON [3.1%]; OPERARIO [6.2%]; TUBO PVC - P ( ELECT. ) 35mm 3M [1050%]; CURVA PVC - P ( ELECT. ) 35mm [115%]; UNION PVC - P ( ELECT. ) 35mm [260%] | 15.52h | 233.22 | 01.02.12 | 000000000000018 | 10 | 9.31 | 93.1 | 160 |
| 295 | 4.2.13 | TUBERIA PVC-SAP DE 40 MM DE DIAMETRO INC. ACCESORIOS | 1d? | 2022-05-27 | 2022-05-28 |  | 20d |  | start no earlier than 2021-12-22 | PEGAMENTO PARA TUBERIA PVC [4.4%]; OFICIAL [27.2%]; PEON [13.6%]; OPERARIO [27.2%]; TUBO PVC - P ( ELECT. ) 40mm 3M [4578%]; CURVA PVC - P ( ELECT. ) 40mm [263.3%]; UNION PVC - P ( ELECT. ) 40mm [1057.3%] | 64.48h | 995.89 | 01.02.13 | 000000000000019 | 43.6 | 9.41 | 410.28 | 160 |
| 296 | 4.2.14 | CAJA DE DERIVACION DE 200x200x150 | 1d? | 2022-05-27 | 2022-05-28 |  | 20d |  | start no earlier than 2021-12-22 | PEON [12.5%]; OPERARIO [12.5%]; CAJA DE DERIVACION GALVANIZADA 200 x 200 X 150 [500%] | 7h | 166.5 | 01.02.14 | 000000000000020 |  | 17 | 85 | 40 |
| 297 | 4.2.15 | SISTEMA DE TUBERIA CONDUIT EMT INC. ACCESORIOS | 1d? | 2022-05-27 | 2022-05-28 |  | 20d |  | start no earlier than 2021-12-22 | OFICIAL; PEON [50%]; OPERARIO; TUBO CONDUIT DE 20mm [9600%]; TUBO FLEXIBLE CONDUIT C/FORRO DE PVC 20mm [700%]; CURVA CONDUIT EMT 20mm [1200%]; CONECTOR CONDUIT EMT 20mm [3200%]; CONECTOR HERMETICO EMT 20mm [800%]; TERMINAL EMT 20mm [4800%]; CAJA RECTANGULAR DE ALUMINIO DE 4 AGUJEROS DE 20mm [600%]; CAJA REDONDA DE 4 AGUJEROS DE 20mm [1300%] | 242h | 3,196.47 | 01.02.15 | 000000000000021 |  | 1004.63 | 1004.63 |  |

| ID | WBS | Task | Duration | Start | Finish | Predecessors | Total slack | Free slack | Constraint | Resources | Work | Cost | Text1 | Text8 | Text3 | Text4 | Text6 | Text2 |
| --- | --- | --- | --- | --- | --- | --- | --- | --- | --- | --- | --- | --- | --- | --- | --- | --- | --- | --- |
| 298 | 4.3 | **ARTEFACTOS DE ILUMINACION - LUMINARIAS / TOMACORRIENTES** | 6d? | 2022-05-27 | 2022-06-05 | 282SS | 15d | 0d |  |  | 963.6h | 64,076.69 | 01.03 | 000000000000022 |  |  |  |  |
| 299 | 4.3.1 | LUMINARIA SHREDER ISLA LD 51W5096 O EQUIVALENTE P/POSTE 60MM | 1d? | 2022-05-27 | 2022-05-28 |  | 20d |  | start no earlier than 2021-12-22 | OFICIAL [60%]; OPERARIO [60%]; CINTA AISLANTE [300%]; LUMINARIA SHREDER ISLA LD 51W5096 O EQUIVALENTE P/POSTE 60MM [600%] | 18.6h | 2,571.43 | 01.03.01 | 000000000000023 | 381.9 | 2291.4 | 10 |  |
| 300 | 4.3.2 | SmartLED Office W60L60 - PHILLIPS (LUMINARIA ADOSADA) 4 LAMPARAS | 4d? | 2022-05-27 | 2022-06-02 |  | 17d |  | start no earlier than 2021-12-22 | OFICIAL [87.5%]; OPERARIO [87.5%]; CINTA AISLANTE [1750%]; SmartLED Office W60L60 - PHILLIPS (LUMINARIA ADOSADA) 4 LAMPARAS [3500%] | 108.5h | 11,604.32 | 01.03.02 | 000000000000024 | 284.88 | 9970.8 | 10 | 35 |
| 301 | 4.3.3 | SmartLED Office W30L120 - PHILLIPS (LUMINARIA ADOSADA) 2 LAMPARAS | 6d? | 2022-05-27 | 2022-06-05 |  | 15d |  | start no earlier than 2021-12-22 | OFICIAL [93.3%]; OPERARIO [93.3%]; CINTA AISLANTE [2800%]; SmartLED Office W30L120 - PHILLIPS (LUMINARIA ADOSADA) 2 LAMPARAS [5600%] | 173.6h | 17,992.35 | 01.03.03 | 000000000000025 | 274.62 | 15378.72 | 10 | 56 |
| 302 | 4.3.4 | INDIKO FORYIMO LED - PHILLIPS (LUMINARIA HERMÉTICA) 2 LAMPARA | 5d? | 2022-05-27 | 2022-06-03 |  | 16d |  | start no earlier than 2021-12-22 | OFICIAL; OPERARIO; CINTA AISLANTE [2500%]; INDIKO FORYIMO LED - PHILLIPS (LUMINARIA HERMÉTICA) 2 LAMPARA [5000%] | 155h | 14,767.6 | 01.03.04 | 000000000000026 | 248.68 | 12434 | 10 | 50 |
| 303 | 4.3.5 | BERYL ADOSADA LED 15W | 1d? | 2022-05-27 | 2022-05-28 |  | 20d |  | start no earlier than 2021-12-22 | OFICIAL [20%]; OPERARIO [20%]; CINTA AISLANTE; BERYL ADOSADA LED 15W [200%] | 6.2h | 479.36 | 01.03.05 | 000000000000027 | 193.01 | 386.02 | 10 |  |
| 304 | 4.3.6 | LAMPARA DE EMERGENCIA DE 24 LEDS | 1d? | 2022-05-27 | 2022-05-28 |  | 20d |  | start no earlier than 2021-12-22 | OFICIAL [50%]; OPERARIO [50%]; LAMPARA DE EMERGENCIA 24 LEDS [500%]; CINTA AISLANTE [250%] | 15.5h | 786.36 | 01.03.06 | 000000000000028 | 110.6 | 553 | 10 |  |
| 305 | 4.3.7 | Reflector Josfel Hall Ligth Led 250W asimétrico o EQUIVALENTE | 2d? | 2022-05-27 | 2022-05-30 |  | 19d |  | start no earlier than 2021-12-22 | OFICIAL [75%]; OPERARIO [75%]; CINTA AISLANTE [300%]; Reflector Josfel Hall Ligth Led 250W asimétrico o EQUIVALENTE [600%] | 33h | 5,071.5 | 01.03.07 | 000000000000029 | 746.57 | 4479.42 |  |  |
| 306 | 4.3.8 | CAJA OCTOGONAL F°G° DE 100mm x 55mm | 4d? | 2022-05-27 | 2022-06-02 |  | 17d |  | start no earlier than 2021-12-22 | OFICIAL [88.1%]; OPERARIO [88.1%]; CAJA OCTOGONAL F°G° DE 100mm x 55mm [14100%] | 197.4h | 4,470.83 | 01.03.08 | 000000000000030 | 15.04 | 2120.64 | 40 | 141 |
| 307 | 4.3.9 | INTERRUPTOR SIMPLE UNIPOLAR | 1d? | 2022-05-27 | 2022-05-28 |  | 20d |  | start no earlier than 2021-12-22 | OFICIAL [42.5%]; OPERARIO [42.5%]; INTERRUPTOR SIMPLE UNIPOLAR [1700%] | 23.8h | 536.83 | 01.03.09 | 000000000000031 | 14.91 | 253.47 | 40 | 17 |
| 308 | 4.3.10 | INTERRUPTOR DOBLE UNIPOLAR | 1d? | 2022-05-27 | 2022-05-28 |  | 20d |  | start no earlier than 2021-12-22 | OFICIAL [77.5%]; OPERARIO [77.5%]; INTERRUPTOR DOBLE UNIPOLAR [3100%] | 43.4h | 1,131.75 | 01.03.10 | 000000000000032 | 19.84 | 615.04 | 40 | 31 |
| 309 | 4.3.11 | INTERRUPTOR TRIPLE UNIPOLAR | 1d? | 2022-05-27 | 2022-05-28 |  | 20d |  | start no earlier than 2021-12-22 | OFICIAL [15%]; OPERARIO [15%]; INTERRUPTOR TRIPLE UNIPOLAR [600%] | 8.4h | 247.55 | 01.03.11 | 000000000000033 | 24.59 | 147.54 | 40 |  |
| 310 | 4.3.12 | INTERRUPTOR DE CONMUTACION SIMPLE | 1d? | 2022-05-27 | 2022-05-28 |  | 20d |  | start no earlier than 2021-12-22 | OFICIAL [5%]; OPERARIO [5%]; INTERRUPTOR DE CONMUTACION SIMPLE [200%] | 2.8h | 64.74 | 01.03.12 | 000000000000034 | 15.7 | 31.4 | 40 |  |
| 311 | 4.3.13 | TOMACORRIENTE DOBLE C/T | 2d? | 2022-05-27 | 2022-05-30 |  | 19d |  | start no earlier than 2021-12-22 | OFICIAL [78.8%]; OPERARIO [78.8%]; TOMACORRIENTE DOBLE C/T [6300%] | 88.2h | 2,359.22 | 01.03.13 | 000000000000035 | 20.78 | 1309.14 | 40 | 63 |
| 312 | 4.3.14 | CAJA RECTANGULAR F°G° DE 100 x 55 x 50mm | 2d? | 2022-05-27 | 2022-05-30 |  | 19d |  | start no earlier than 2021-12-22 | OFICIAL [78.8%]; OPERARIO [78.8%]; CAJA RECTANGULAR F°G° DE 100 x 55 x 50mm [6300%] | 88.2h | 1,916.96 | 01.03.14 | 000000000000036 | 13.76 | 866.88 | 40 | 63 |
| 313 | 4.3.15 | TIMBRE (CHICHARRA) + PULSADOR | 1d? | 2022-05-27 | 2022-05-28 |  | 20d |  | start no earlier than 2021-12-22 | SUMINISTRO E INSTALACION DE TIMBRE (CHICHARRA) + PULSADOR | 1h | 75.89 | 01.03.15 | 000000000000037 | 67.89 | 67.89 |  |  |
| 314 | 4.4 | **TABLERO ELECTRICO TRIFASICO/ MONOFASICO** | 1d? | 2022-05-27 | 2022-05-28 | 298SS | 20d | 0d |  |  | 36.33h | 2,893.23 | 01.04 | 000000000000038 |  |  |  |  |
| 315 | 4.4.1 | TABLERO ELECTRICO DE F°G° EMPOTRADO 8 POLOS | 1d? | 2022-05-27 | 2022-05-28 |  | 20d |  | start no earlier than 2021-12-22 | OFICIAL [125%]; OPERARIO [125%]; TABLERO ELECTRICO DE F°G° EMPOTRADO 8 POLOS [500%] | 25h | 1,850.15 | 01.04.01 | 000000000000039 | 275.35 | 1376.75 |  |  |
| 316 | 4.4.2 | TABLERO ELECTRICO DE F°G° EMPOTRADO 18 POLOS | 1d? | 2022-05-27 | 2022-05-28 |  | 20d |  | start no earlier than 2021-12-22 | OFICIAL [25%]; OPERARIO [25%]; TABLERO ELECTRICO DE F°G° EMPOTRADO 18 POLOS | 5h | 440.03 | 01.04.02 | 000000000000040 | 345.35 | 345.35 |  |  |
| 317 | 4.4.3 | TABLERO ELECTRICO DE F°G° EMPOTRADO 32 POLOS | 1d? | 2022-05-27 | 2022-05-28 |  | 20d |  | start no earlier than 2021-12-22 | OFICIAL [33.3%]; OPERARIO [33.3%]; TABLERO ELECTRICO DE F°G° EMPOTRADO 32 POLOS | 6.33h | 603.05 | 01.04.03 | 000000000000041 | 479.48 | 479.48 |  |  |
| 318 | 4.5 | **INTERRUPTORES TERMOMAGNETICOS MONOFASICOS** | 2d? | 2022-05-27 | 2022-05-30 | 314SS | 19d | 0d |  |  | 43.75h | 1,978.5 | 01.05 | 000000000000042 |  |  |  |  |
| 319 | 4.5.1 | INTERRUPTOR THERMOMAGNETICO MONOFASICO 2X20 A | 2d? | 2022-05-27 | 2022-05-30 |  | 19d |  | start no earlier than 2021-12-22 | OPERARIO [75%]; PEON [37.5%]; INTERRUPTOR THERMOMAGNETICO 2X20 A [2400%] | 42h | 1,892.64 | 01.05.01 | 000000000000043 | 54.43 | 1306.32 | 16 | 24 |
| 320 | 4.5.2 | INTERRUPTOR THERMOMAGNETICO 2X35 A | 1d? | 2022-05-27 | 2022-05-28 |  | 20d |  | start no earlier than 2021-12-22 | OPERARIO [6.2%]; PEON [3.1%]; INTERRUPTOR THERMOMAGNETICO 2X35A | 1.75h | 85.86 | 01.05.02 | 000000000000044 | 61.43 | 61.43 | 16 |  |
| 321 | 4.6 | **INTERRUPTORES DIFERENCIALES** | 1d? | 2022-05-27 | 2022-05-28 | 318SS | 20d | 0d |  |  | 13.1h | 983.22 | 01.06 | 000000000000045 |  |  |  |  |
| 322 | 4.6.1 | INTERRUPTOR DIFERENCIAL 2x20 A/30mm A | 1d? | 2022-05-27 | 2022-05-28 |  | 20d |  | start no earlier than 2021-12-22 | OFICIAL [28%]; OPERARIO [28%]; INTERRUPTOR DIFERENCIAL 2 X 20A - 30mA [700%] | 11.47h | 851.74 | 01.06.01 | 000000000000046 | 99.85 | 698.95 | 25 |  |
| 323 | 4.6.2 | INTERRUPTOR DIFERENCIAL 2x25 A/30mm A | 1d? | 2022-05-27 | 2022-05-28 |  | 20d |  | start no earlier than 2021-12-22 | OFICIAL [4%]; OPERARIO [4%]; INTERRUPTOR DIFERENCIAL 2x25 A/30mm A | 1.63h | 131.47 | 01.06.02 | 000000000000047 | 109.75 | 109.75 | 25 |  |

| ID | WBS | Task | Duration | Start | Finish | Predecessors | Total slack | Free slack | Constraint | Resources | Work | Cost | Text1 | Text8 | Text3 | Text4 | Text6 | Text2 |
| --- | --- | --- | --- | --- | --- | --- | --- | --- | --- | --- | --- | --- | --- | --- | --- | --- | --- | --- |
| 324 | 4.7 | **CIRCUITOS DE MANDO DE ILUMINACION DE PATIOS** | 1d? | 2022-05-27 | 2022-05-28 | 321SS | 18d | 0d |  |  | 3.87h | 249.46 | 01.07 | 000000000000048 |  |  |  |  |
| 325 | 4.7.1 | PULSADOR LUMINOSO NA 220V IP66 | 1d? | 2022-05-27 | 2022-05-28 |  | 18d |  | start no earlier than 2021-12-22 | OFICIAL [6.7%]; OPERARIO [6.7%]; PULSADOR LUMINOSO NA 220V IP66 | 2.07h | 160.59 | 01.07.01 | 000000000000049 | 129.48 | 129.48 | 15 |  |
| 326 | 4.7.2 | CONTACTOR TRIFASICO 25A | 1d? | 2022-05-27 | 2022-05-28 |  | 18d |  | start no earlier than 2021-12-22 | OFICIAL [5%]; OPERARIO [5%]; CONTACTOR TRIFASICO 25A | 1.8h | 88.87 | 01.07.02 | 000000000000050 | 63.53 | 63.53 | 20 |  |
| 327 | 4.8 | **POSTES DE F°G°** | 2d? | 2022-05-28 | 2022-05-31 | 324 | 18d | 0d |  |  | 44.6h | 6,894.93 | 01.08 | 000000000000051 |  |  |  |  |
| 328 | 4.8.1 | POSTE DE F°G° DE 4m | 2d? | 2022-05-28 | 2022-05-31 |  | 18d |  | start no earlier than 2021-12-22 | SUMINISTRO E INSTALACION DE POSTE DE F°G° DE 4m [600%] | 6h | 5,186.7 | 01.08.01 | 000000000000052 | 856.45 | 5138.7 |  |  |
| 329 | 4.8.2 | DADOS DE CONCRETO DE POSTES/ICLUYE ACABADO | 2d? | 2022-05-28 | 2022-05-31 |  | 18d |  | start no earlier than 2021-12-22 | CEMENTO BLANCO BOLSA 50 kg [78%]; MARMOLINA [150%]; GRANALLA [432%]; OFICIAL; OPERARIO; PIEDRA CHANCADA DE 1/2" a 3/4" [0.27 m3]; ARENA GRUESA [0.25 m3] | 38.6h | 1,708.23 | 01.08.02 | 000000000000053 | 139.83 | 838.98 |  |  |
| 330 | 4.9 | **PUESTA A TIERRA DE TABLERO GENERAL** | 12d? | 2022-05-28 | 2022-06-16 | 327SS | 8d | 0d |  |  | 182.4h | 6,179.44 | 01.09 | 000000000000054 |  |  |  |  |
| 331 | 4.9.1 | POZO CONEXION A TIERRA | 12d? | 2022-05-28 | 2022-06-16 |  | 8d |  | start no earlier than 2021-12-22 | CEMENTO PORTLAND TIPO MS (42.5 kg) [3 bls]; PEON; CABLE TW # 2 AWG - 35 mm2 [3000%]; TUBERIA PVC SAP PARA INSTALACIONES ELECTRICAS DE 1" [3000%]; TIERRA DE CHACRA O VEGETAL [840%]; PIEDRA CHANCADA DE 1/2" a 3/4" [0.36 m3]; ARENA GRUESA [0.18 m3]; VARILLA DE COBRE DE 1/2" X 2.40 m [600%]; MARCO Y TAPA FIERRO GALVANIZADO PARA MEDIDOR 1/2" - 3/4" [600%]; CURVA PVC SAP PESADO PARA INSTALACIONES ELECTRICAS DE 1" [600%] | 182.4h | 6,179.44 | 01.09.01 | 000000000000055 | 613.49 | 3680.94 | 0.5 |  |
| 332 | 4.10 | **BUZON ELECTRICO** | 3d? | 2022-05-28 | 2022-06-02 | 330SS | 16d | 0d |  |  | 54h | 2,609.52 | 01.10 | 000000000000056 |  |  |  |  |
| 333 | 4.10.1 | BUZON DEL SISTEMA ELECTRICO 1.00x1.00x0.8 | 3d? | 2022-05-28 | 2022-06-02 |  | 16d |  | start no earlier than 2021-12-22 | OFICIAL; OPERARIO; BUZON PARA PARA SISTEMA ELECTRICO [600%] | 54h | 2,609.52 | 01.10.01 | 000000000000057 | 253.56 | 1521.36 |  |  |
| 334 | 4.11 | **ELECTROBOMBA** | 1d? | 2022-06-02 | 2022-06-03 | 332 | 16d |  |  |  | 8h | 492.68 | 01.11 | 000000000000058 |  |  |  |  |
| 335 | 4.11.1 | TABLERO DE ELECTROBOMBAS | 1d? | 2022-06-02 | 2022-06-03 |  | 16d |  | start no earlier than 2021-12-22 | OFICIAL [12.5%]; OPERARIO [12.5%]; TABLERO DE CONTROL DE ELECTROBOMBA; ALTERNOR DE ELECTROBOMBA; INTERRUPTOR DE CONTROL DE NIVEL DE AGUA [200%]; CONTROLES DE ARRANQUE Y PARADA [200%] | 8h | 492.68 | 01.11.01 | 000000000000059 | 401.34 | 401.34 |  |  |
| 336 | 4.12 | **TRANSPORTE DE MATERIALES** | 1d? | 2022-05-11 | 2022-05-12 | 278SS | 30d |  |  |  | 1h | 6,353.56 | 01.12 | 000000000000060 |  |  |  |  |
| 337 | 4.12.1 | TRANSPORTE DE MATERIALES (3% DE MATERIALES) | 1d? | 2022-05-11 | 2022-05-12 |  | 30d |  | start no earlier than 2021-12-22 | TRANSPORTE DE MATERIALES ELECTRICOS (3% DE MATERIALES) | 1h | 6,353.56 | 01.12.01 | 000000000000061 | 6345.56 | 6345.56 | 25 |  |
| 338 | 4.13 | **COMUNICACIONES** | 2d? | 2022-05-11 | 2022-05-14 | 278SS | 29d |  |  |  | 108.02h | 2,155.85 | 01.13 | 000000000000062 |  |  |  |  |
| 339 | 4.13.1 | TUBERIA PVC-SAP DE 25 MM DE DIAMETRO INC. ACCESORIOS | 1d? | 2022-05-11 | 2022-05-12 |  | 30d |  | start no earlier than 2021-12-22 | PEGAMENTO PARA TUBERIA PVC [4.2%]; OFICIAL [26.2%]; PEON [13.1%]; OPERARIO [26.2%]; TUBO PVC - P ( ELECT. ) 25mm 3M [4410%]; CURVA PVC - P ( ELECT. ) 25mm [554.8%]; UNION PVC - P ( ELECT. ) 25mm [1407%] | 69.02h | 878.85 | 01.13.01 | 000000000000063 | 6.18 | 259.56 | 160 | 42 |
| 340 | 4.13.2 | CAJA DE DERIVACION DE 200x200x150 | 1d? | 2022-05-11 | 2022-05-12 |  | 30d |  | start no earlier than 2021-12-22 | PEON [25%]; OPERARIO [25%]; CAJA DE DERIVACION GALVANIZADA 200 x 200 X 150 [1000%] | 14h | 333 | 01.13.02 | 000000000000064 | 17 | 170 | 40 | 10 |
| 341 | 4.13.3 | CAJA RECTANGULAR F°G° DE 100 x 55 x 50mm | 2d? | 2022-05-11 | 2022-05-14 |  | 29d |  | start no earlier than 2021-12-22 | OFICIAL [62.5%]; OPERARIO [62.5%]; CAJA RECTANGULAR F°G° DE 100 x 55 x 50mm [500%] | 25h | 944 | 01.13.03 | 000000000000065 | 94.12 | 470.6 |  |  |
| 342 | 4.14 | **CONEXION Y ADECUACION A RED DE ENERGIA EXISTENTE** | 4d? | 2022-05-27 | 2022-06-02 | 282SS | 17d |  |  |  | 68h | 3,067.37 | 01.14 | 000000000000066 |  |  |  |  |
| 343 | 4.14.1 | CONEXION Y ADECUACION A RED DE ENERGIA EXISTENTE (incluye todas las gestiones necesarias) | 4d? | 2022-05-27 | 2022-06-02 |  | 17d |  | start no earlier than 2021-12-22 | OFICIAL; OPERARIO; CAJA DE CONEXION DE SUMINISTRO; CAJA PORTAMEDIDOR; MEDIDOR DE ENERGIA ELECTRICA; CAJA PORTA - INTERRUPTOR DE 30A | 68h | 3,067.37 | 01.14.01 | 000000000000067 | 1648.49 | 1648.49 | 0.25 |  |
| 344 | 5 | **PLAN DE CONTINGENCIA** | 8d? | 2022-01-01 | 2022-01-14 |  | 104d |  |  |  | 3791.57h | 144,422.1 |  |  |  |  |  |  |
| 345 | 5.1 | **AMBIENTES PREFABRICADOS** | 8d? | 2022-01-01 | 2022-01-14 | 2SS | 104d |  |  |  | 3714.57h | 120,830.46 | 01 | 000000000000001 |  |  |  |  |
| 346 | 5.1.1 | AULA PROVISIONAL EN DRYWALL(INC. VENTANAS, PUERTAS,PINTURA, VIDRIO, TECHO, CALAMINON Y ACCESORIOS) | 1d? | 2022-01-01 | 2022-01-02 |  | 111d |  | start no earlier than 2021-12-22 | AULA PROVISIONAL DRYWALL(INC. VENTANAS PUERTAS VIDRIOS TECHO CALAMINON Y ACCES.) | 1h | 14,008 | 01.01 | 000000000000002 | 14000 | 14000 |  |  |
| 347 | 5.1.2 | MONTAJE Y DESMONTAJE DE AULA PROVISIONAL EN DRYWALL (INC. VENTANAS, PUERTAS, PINTURA, VIDRIO, CALAMINON Y ACCESORIOS) | 8d? | 2022-01-01 | 2022-01-14 |  | 104d |  | start no earlier than 2021-12-22 | AULA PROVISIONAL DRYWALL(INC. VENTANAS PUERTAS VIDRIOS TECHO CALAMINON Y ACCES.) [300%] | 3h | 42,024 | 01.05 | 000000000000020 | 14000 | 42000 | 0.4 |  |
| 348 | 5.1.3 | COMEDOR PROVISIONAL EN DRYWALL(INC. VENTANAS, PUERTAS,VIDRIO, TECHO, CALAMINON Y ACCESORIOS) | 1d? | 2022-01-01 | 2022-01-02 |  | 111d |  | start no earlier than 2021-12-22 | COMEDOR PROVISIONAL EN DRYWALL(INC. PUERTAS VENTANAS VIDRIOS TECHOS CALAMINON Y ACCESORIOS) | 1h | 17,508 | 01.02 | 000000000000003 | 17500 | 17500 |  |  |
| 349 | 5.1.4 | AMBIENTE ADMINISTRATIVO EN DRYWALL(INC. VENTANAS,PUERTAS,VIDRIO,TECHO,CALAMINON Y ACCESORIOS) | 1d? | 2022-01-01 | 2022-01-02 |  | 111d |  | start no earlier than 2021-12-22 | AMBIENTE ADMINISTRATIVO PROVISIONAL EN DRYWALL(INC. VENTANAS PUERTAS VIDRIOS TECHO CALAMINON Y ACCESORIOS) | 1h | 7,408 | 01.03 | 000000000000004 | 7400 | 7400 |  |  |
| 350 | 5.1.5 | CERCO PERIMETRICO DE MADERA Y TRIPLAY INC. PORTON DE DOS HOJAS | 3d? | 2022-01-01 | 2022-01-06 |  | 109d |  | start no earlier than 2021-12-22 | PEON [72.2%]; OFICIAL [72.2%]; ALAMBRE NEGRO # 8 [13 kg]; CLAVOS PARA MADERA CON CABEZA DE 2 1/2" [390%]; MADERA MACHIHEMBRADA TORNILLO [39000%]; CANDADO DE BRONCE FORTE 60 mm [13000%]; PORTON METALICO [13000%] | 3678.57h | 38,689.23 | 01.04 | 000000000000005 | 68.47 | 8901.1 | 60 | 130 |
| 351 | 5.1.6 | DESMONTAJE DE MATERIAL PREFABRICADO AL FINAL DE OBRA | 3d? | 2022-01-01 | 2022-01-06 |  | 109d |  | start no earlier than 2021-12-22 | OPERARIO [41.7%]; PEON [83.3%] | 30h | 1,193.23 | 01.06 | 000000000000006 | 605.43 | 605.43 | 0.4 |  |

| ID | WBS | Task | Duration | Start | Finish | Predecessors | Total slack | Constraint | Resources | Work | Cost | Text1 | Text8 | Text3 | Text4 |
| --- | --- | --- | --- | --- | --- | --- | --- | --- | --- | --- | --- | --- | --- | --- | --- |
| 352 | 5.2 | **INSTALACIONES SANITARIAS** | 1d? | 2022-01-01 | 2022-01-02 | 2SS | 111d |  |  | 43h | 16,002.76 | 02 | 000000000000007 |  |  |
| 353 | 5.2.1 | SERVICIOS HIGIÉNICOS PORTATIL (INICIAL, PRIMARIA Y DOCENTES) | 1d? | 2022-01-01 | 2022-01-02 |  | 111d | start no earlier than 2021-12-22 | BAÑO PORTATIL INICIAL [1000%]; BAÑO PORTATIL PRIMARIA [1000%]; BAÑO PORTATIL DOCENTES [500%] | 25h | 13,950 | 02.01 | 000000000000019 | 2750 | 13750 |
| 354 | 5.2.2 | SUMINISTRO E INSTALACION DE LAVATORIOS CON PEDAL INC. TANQUE ELEVADO DE 1100 LTS. | 1d? | 2022-01-01 | 2022-01-02 |  | 111d | start no earlier than 2021-12-22 | OPERARIO [50%]; PEON [50%]; LAVADERO CON PEDAL INC. BASE METALICA [300%]; SUMINISTRO E INSTALACION DE TANQUE ELEVADO DE 1100 LTS Y ACCES.; TUBO ABASTO ESPIGA COBRE TERM/H-H 1/2" X 1/2" 30 cm [300%]; GRIFERIA PARA LAVADERO DE ACERO INOXIDABLE [300%] | 18h | 2,052.76 | 02.02 | 000000000000009 | 1806.76 | 1806.76 |
| 355 | 5.3 | **INSTALACIONES ELECTRICAS** | 1d? | 2022-01-01 | 2022-01-02 | 2SS | 111d |  |  | 8h | 1,714 | 03 | 000000000000010 |  |  |
| 356 | 5.3.1 | INST. ELECTRICAS EN GENERAL INCL. CABLES Y ACCESORIOS. | 1d? | 2022-01-01 | 2022-01-02 |  | 111d | start no earlier than 2021-12-22 | INST. ELECTRICAS GENERAL INC. CABLES Y ACCESORIOS. | 8h | 1,714 | 03.01 | 000000000000011 | 1650 | 1650 |
| 357 | 5.4 | **VARIOS** | 1d? | 2022-01-01 | 2022-01-02 | 2SS | 111d |  |  | 26h | 5,874.88 | 03.02 | 000000000000012 |  |  |
| 358 | 5.4.1 | FLETE TERRESTRE | 1d? | 2022-01-01 | 2022-01-02 |  | 111d | start no earlier than 2021-12-22 | FLETE | 1h | 3,508 | 03.02.01 | 000000000000013 | 3500 | 3500 |
| 359 | 5.4.2 | DESMONTAJE FINAL DE AULAS PREFABRICADAS INC. TRASLADO A ALMACEN. | 1d? | 2022-01-01 | 2022-01-02 |  | 111d | start no earlier than 2021-12-22 | TRASLADO DE AULAS A ALMACEN [12.5%]; OFICIAL; PEON [200%] | 25h | 2,366.88 | 03.02.02 | 000000000000014 | 1929.44 | 1929.44 |
